# KAUST PERIMETER SECURITY SYSTEMS

Schedule from Primavera P6, 2013-01-27 to 2015-10-30, data date 2014-04-06, costs in USD, A marks actual dates.
Must finish by 2015-10-30

## Calendars

- 7-Day Workweek: Mon-Sun 08:00-12:00, 13:00-17:00.

## Resources

| Resource | Group | Rate |
| --- | --- | --- |
| Procurement | labor | 1 |
| Labour | labor | 1 |
| Engineer | labor | 1 |
| Supervisor | labor |  |
| Mobile Crane | labor | 1 |
| Engineering | labor | 1 |
| Grader | labor | 1 |
| Surveyor | labor | 1 |
| Lumpsum | material |  |
| Dump Truck | labor | 1 |
| Compactor | labor |  |
| Concrete Pump | labor | 1 |
| Steel Fixer | labor | 1 |
| CARPANTER | labor | 1 |
| Loader | labor | 1 |
| Excavator | equipment |  |
| Technician | labor |  |

## Schedule

| ID | WBS | Activity | Type | Duration | Start | Finish | Predecessors | Complete | Planned start | Planned finish | Total float | Free float | Constraint |
| --- | --- | --- | --- | --- | --- | --- | --- | --- | --- | --- | --- | --- | --- |
|  | 1 | **GENERAL** |  |  | 2013-01-27 | 2015-10-30 |  |  |  |  |  |  |  |
|  | 1 | **MILESTONES** |  |  | 2013-01-27 | 2015-10-30 |  |  |  |  |  |  |  |
|  | 1 | **CONTRACT MILESTONES** |  |  | 2013-01-27 | 2015-10-30 |  |  |  |  |  |  |  |
| MS-1000 |  | CONTRACT AWARD DATE | milestone | 0d | 2013-01-27 A | 2013-01-27 A |  | 100% |  |  |  |  |  |
| MS-1060 |  | SUBMISSION OF PROJECT EXECUTION PLAN | milestone | 0d | 2013-07-07 A | 2013-07-07 A | MS-1000 FS+76.25d | 100% |  |  |  |  |  |
| MS-1070 |  | SUBMISSION OF PROCUREMENT PLAN AND QUALITY | milestone | 0d | 2013-07-07 A | 2013-07-07 A | MS-1000 FS+76.25d, MS-1060 FF | 100% |  |  |  |  |  |
| MS-1080 |  | SUBMISSION OF WORK SCHEDULE | milestone | 0d | 2013-07-07 A | 2013-07-07 A | MS-1000 FS+76.25d, MS-1070 FF, MS-1010, MS-1020 | 100% |  |  |  |  |  |
| MS-1090 |  | APPROVAL OF WORK SCHEDULE | milestone | 0d | 2013-07-07 A | 2013-07-07 A | MS-1080 FS+126.25d | 100% |  |  |  |  |  |
| MS-1040 |  | SUBMISSION OF GEO TECHNICAL INVESTIGATION REPORT | milestone | 0d | 2013-07-28 A | 2013-07-28 A | MS-1000 FS+228.75d | 100% |  |  |  |  |  |
| MS-1100 |  | ISSUE 50% DESIGN PACKAGE | milestone | 0d | 2013-07-31 A | 2013-07-31 A | ED-1050, MS-1090 FS+30d | 100% |  |  |  |  |  |
| MS-1050 |  | COMPLETE ENVIRONMENTAL IMPACT ASSESSMENT | milestone | 0d | 2013-08-06 A | 2013-08-06 A | MS-1000 FS+240d | 100% |  |  |  |  |  |
| MS-1030 |  | SITE SURVEYS COMPLETED | milestone | 0d | 2013-09-02 A | 2013-09-02 A | MS-1000 FS+273.75d | 100% |  |  |  |  |  |
| MS-1010 |  | COMPLETE MOBILIZATION | milestone | 0d | 2013-09-26 A | 2013-09-26 A | MOB1130, MOB1210, MOB1140, CSP1050 | 100% |  |  |  |  |  |
| MS-1020 |  | COMPLETE TEMPORARY SITE OFFICES | milestone | 0d | 2013-09-26 A | 2013-09-26 A | CSP1050, MS-1030, MS-1040 | 100% |  |  |  |  |  |
| MS-1110 |  | ISSUE 90% DESIGN PACKAGE | milestone | 0d | 2013-10-03 A | 2013-10-03 A | ED-1110, MS-1100 | 100% |  |  |  |  |  |
| MS-1120 |  | ISSUE 100% DESIGN PACKAGE | milestone | 0d | 2014-02-13 A | 2014-02-13 A | ED-1170 FF, MS-1110 FS+25d | 100% | 2014-02-15 | 2014-02-15 |  |  | finish on 2014-02-15 |
| MS-1130 |  | FACTORY ACCEPTANCE TEST FOR SECURITY SYSTEM COMPLETED | milestone | 0d | 2014-10-13 | 2014-10-13 | MS-1110 FS+375d |  |  |  | 0d |  |  |
| MS-1140 |  | COMPLETE PO PLACEMENT OF ALL BULK MATERIAL | milestone | 0d | 2014-11-20 | 2014-11-20 | MS-1130 FS+38d |  |  |  | 0d |  |  |
| MS-1150 |  | ALL MATERIAL DELIVERED TO WORK SITE | milestone | 0d | 2015-07-16 | 2015-07-16 | MS-1000 FS+898.75d, MS-1140 FS+238d, DTS1150 FS+20d |  |  |  | 0d |  |  |
| MS-1160 |  | COMPLETE SPARE PARTS DATA PACKAGES FOR ALL EQUIPMENT | milestone | 0d | 2015-08-22 | 2015-08-22 | MS-1220 FS+18.75d, MS-1150 FS+37d |  |  |  | 0d |  |  |
| MS-1170 |  | SUBMITTAL OF ALL DOCUMENTATION REQUIREMENTS | milestone | 0d | 2015-09-04 | 2015-09-04 | MS-1210, MS-1220, MS-1230, MS-1240, MS-1160 FS+12.5d |  |  |  | 0d | 0.25d |  |
| MS-1180 |  | COMPLETE PERFORMANCE ACCEPTANCE FOR ALL WORK | milestone | 0d | 2015-10-01 | 2015-10-01 | PRC-1050 |  |  |  | -0.25d | 0d |  |
| MS-1190 |  | COMPLETE DEMOBILIZATION | milestone | 0d | 2015-10-30 | 2015-10-30 | DMOB-1000, MS-1170 FS+56d |  |  |  | -0.25d | 0d |  |
| MS-1200 |  | SCHEDULE COMPLETION DATE/FINAL SYSTEM ACCEPTANCE | milestone | 0d | 2015-10-30 | 2015-10-30 | MS-1220 FS+43.75d, MS-1210 FF+75d, MS-1180 FS+29.5d, MS-1120, DMOB-1010, MS-1190 |  |  |  | -0.25d | 0d |  |

| ID | WBS | Activity | Type | Duration | Start | Finish | Predecessors | Complete | Total float | Free float | Resources | Cost | Devision-01 |
| --- | --- | --- | --- | --- | --- | --- | --- | --- | --- | --- | --- | --- | --- |
|  | 2 | **CONSTRUCTION MILESTONES** |  |  | 2015-06-23 | 2015-08-17 |  |  |  |  |  |  |  |
| MS-1240 |  | COMPLETE CONSTRUCTION OF SECURITY DITCH | milestone | 0d | 2015-06-23 | 2015-06-23 | ZBDI-1080, ZCDI-1080, CCG-4-1040 FS+187.5d |  | 0d |  |  |  |  |
| MS-1220 |  | COMPLETE CONSTRUCTION OF SECURITY SYSTEM | milestone | 0d | 2015-08-03 | 2015-08-03 | BAIS-1010, CSF-1020, VBA-1010 FS+87.5d, MCZC-1000 FS+20d, EPS1020 FS+137.5d, LPZD-1010, EATS-1010, MCZA-1000 FS+20d, MCZB-1000, CDBZA-1050 FS+112.5d, CDBZB-1050 FS+30d |  | 0.25d |  |  |  |  |
| MS-1210 |  | COMPLETE CONSTRUCTION OF ALL BUILDINGS AND SECURITY GATES | milestone | 0d | 2015-08-10 | 2015-08-10 | CBAPG-1310 FS+200d, CBATS-1310, BBS1040 FS+20d, BSS-1010, CBAJFC-1310 FS+150d, CBAQRT-1320 FS+90d, CBAUPS-1320 FS+130d, CBMUPS-1250 FS+100d, CBEUPS-1160, KAR-2-1070 FS+230d, LAND-1040 FS+31.25d, ESG-1010 FS+30d, LPZB-1010 FS+30d, CBMJFC-1250 FS+150d, CCG-2-1040, ZBPR-1070 |  | 0.25d | 0d |  |  |  |
| MS-1230 |  | COMPLETE CONSTRUCTION OF PERIMETER FENCE | milestone | 0d | 2015-08-17 | 2015-08-17 | ZBF-1170, ZBF-1230, ZCF-1290, ZCF-1350, ZDF-1410, ZDF-1470, ZAF-1110, ZAF-1050, LPZA-1010 FS+56.25d, ZAMR-1070 FS+87.5d, ZAPR-1070 FS+112.5d, ZBMR-1070 FS+30d, ZDMR-1070 |  | -0.25d | 0d |  |  |  |
|  | 2 | **MOBILIZATION** |  |  | 2013-03-28 | 2013-09-26 |  |  |  |  |  |  |  |
|  | 1 | **TEMPORARY SITE OFFICES** |  |  | 2013-03-28 | 2013-09-26 |  |  |  |  |  |  |  |
| CSP1000 |  | REMOVING OF DEBRIS & LEVELING |  | 18.75d | 2013-03-28 A | 2013-04-11 A | MS-1000 FS+75d | 100% |  |  | Labour [4649 h] | 4,649 | MOB |
| CSP1010 |  | TEMPORARY SAFETY FENCES |  | 37.5d | 2013-04-12 A | 2013-05-11 A | CSP1000 | 100% |  |  | Labour [13481 h] | 13,481 | MOB |
| CSP1020 |  | SITE OFFICES CONTRACTOR |  | 75d | 2013-05-12 A | 2013-07-10 A | CSP1010 | 100% |  |  | Labour [13481 h] | 13,481 | MOB |
| CSP1030 |  | WHERE HOUSE AND JUNK YARD |  | 50d | 2013-07-27 A | 2013-09-04 A | CSP1020 FS+20d | 100% |  |  | Labour [11157 h] | 11,157 | MOB |
| CSP1040 |  | CARS PARKING AREA & SUNSHADES |  | 45d | 2013-08-16 A | 2013-09-20 A | CSP1030 FF+20d | 100% |  |  | Labour [6973 h] | 6,973 | MOB |
| CSP1050 |  | OTHER UTILITIES |  | 52.5d | 2013-08-16 A | 2013-09-26 A | CSP1040 FF+6.25d, MOB1140 FF, MOB1210 FF | 100% |  |  | Labour [1581 h] | 1,581 | MOB |
|  | 3 | **EQUIPMENTS** |  |  | 2013-07-18 | 2013-09-10 |  |  |  |  |  |  |  |
| MOB1150 |  | LIFTING EQUIPMENTS |  | 25d | 2013-07-18 A | 2013-08-06 A | MOB1040 FS+77.5d, MS-1050 FF | 100% |  |  | Procurement [841 h] | 841 | MOB |
| MOB1160 |  | TRUCKS/TRAILERS |  | 25d | 2013-07-18 A | 2013-08-06 A | MOB1040 FS+77.5d, MOB1150 FF | 100% |  |  | Procurement [841 h] | 841 | MOB |
| MOB1170 |  | EARTH MOVERS |  | 15d | 2013-08-06 A | 2013-08-17 A | MOB1160 FS-1.25d | 100% |  |  | Procurement [841 h] | 841 | MOB |
| MOB1180 |  | COMPACTORS |  | 15d | 2013-08-18 A | 2013-08-29 A | MOB1170 | 100% |  |  | Procurement [841 h] | 841 | MOB |
| MOB1190 |  | COMPRESSOR/WELDERS |  | 15d | 2013-08-30 A | 2013-09-10 A | MOB1180 | 100% |  |  | Procurement [841 h] | 841 | MOB |
| MOB1200 |  | CONCRETE EQUIPMENT |  | 15d | 2013-08-30 A | 2013-09-10 A | MOB1190 FF | 100% |  |  | Procurement [841 h] | 841 | MOB |
| MOB1210 |  | GENERATORS/LIGHT TOWERS |  | 15d | 2013-08-30 A | 2013-09-10 A | MOB1200 FF | 100% |  |  | Procurement [841 h] | 841 | MOB |
|  | 2 | **MAN POWER** |  |  | 2013-04-27 | 2013-09-26 |  |  |  |  |  |  |  |
| MOB1040 |  | QA/QC MANAGER |  | 25d | 2013-04-27 A | 2013-05-16 A | CSP1000 FS+18.75d | 100% |  |  | Procurement [539 h] | 539 | MOB |
| MOB1090 |  | QC DOCUMENTS CONTROLLER |  | 25d | 2013-05-07 A | 2013-05-26 A | MOB1040 FF+12.5d | 100% |  |  | Procurement [539 h] | 539 | MOB |
| MOB1050 |  | PLANNER/SCHEDULER |  | 25d | 2013-05-17 A | 2013-06-05 A | MOB1040 | 100% |  |  | Procurement [539 h] | 539 | MOB |
| MOB1060 |  | QC CIVIL INSPECTOR |  | 25d | 2013-05-17 A | 2013-06-05 A | MOB1040, MOB1050 FF | 100% |  |  | Procurement [539 h] | 539 | MOB |
| MOB1070 |  | QC MECHANICAL INSPECTOR |  | 25d | 2013-05-17 A | 2013-06-05 A | MOB1040 | 100% |  |  | Procurement [539 h] | 539 | MOB |
| MOB1080 |  | QC ELECTRICAL INSPECTOR |  | 25d | 2013-05-17 A | 2013-06-05 A | MOB1040 | 100% |  |  | Procurement [539 h] | 539 | MOB |
| MOB1120 |  | QC PROCUREMENT SUPERVISOR |  | 25d | 2013-05-17 A | 2013-06-05 A | MOB1040 | 100% |  |  | Procurement [539 h] | 539 | MOB |
| MOB1100 |  | HSE MANAGER |  | 25d | 2013-05-27 A | 2013-06-15 A | MOB1090 | 100% |  |  | Procurement [539 h] | 539 | MOB |
| MOB1110 |  | SAFETY OFFICER |  | 25d | 2013-06-16 A | 2013-07-05 A | MOB1100 | 100% |  |  | Procurement [539 h] | 539 | MOB |
| MOB1130 |  | PROCUREMENT MANAGER |  | 25d | 2013-07-26 A | 2013-08-14 A | MOB1080 FS+62.5d, MOB1060, MOB1070, MOB1110, MOB1120 | 100% |  |  | Procurement [539 h] | 539 | MOB |
| MOB1140 |  | MATERIAL ENGINEER |  | 25d | 2013-09-07 A | 2013-09-26 A | MOB1090 FS+78.75d, MOB1130 FF+53.75d | 100% |  |  | Procurement [539 h] | 539 | MOB |

| ID | WBS | Activity | Duration | Start | Finish | Predecessors | Complete | Planned start | Planned finish | Resources | Cost | Actual cost | Devision-01 |
| --- | --- | --- | --- | --- | --- | --- | --- | --- | --- | --- | --- | --- | --- |
|  | 5 | **ENGINEERING** |  | 2013-04-02 | 2014-03-31 |  |  |  |  |  |  |  |  |
|  | 1 | **DESIGNING** |  | 2013-04-02 | 2014-03-31 |  |  |  |  |  |  |  |  |
|  | 1 | **50% COMPLETION** |  | 2013-04-02 | 2013-10-11 |  |  |  |  |  |  |  |  |
| ED-1000 |  | FRONT & ENGINEERING DESIGN (50%) | 20d | 2013-04-02 A | 2013-05-16 A | MS-1000 FS+2.5d | 100% | 2013-03-02 | 2013-03-17 | Engineering [2753 h] | 2,753 |  | ENG |
| ED-1010 |  | DETAIL DESIGN (50%) | 75d | 2013-05-16 A | 2013-08-13 A | ED-1000 | 100% | 2013-03-18 | 2013-05-31 | Engineering [16898 h] | 16,898 | 16,898 | ENG |
| ED-1020 |  | REVIEW FOR ARAMCO (50%) | 17.5d | 2013-08-14 A | 2013-09-01 A | ED-1010 | 100% | 2013-05-17 | 2013-06-03 | Engineering [584 h] | 584 | 584 | ENG |
| ED-1030 |  | LIST OF CONFLICT (50%) | 17.5d | 2013-09-02 A | 2013-09-14 A | ED-1020 | 100% | 2013-05-31 | 2013-06-13 | Engineering [1691 h] | 1,691 |  | ENG |
| ED-1040 |  | REVISION (50%) | 37.5d | 2013-09-15 A | 2013-09-29 A | ED-1030 | 100% | 2013-06-14 | 2013-07-13 | Engineering [4451 h] | 4,451 |  | ENG |
| ED-1050 |  | APPROVAL (50%) | 22.5d | 2013-09-30 A | 2013-10-11 A | ED-1040 | 100% | 2013-07-14 | 2013-07-31 | Engineering [1134 h] | 1,134 |  | ENG |
|  | 2 | **90% COMPLETION** |  | 2013-09-01 | 2014-02-27 |  |  |  |  |  |  |  |  |
| ED-1060 |  | FRONT & ENGINEERING DESIGN (90%) | 8.75d | 2013-09-01 A | 2013-09-07 A | ED-1050 | 100% | 2013-08-01 | 2013-08-07 | Engineering [1720 h] | 1,720 |  | ENG |
| ED-1070 |  | DETAIL DESIGN (90%) | 37.5d | 2013-09-08 A | 2013-12-29 A | ED-1060 | 100% | 2013-08-08 | 2013-09-14 | Engineering [10566 h] | 10,566 | 10,566 | ENG |
| ED-1080 |  | REVIEW FOR ARAMCO (90%) | 8.75d | 2013-12-19 A | 2014-01-06 A | ED-1070 FF+8.75d | 100% | 2013-09-07 | 2013-09-15 | Engineering [548 h] | 548 | 548 | ENG |
| ED-1090 |  | LIST OF CONFLICT (90%) | 6.25d | 2014-01-07 A | 2014-01-16 A | ED-1080 FF+5d | 100% | 2013-09-13 | 2013-09-17 | Engineering [1492 h] | 1,492 |  | ENG |
| ED-1100 |  | REVISION (90%) | 15d | 2014-01-18 A | 2014-02-19 A | ED-1090 | 100% | 2013-09-18 | 2013-09-29 | Engineering [2632 h] | 2,632 |  | ENG |
| ED-1110 |  | APPROVAL (90%) | 5d | 2014-02-20 A | 2014-02-27 A | ED-1100 | 100% | 2013-09-30 | 2013-10-03 | Engineering [242 h] | 242 |  | ENG |
|  | 3 | **100% COMPLETION** |  | 2014-02-06 | 2014-03-31 |  |  |  |  |  |  |  |  |
| ED-1120 |  | FRONT & ENGINEERING DESIGN (100%) | 6.25d | 2014-02-06 A | 2014-02-12 A | ED-1110 | 100% | 2013-10-04 | 2013-10-08 | Engineering [352 h] | 352 | 352 | ENG |
| ED-1130 |  | DETAIL DESIGN (100%) | 12.5d | 2014-02-10 A | 2014-02-27 A | ED-1120 | 100% | 2013-10-09 | 2013-10-18 | Engineering [1315 h] | 1,315 | 1,315 | ENG |
| ED-1140 |  | REVIEW FOR ARAMCO (100%) | 8.75d | 2014-02-27 A | 2014-03-06 A | ED-1130 | 100% | 2013-12-15 | 2013-12-21 | Engineering [223 h] | 223 |  | ENG |
| ED-1150 |  | LIST OF CONFLICT (100%) | 6.25d | 2014-03-06 A | 2014-03-13 A | ED-1140 FF | 100% | 2013-12-02 | 2013-12-06 | Engineering [117 h] | 117 |  | ENG |
| ED-1160 |  | REVISION (100%) | 5d | 2014-03-13 A | 2014-03-23 A | ED-1150 | 100% | 2013-12-07 | 2013-12-10 | Engineering [310 h] | 310 |  | ENG |
| ED-1170 |  | APPROVAL (100%) | 10d | 2014-03-24 A | 2014-03-31 A | ED-1160 FF+7.5d | 100% | 2013-12-16 | 2013-12-25 | Engineering [70 h] | 70 |  | ENG |
|  | 6 | **PROCUREMENT** |  | 2013-09-01 | 2015-06-23 |  |  |  |  |  |  |  |  |
|  | 1 | **PROCUREMENT PLAN** |  | 2013-09-01 | 2014-09-09 |  |  |  |  |  |  |  |  |
|  | 1 | **MATERIAL SUBMITTALS** |  | 2013-09-01 | 2014-01-26 |  |  |  |  |  |  |  |  |
|  | 1 | **CIVIL & ARCHITECTURAL** |  | 2013-10-04 | 2013-11-22 |  |  |  |  |  |  |  |  |
| MSC1000 |  | SECURITY FENCE | 6.25d | 2013-10-04 A | 2013-10-08 A | ED-1110 | 100% |  |  | Procurement [5138 h] | 5,138 |  |  |
| MSC1010 |  | JFC BUILDING | 6.25d | 2013-10-09 A | 2013-10-13 A | MSC1000 | 100% |  |  | Procurement [4906 h] | 4,906 |  |  |
| MSC1020 |  | QRT BUILDING | 6.25d | 2013-10-14 A | 2013-10-18 A | MSC1010 | 100% |  |  | Procurement [5153 h] | 5,153 |  |  |
| MSC1030 |  | GUARD HOUSE (WADI) | 6.25d | 2013-10-19 A | 2013-10-23 A | MSC1020 | 100% |  |  | Procurement [5246 h] | 5,246 |  |  |
| MSC1040 |  | UPS BUILDING | 6.25d | 2013-10-24 A | 2013-10-28 A | MSC1030 | 100% |  |  | Procurement [4949 h] | 4,949 |  |  |
| MSC1050 |  | GATE HOUSE 2&3 INCLUDING PARKING,BUS STOP SHADE | 6.25d | 2013-10-29 A | 2013-11-02 A | MSC1040 | 100% |  |  | Procurement [4814 h] | 4,814 |  |  |
| MSC1060 |  | VISITORS CENTER | 6.25d | 2013-11-03 A | 2013-11-07 A | MSC1050 | 100% |  |  | Procurement [5076 h] | 5,076 |  |  |
| MSC1070 |  | GUARD HOUSE MARINE | 6.25d | 2013-11-08 A | 2013-11-12 A | MSC1060 | 100% |  |  | Procurement [5110 h] | 5,110 |  |  |
| MSC1080 |  | TURNSTILE & X-RAY BUILDING | 6.25d | 2013-11-13 A | 2013-11-17 A | MSC1070 | 100% |  |  | Procurement [4875 h] | 4,875 |  |  |
| MSC1090 |  | GENERATOR BUILDING | 6.25d | 2013-11-18 A | 2013-11-22 A | MSC1080 | 100% |  |  | Procurement [5832 h] | 5,832 |  |  |

| ID | WBS | Activity | Duration | Start | Finish | Predecessors | Complete | Planned start | Planned finish | Resources | Cost | Actual cost |
| --- | --- | --- | --- | --- | --- | --- | --- | --- | --- | --- | --- | --- |
|  | 2 | **MEP** |  | 2013-11-07 | 2013-11-24 |  |  |  |  |  |  |  |
| MSM1000 |  | JFC BUILDING | 2.5d | 2013-11-07 A | 2013-11-08 A | MSC1060 FF+1.25d | 100% |  |  | Procurement [3518 h] | 3,518 |  |
| MSM1010 |  | QRT BUILDING | 2.5d | 2013-11-09 A | 2013-11-10 A | MSM1000 | 100% |  |  | Procurement [3703 h] | 3,703 |  |
| MSM1020 |  | GUARD HOUSE (WADI) | 2.5d | 2013-11-11 A | 2013-11-12 A | MSM1010 | 100% |  |  | Procurement [4073 h] | 4,073 |  |
| MSM1030 |  | UPS BUILDING | 2.5d | 2013-11-13 A | 2013-11-14 A | MSM1020 | 100% |  |  | Procurement [3271 h] | 3,271 |  |
| MSM1040 |  | GATE HOUSE 2&3 INCLUDING PARKING,BUS STOP SHADE | 2.5d | 2013-11-15 A | 2013-11-16 A | MSM1030 | 100% |  |  | Procurement [3120 h] | 3,120 |  |
| MSM1050 |  | VISITORS CENTER | 2.5d | 2013-11-17 A | 2013-11-18 A | MSM1040 | 100% |  |  | Procurement [3116 h] | 3,116 |  |
| MSM1060 |  | GUARD HOUSE MARINE | 2.5d | 2013-11-19 A | 2013-11-20 A | MSM1050 | 100% |  |  | Procurement [3116 h] | 3,116 |  |
| MSM1070 |  | TURNSTILE & X-RAY BUILDING | 2.5d | 2013-11-21 A | 2013-11-22 A | MSM1060 | 100% |  |  | Procurement [3379 h] | 3,379 |  |
| MSM1080 |  | GENERATOR BUILDING | 2.5d | 2013-11-23 A | 2013-11-24 A | MSM1070 | 100% |  |  | Procurement [3363 h] | 3,363 |  |
|  | 3 | **TELECOM & SECURITY** |  | 2013-09-01 | 2013-11-30 |  |  |  |  |  |  |  |
| MSTS1140 |  | CARGO SCREENING SYSTEM | 6.25d | 2013-09-01 A | 2013-09-05 A | MSTS1130 FF | 100% | 2014-02-05 | 2014-02-11 | Procurement [1003 h] | 1,003 | 1,003 |
| MSTS1100 |  | RADAR SYSTEM | 6.25d | 2013-09-05 A | 2013-09-12 A | MSTS1080 | 100% | 2013-11-28 | 2013-12-02 | Procurement [926 h] | 926 |  |
| MSTS1110 |  | VESSEL BARRIER | 6.25d | 2013-09-05 A | 2013-09-12 A | MSTS1100 | 100% | 2013-12-03 | 2013-12-09 | Procurement [972 h] | 972 | 972 |
| MSTS1150 |  | CCTV CAMERAS | 6.25d | 2013-09-05 A | 2013-09-12 A | MSTS1140 FF | 100% | 2014-02-05 | 2014-02-11 | Procurement [997 h] | 997 | 997 |
| MSTS1130 |  | DROP ARM SYSTEM | 6.25d | 2013-10-06 A | 2013-10-13 A | MSTS1120 | 100% | 2014-02-05 | 2014-02-11 | Procurement [987 h] | 987 | 987 |
| MSTS1120 |  | SONAR SYSTEM | 6.25d | 2013-10-31 A | 2013-11-07 A | MSTS1110 | 100% | 2014-01-30 | 2014-02-05 | Procurement [1065 h] | 1,065 | 1,065 |
| MSTS1010 |  | JFC BUILDING | 16.25d | 2013-11-15 A | 2013-11-27 A | MSM1030 | 100% |  |  | Procurement [895 h] | 895 |  |
| MSTS1000 |  | SECURITY FENCE | 3.75d | 2013-11-25 A | 2013-11-27 A | MSM1080 | 100% | 2013-11-25 | 2013-11-28 | Procurement [957 h] | 957 |  |
| MSTS1020 |  | QRT BUILDING | 3.75d | 2013-11-25 A | 2013-11-27 A | MSM1080 | 100% |  |  | Procurement [926 h] | 926 |  |
| MSTS1030 |  | GUARD HOUSE (WADI) | 3.75d | 2013-11-25 A | 2013-11-27 A | MSM1080 | 100% |  |  | Procurement [864 h] | 864 |  |
| MSTS1040 |  | UPS BUILDING | 3.75d | 2013-11-25 A | 2013-11-27 A | MSM1080 | 100% |  |  | Procurement [1049 h] | 1,049 |  |
| MSTS1050 |  | GATE HOUSE 2&3 INCLUDING PARKING,BUS STOP SHADE | 3.75d | 2013-11-25 A | 2013-11-27 A | MSM1080 | 100% |  |  | Procurement [910 h] | 910 |  |
| MSTS1060 |  | VISITORS CENTER | 3.75d | 2013-11-25 A | 2013-11-27 A | MSM1080 | 100% |  |  | Procurement [957 h] | 957 |  |
| MSTS1070 |  | GUARD HOUSE MARINE | 3.75d | 2013-11-25 A | 2013-11-27 A | MSM1080 | 100% |  |  | Procurement [926 h] | 926 |  |
| MSTS1080 |  | TURNSTILE & X-RAY BUILDING | 3.75d | 2013-11-25 A | 2013-11-27 A | MSM1080 | 100% |  |  | Procurement [910 h] | 910 |  |
| MSTS1090 |  | GENERATOR BUILDING | 3.75d | 2013-11-28 A | 2013-11-30 A | MSTS1080 | 100% |  |  | Procurement [987 h] | 987 |  |

| ID | WBS | Activity | Duration | Start | Finish | Predecessors | Complete | Planned start | Planned finish | Resources | Cost | Actual cost |
| --- | --- | --- | --- | --- | --- | --- | --- | --- | --- | --- | --- | --- |
|  | 4 | **LANDSCAPING** |  | 2013-10-11 | 2014-01-26 |  |  |  |  |  |  |  |
| MSL1000 |  | IRRIGATION SYSTEM | 2.5d | 2013-10-11 A | 2013-10-12 A | MSTS1150 | 100% |  |  | Procurement [728 h] | 728 |  |
| MSL1010 |  | IRRIGATION CONTROL SYSTEM | 2.5d | 2013-11-07 A | 2013-12-01 A | MSTS1150 | 100% | 2014-02-11 | 2014-02-14 | Procurement [710 h] | 710 | 710 |
| MSL1020 |  | JUNCTION BOXES | 2.5d | 2013-11-07 A | 2013-12-01 A | MSTS1150 | 100% | 2014-02-11 | 2014-02-14 | Procurement [725 h] | 725 | 725 |
| MSL1030 |  | SOFTSCAPING FINISHING | 2.5d | 2013-12-11 A | 2014-01-14 A | MSTS1150 | 100% | 2014-02-11 | 2014-02-14 | Procurement [741 h] | 741 | 741 |
| MSL1040 |  | HARDSCAPING FINISHING | 2.5d | 2013-12-11 A | 2014-01-16 A | MSL1030 | 100% | 2014-02-14 | 2014-02-16 | Procurement [707 h] | 707 | 707 |
| MSL1050 |  | WATER PUMPS | 2.5d | 2014-01-24 A | 2014-01-26 A | MSL1030 | 100% |  |  | Procurement [790 h] | 790 | 790 |
| MSL1060 |  | WATER FEATURES | 2.5d | 2014-01-24 A | 2014-01-26 A | MSL1030 | 100% |  |  | Procurement [710 h] | 710 | 710 |
|  | 2 | **MATERIAL APPROVAL** |  | 2013-10-09 | 2014-09-09 |  |  |  |  |  |  |  |
|  | 2 | **CIVIL & ARCHITECTURAL** |  | 2013-10-09 | 2013-12-06 |  |  |  |  |  |  |  |
| MAC1000 |  | SECURITY FENCE | 12.5d | 2013-10-09 A | 2013-10-18 A | MSC1000 | 100% |  |  | Procurement [1512 h] | 1,512 |  |
| MAC1010 |  | JFC BUILDING | 12.5d | 2013-10-14 A | 2013-10-23 A | MSC1010 | 100% |  |  | Procurement [1419 h] | 1,419 |  |
| MAC1020 |  | QRT BUILDING | 12.5d | 2013-10-20 A | 2013-10-29 A | MSC1020 FS+1.25d | 100% |  |  | Procurement [1203 h] | 1,203 |  |
| MAC1030 |  | GUARD HOUSE (WADI) | 12.5d | 2013-10-26 A | 2013-11-04 A | MSC1030 FS+2.5d | 100% |  |  | Procurement [1203 h] | 1,203 |  |
| MAC1040 |  | UPS BUILDING | 12.5d | 2013-11-01 A | 2013-11-10 A | MSC1040 FS+3.75d | 100% |  |  | Procurement [1142 h] | 1,142 |  |
| MAC1050 |  | GATE HOUSE 2&3 INCLUDING PARKING,BUS STOP SHADE | 12.5d | 2013-11-07 A | 2013-11-16 A | MSC1050 FS+5d | 100% |  |  | Procurement [1234 h] | 1,234 |  |
| MAC1060 |  | VISITORS CENTER | 12.5d | 2013-11-13 A | 2013-11-22 A | MSC1060 FS+6.25d | 100% |  |  | Procurement [1234 h] | 1,234 |  |
| MAC1070 |  | GUARD HOUSE MARINE | 12.5d | 2013-11-19 A | 2013-11-28 A | MSC1070 FS+7.5d | 100% |  |  | Procurement [1203 h] | 1,203 |  |
| MAC1080 |  | TURNSTILE & X-RAY BUILDING | 12.5d | 2013-11-25 A | 2013-12-04 A | MSC1080 FS+8.75d | 100% |  |  | Procurement [1389 h] | 1,389 |  |
| MAC1090 |  | GENERATOR BUILDING | 12.5d | 2013-11-30 A | 2013-12-06 A | MSC1090 FS+8.75d | 100% | 2013-11-30 | 2013-12-09 | Procurement [1234 h] | 1,234 |  |
|  | 3 | **MEP** |  | 2013-11-09 | 2013-11-30 |  |  |  |  |  |  |  |
| MAM1000 |  | JFC BUILDING | 7.5d | 2013-11-09 A | 2013-11-14 A | MSM1000 | 100% |  |  | Procurement [833 h] | 833 |  |
| MAM1010 |  | QRT BUILDING | 7.5d | 2013-11-11 A | 2013-11-16 A | MSM1010 | 100% |  |  | Procurement [895 h] | 895 |  |
| MAM1020 |  | GUARD HOUSE (WADI) | 7.5d | 2013-11-13 A | 2013-11-18 A | MSM1020 | 100% |  |  | Procurement [818 h] | 818 |  |
| MAM1030 |  | UPS BUILDING | 7.5d | 2013-11-15 A | 2013-11-20 A | MSM1030 | 100% |  |  | Procurement [771 h] | 771 |  |
| MAM1040 |  | GATE HOUSE 2&3 INCLUDING PARKING,BUS STOP SHADE | 7.5d | 2013-11-17 A | 2013-11-22 A | MSM1040 | 100% |  |  | Procurement [802 h] | 802 |  |
| MAM1050 |  | VISITORS CENTER | 7.5d | 2013-11-19 A | 2013-11-24 A | MSM1050 | 100% |  |  | Procurement [879 h] | 879 |  |
| MAM1060 |  | GUARD HOUSE MARINE | 7.5d | 2013-11-21 A | 2013-11-26 A | MSM1060 | 100% |  |  | Procurement [833 h] | 833 |  |
| MAM1070 |  | TURNSTILE & X-RAY BUILDING | 7.5d | 2013-11-23 A | 2013-11-28 A | MSM1070 | 100% |  |  | Procurement [926 h] | 926 |  |
| MAM1080 |  | GENERATOR BUILDING | 7.5d | 2013-11-25 A | 2013-11-30 A | MSM1080 | 100% |  |  | Procurement [907 h] | 907 |  |

| ID | WBS | Activity | Duration | Start | Finish | Predecessors | Complete | Planned start | Planned finish | Total float | Free float | Resources | Cost | Actual cost |
| --- | --- | --- | --- | --- | --- | --- | --- | --- | --- | --- | --- | --- | --- | --- |
|  | 4 | **TELECOM & SECURITY** |  | 2013-11-18 | 2014-09-09 |  |  |  |  |  |  |  |  |  |
| MATS1010 |  | QRT BUILDING | 7.5d | 2013-11-18 A | 2013-11-23 A | MSTS1010 | 100% |  |  |  |  | Procurement [231 h] | 231 |  |
| MATS1000 |  | JFC BUILDING | 7.5d | 2013-11-28 A | 2013-12-03 A | MSTS1000 | 100% |  |  |  |  | Procurement [231 h] | 231 |  |
| MATS1020 |  | GUARD HOUSE (WADI) | 7.5d | 2013-12-03 A | 2014-01-31 A | MSTS1020 FS+6.25d | 100% | 2013-12-03 | 2013-12-10 |  |  | Procurement [216 h] | 216 | 216 |
| MATS1030 |  | UPS BUILDING | 7.5d | 2014-01-24 A | 2014-01-31 A | MSTS1030 | 100% |  |  |  |  | Procurement [272 h] | 272 | 272 |
| MATS1040 |  | GATE HOUSE 2&3 INCLUDING PARKING,BUS STOP SHADE | 7.5d | 2014-01-24 A | 2014-01-31 A | MSTS1040 FS+6.25d | 100% |  |  |  |  | Procurement [231 h] | 231 | 231 |
| MATS1050 |  | VISITORS CENTER | 7.5d | 2014-01-24 A | 2014-01-31 A | MSTS1050 | 100% |  |  |  |  | Procurement [216 h] | 216 | 216 |
| MATS1060 |  | GUARD HOUSE MARINE | 7.5d | 2014-01-24 A | 2014-01-31 A | MSTS1060 | 100% |  |  |  |  | Procurement [278 h] | 278 | 278 |
| MATS1070 |  | TURNSTILE & X-RAY BUILDING | 7.5d | 2014-01-24 A | 2014-01-31 A | MSTS1070 | 100% |  |  |  |  | Procurement [262 h] | 262 | 262 |
| MATS1080 |  | GENERATOR BUILDING | 7.5d | 2014-01-24 A | 2014-01-31 A | MSTS1080 FS+12.5d | 100% |  |  |  |  | Procurement [247 h] | 247 | 247 |
| MATS1090 |  | SECURITY FENCE | 14d | 2014-06-03 | 2014-06-17 | MSTS1090 FS+63d, MATS1080 FS+123d |  |  |  | 15.5d | 0d | Procurement [262 h] | 262 |  |
| MATS1100 |  | RADAR SYSTEM | 14d | 2014-06-17 | 2014-07-01 | MSTS1100, MATS1090 |  |  |  | 15.5d | 0d | Procurement [216 h] | 216 |  |
| MATS1110 |  | VESSEL BARRIER | 14d | 2014-07-01 | 2014-07-15 | MSTS1110, MATS1100 |  |  |  | 15.5d | 0d | Procurement [231 h] | 231 |  |
| MATS1120 |  | SONAR SYSTEM | 14d | 2014-07-15 | 2014-07-29 | MSTS1120, MATS1110 |  |  |  | 15.5d | 0d | Procurement [259 h] | 259 |  |
| MATS1130 |  | DROP ARM SYSTEM | 14d | 2014-07-29 | 2014-08-12 | MSTS1130, MATS1120 |  |  |  | 15.5d | 0d | Procurement [231 h] | 231 |  |
| MATS1140 |  | CARGO SCREENING SYSTEM | 14d | 2014-08-12 | 2014-08-26 | MSTS1140, MATS1130 |  |  |  | 15.5d | 0d | Procurement [231 h] | 231 |  |
| MATS1150 |  | CCTV CAMERAS | 14d | 2014-08-26 | 2014-09-09 | MSTS1150, MATS1140 |  |  |  | 15.5d | 0d | Procurement [216 h] | 216 |  |
|  | 5 | **LANDSCAPING** |  | 2014-05-01 | 2014-08-07 |  |  |  |  |  |  |  |  |  |
| MAL1000 |  | IRRIGATION SYSTEM | 14d | 2014-05-01 | 2014-05-15 | MSL1000 FS+62.5d, MATS1080 FS+90d |  |  |  | 8d | 0d | Procurement [170 h] | 170 |  |
| MAL1010 |  | IRRIGATION CONTROL SYSTEM | 14d | 2014-05-15 | 2014-05-29 | MSL1010 FS+8.75d, MAL1000 |  |  |  | 8d | 0d | Procurement [173 h] | 173 |  |
| MAL1020 |  | JUNCTION BOXES | 14d | 2014-05-29 | 2014-06-12 | MSL1020 FS+8.75d, MAL1010 |  |  |  | 8d | 0d | Procurement [201 h] | 201 |  |
| MAL1030 |  | SOFTSCAPING FINISHING | 14d | 2014-06-12 | 2014-06-26 | MSL1030, MAL1020 |  |  |  | 8d | 0d | Procurement [170 h] | 170 |  |
| MAL1040 |  | HARDSCAPING FINISHING | 14d | 2014-06-26 | 2014-07-10 | MSL1040, MAL1030 |  |  |  | 8d | 0d | Procurement [170 h] | 170 |  |
| MAL1050 |  | WATER PUMPS | 14d | 2014-07-10 | 2014-07-24 | MSL1050, MAL1040 |  |  |  | 8d | 0d | Procurement [185 h] | 185 |  |
| MAL1060 |  | WATER FEATURES | 14d | 2014-07-24 | 2014-08-07 | MSL1060, MSL1050, MAL1050 |  |  |  | 8d | 0d | Procurement [210 h] | 210 |  |

| ID | WBS | Activity | Duration | Start | Finish | Predecessors | Complete | Total float | Free float | Resources | Cost |
| --- | --- | --- | --- | --- | --- | --- | --- | --- | --- | --- | --- |
|  | 2 | **PURCHASE ORDERS** |  | 2013-10-19 | 2015-01-19 |  |  |  |  |  |  |
|  | 2 | **CIVIL & ARCHITECTURAL** |  | 2013-10-19 | 2014-07-12 |  |  |  |  |  |  |
| POC1000 |  | SECURITY FENCE | 8.75d | 2013-10-19 A | 2013-10-25 A | MAC1000 | 100% |  |  | Procurement [8640 h] | 8,640 |
| POC1010 |  | JFC BUILDING | 8.75d | 2013-10-24 A | 2013-10-30 A | MAC1010 | 100% |  |  | Procurement [8516 h] | 8,516 |
| POC1020 |  | QRT BUILDING | 8.75d | 2013-10-30 A | 2013-11-05 A | MAC1020 | 100% |  |  | Procurement [8609 h] | 8,609 |
| POC1030 |  | GUARD HOUSE (WADI) | 8.75d | 2013-11-05 A | 2013-11-11 A | MAC1030 | 100% |  |  | Procurement [8701 h] | 8,701 |
| POC1040 |  | UPS BUILDING | 8.75d | 2013-11-11 A | 2013-11-17 A | MAC1040 | 100% |  |  | Procurement [8547 h] | 8,547 |
| POC1050 |  | GATE HOUSE 2&3 INCLUDING PARKING,BUS STOP SHADE | 8.75d | 2013-11-17 A | 2013-11-23 A | MAC1050 | 100% |  |  | Procurement [8485 h] | 8,485 |
| POC1060 |  | VISITORS CENTER | 8.75d | 2013-11-23 A | 2013-11-29 A | MAC1060 | 100% |  |  | Procurement [8362 h] | 8,362 |
| POC1070 |  | GUARD HOUSE MARINE | 14d | 2014-05-31 | 2014-06-14 | MAC1070 FS+36d, MATS1080 FS+120d |  | 5.75d | 0d | Procurement [8609 h] | 8,609 |
| POC1080 |  | TURNSTILE & X-RAY BUILDING | 14d | 2014-06-14 | 2014-06-28 | MAC1080 FS+15d, POC1070 |  | 5.75d | 0d | Procurement [8640 h] | 8,640 |
| POC1090 |  | GENERATOR BUILDING | 14d | 2014-06-28 | 2014-07-12 | MAC1090 FS+8.75d, POC1080 |  | 5.75d | 0d | Procurement [8053 h] | 8,053 |
|  | 3 | **MEP** |  | 2013-11-15 | 2014-08-05 |  |  |  |  |  |  |
| POM1000 |  | JFC BUILDING | 8.75d | 2013-11-15 A | 2013-11-21 A | MAM1000 | 100% |  |  | Procurement [5678 h] | 5,678 |
| POM1010 |  | QRT BUILDING | 8.75d | 2013-11-17 A | 2013-11-23 A | MAM1010 | 100% |  |  | Procurement [5554 h] | 5,554 |
| POM1020 |  | GUARD HOUSE (WADI) | 8.75d | 2013-11-19 A | 2013-11-25 A | MAM1020 | 100% |  |  | Procurement [5616 h] | 5,616 |
| POM1030 |  | UPS BUILDING | 8.75d | 2013-11-21 A | 2013-11-27 A | MAM1030 | 100% |  |  | Procurement [6110 h] | 6,110 |
| POM1040 |  | GATE HOUSE 2&3 INCLUDING PARKING,BUS STOP SHADE | 8.75d | 2013-11-23 A | 2013-11-29 A | MAM1040 | 100% |  |  | Procurement [5523 h] | 5,523 |
| POM1050 |  | VISITORS CENTER | 8.75d | 2013-11-25 A | 2013-12-01 A | MAM1050 | 100% |  |  | Procurement [5616 h] | 5,616 |
| POM1060 |  | GUARD HOUSE MARINE | 8.75d | 2013-11-27 A | 2013-12-03 A | MAM1060 | 100% |  |  | Procurement [5708 h] | 5,708 |
| POM1070 |  | TURNSTILE & X-RAY BUILDING | 8.75d | 2013-11-29 A | 2013-12-05 A | MAM1070 | 100% |  |  | Procurement [5678 h] | 5,678 |
| POM1080 |  | GENERATOR BUILDING | 24d | 2014-07-12 | 2014-08-05 | MAM1080, POC1090 |  | 5.75d | 0d | Procurement [5616 h] | 5,616 |
|  | 4 | **TELECOM & SECURITY** |  | 2014-08-05 | 2015-01-19 |  |  |  |  |  |  |
| POT1000 |  | JFC BUILDING | 12.5d | 2014-08-05 | 2014-08-17 | MATS1000, POM1080 |  | 5.75d | 0d | Procurement [1583 h] | 1,583 |
| POT1010 |  | QRT BUILDING | 12.5d | 2014-08-05 | 2014-08-17 | MATS1010, POT1000 SS |  | 5.75d | 0d | Procurement [1543 h] | 1,543 |
| POT1020 |  | GUARD HOUSE (WADI) | 12.5d | 2014-08-05 | 2014-08-17 | MATS1020, POT1010 SS |  | 5.75d | 0d | Procurement [1512 h] | 1,512 |
| POT1030 |  | UPS BUILDING | 12.5d | 2014-08-05 | 2014-08-17 | MATS1030, POT1020 SS |  | 5.75d | 0d | Procurement [1648 h] | 1,648 |
| POT1050 |  | VISITORS CENTER | 12.5d | 2014-08-05 | 2014-08-18 | MATS1050, POT1040 SF |  | 20.5d | 0d | Procurement [1598 h] | 1,598 |
| POT1060 |  | GUARD HOUSE MARINE | 12.5d | 2014-08-05 | 2014-08-18 | MATS1060, POT1050 SS |  | 20.5d | 0d | Procurement [1629 h] | 1,629 |
| POT1040 |  | GATE HOUSE 2&3 INCLUDING PARKING,BUS STOP SHADE | 12.5d | 2014-08-18 | 2014-08-30 | MATS1040, POT1030 |  | 20.5d | 0d | Procurement [1592 h] | 1,592 |
| POT1070 |  | TURNSTILE & X-RAY BUILDING | 12.5d | 2014-08-18 | 2014-08-30 | MATS1070, POT1060 |  | 20.5d | 0d | Procurement [1543 h] | 1,543 |
| POT1080 |  | GENERATOR BUILDING | 12.5d | 2014-10-19 | 2014-11-01 | MATS1080, POT1070 FF+62.5d, POT1070 SS |  | 20.5d | 0d | Procurement [1611 h] | 1,611 |
| POT1090 |  | SECURITY FENCE | 12.5d | 2014-10-19 | 2014-11-01 | MATS1090, POT1080 FF, POT1080 SS |  | 20.5d | 0d | Procurement [1598 h] | 1,598 |
| POT1100 |  | RADAR SYSTEM | 12.5d | 2014-11-01 | 2014-11-13 | MATS1100, POT1090 FF, POT1090 |  | 20.5d | 0d | Procurement [1617 h] | 1,617 |
| POT1110 |  | VESSEL BARRIER | 12.5d | 2014-11-01 | 2014-11-13 | MATS1110 FS+62.5d, POT1100 FF, POT1100 SS |  | 20.5d | 0d | Procurement [1580 h] | 1,580 |
| POT1120 |  | SONAR SYSTEM | 12.5d | 2014-11-01 | 2014-11-13 | MATS1120, POT1110 FF, POT1110 SS |  | 20.5d | 0d | Procurement [1589 h] | 1,589 |
| POT1130 |  | DROP ARM SYSTEM | 12.5d | 2014-11-01 | 2014-11-13 | MATS1130, POT1120 FF, POT1120 SS |  | 20.5d | 0d | Procurement [1648 h] | 1,648 |
| POT1140 |  | CARGO SCREENING SYSTEM | 12.5d | 2014-11-13 | 2014-11-26 | MATS1140, POT1130 |  | 20.5d | 5d | Procurement [1598 h] | 1,598 |
| POT1150 |  | CCTV CAMERAS | 12.5d | 2015-01-07 | 2015-01-19 | MATS1150 FS+120d, POT1140 FS+37.5d, POT1140 SS |  | 15.5d | 10d | Procurement [1660 h] | 1,660 |

| ID | WBS | Activity | Duration | Start | Finish | Predecessors | Complete | Remaining | Planned start | Planned finish | Total float | Free float | Resources | Cost | Actual cost |
| --- | --- | --- | --- | --- | --- | --- | --- | --- | --- | --- | --- | --- | --- | --- | --- |
|  | 5 | **LANDSCAPING** |  | 2014-06-26 | 2014-11-04 |  |  |  |  |  |  |  |  |  |  |
| POL1030 |  | SOFTSCAPING FINISHING | 8.75d | 2014-06-26 | 2014-07-05 | MAL1030 |  |  |  |  | 31.25d | 0d | Procurement [1216 h] | 1,216 |  |
| POL1040 |  | HARDSCAPING FINISHING | 8.75d | 2014-07-15 | 2014-07-23 | MAL1040, POL1030 FS+10d |  |  |  |  | 31.25d | 9.25d | Procurement [1213 h] | 1,213 |  |
| POL1050 |  | WATER PUMPS | 8.75d | 2014-07-24 | 2014-08-02 | MAL1050, POL1040 FF |  |  |  |  | 22d | 14d | Procurement [1231 h] | 1,231 |  |
| POL1060 |  | WATER FEATURES | 8.75d | 2014-08-07 | 2014-08-16 | MAL1060, POL1050 FF |  |  |  |  | 8d | 0d | Procurement [1234 h] | 1,234 |  |
| POL1020 |  | JUNCTION BOXES | 8.75d | 2014-10-10 | 2014-10-19 | MAL1020 FS+120d |  |  |  |  | 16.5d | 0d | Procurement [1222 h] | 1,222 |  |
| POL1000 |  | IRRIGATION SYSTEM | 8.75d | 2014-10-12 | 2014-10-21 | MAL1000 FS+150d |  |  |  |  | 22d | 0d | Procurement [1166 h] | 1,166 |  |
| POL1010 |  | IRRIGATION CONTROL SYSTEM | 8.75d | 2014-10-26 | 2014-11-04 | MAL1010 FS+150d |  |  |  |  | 18d | 0d | Procurement [1234 h] | 1,234 |  |
|  | 3 | **DELIVERY** |  | 2013-10-26 | 2015-06-23 |  |  |  |  |  |  |  |  |  |  |
|  | 2 | **CIVIL & ARCHITECTURAL** |  | 2013-10-26 | 2015-06-23 |  |  |  |  |  |  |  |  |  |  |
| DCA1000 |  | SECURITY FENCE (ZONE-A) | 31.25d | 2013-10-26 A | 2013-11-19 A | POC1000 | 100% |  |  |  |  |  | Procurement [41897 h] | 41,897 |  |
| DCA1040 |  | JFC BUILDING | 15d | 2013-10-31 A | 2013-11-11 A | POC1010 | 100% |  |  |  |  |  | Procurement [19899 h] | 19,899 |  |
| DCA1080 |  | GATE HOUSE 2 & 3 INCLUDING PARKING,BUS STOP SHADE | 314d | 2013-11-24 A | 2014-11-05 | POC1050 | 10% | 214d | 2013-11-24 | 2014-10-03 | 5.5d | 0d | Procurement [19899 h] | 19,899 | 6,337 |
| DCA1090 |  | VISITORS CENTER | 314d | 2013-11-30 A | 2014-11-05 | POC1060 | 10% | 214d | 2013-11-30 | 2014-10-09 | 5.5d | 0d | Procurement [19099 h] | 19,099 | 6,082 |
| DCA1010 |  | SECURITY FENCE (ZONE-B) | 31.25d | 2014-05-31 | 2014-07-01 | DCA1000 FS+31.25d, MATS1080 FS+120d |  |  |  |  | 3.5d | 0d | Procurement [41897 h] | 41,897 |  |
| DCA1110 |  | TURNSTILE & X-RAY BUILDING | 314d | 2014-06-28 | 2015-05-08 | POC1080 |  |  |  |  | 12d | 6.5d | Procurement [19999 h] | 19,999 |  |
| DCA1050 |  | QRT BUILDING | 314d | 2014-07-01 | 2015-05-11 | POC1020 FS+112.5d, DCA1040 FS+106.25d, DCA1010 |  |  |  |  | 7.75d | 0d | Procurement [18999 h] | 18,999 |  |
| DCA1060 |  | GUARD HOUSE (WADI) | 314d | 2014-07-31 | 2015-06-10 | POC1030 FS+75d, DCA1050 SS+30d |  |  |  |  | 7.75d | 0d | Procurement [19799 h] | 19,799 |  |
| DCA1070 |  | UPS BUILDING | 314d | 2014-07-31 | 2015-06-10 | POC1040 FS+62.5d, DCA1060 SS |  |  |  |  | 7.75d | 2.25d | Procurement [19899 h] | 19,899 |  |
| DCA1020 |  | SECURITY FENCE (ZONE-C) | 31.25d | 2014-09-02 | 2014-10-03 | DCA1010 FS+62.5d |  |  |  |  | 3.5d | 0d | Procurement [41897 h] | 41,897 |  |
| DCA1100 |  | GUARD HOUSE MARINE | 254d | 2014-09-02 | 2015-05-14 | POC1070 FS+80d |  |  |  |  | 10d | 4.5d | Procurement [19899 h] | 19,899 |  |
| DCA1120 |  | GENERATOR BUILDING | 280d | 2014-09-17 | 2015-06-23 | POC1090 FS+18.75d, DCA1050 SS, DCA1060 SS, DCA1070 SS+45d, DCA1080 FS-50d, DCA1100 SS+10d, DCA1110 FF+40d, DCA1090 FS-50d |  |  |  |  | 5.5d | 0d | Procurement [19899 h] | 19,899 |  |
| DCA1030 |  | SECURITY FENCE (ZONE-D) | 26.25d | 2014-10-11 | 2014-11-06 | DCA1020 FS+7.5d |  |  |  |  | 3.5d | 0d | Procurement [41897 h] | 41,897 |  |
|  | 3 | **MEP** |  | 2013-11-22 | 2015-01-14 |  |  |  |  |  |  |  |  |  |  |
| DM1000 |  | JFC BUILDING | 131.25d | 2013-11-22 A | 2014-08-15 | POM1000, DCA1040 | 20% | 131.25d | 2013-11-22 | 2014-03-06 | 5.5d | 0d | Procurement [8014 h] | 8,014 |  |
| DM1010 |  | QRT BUILDING | 131.25d | 2013-11-24 A | 2014-08-17 | POM1010, DM1000 FF+2.5d | 20% | 131.25d | 2013-11-24 | 2014-03-08 | 5.5d | 0d | Procurement [7892 h] | 7,892 |  |
| DM1020 |  | GUARD HOUSE (WADI) | 131.25d | 2013-11-26 A | 2014-08-17 | POM1020, DM1010 FF | 20% | 131.25d | 2013-11-26 | 2014-03-10 | 5.5d | 0d | Procurement [7979 h] | 7,979 |  |
| DM1030 |  | UPS BUILDING | 131.25d | 2013-11-28 A | 2014-08-17 | POM1030, DM1020 FF | 20% | 131.25d | 2013-11-28 | 2014-03-12 | 5.5d | 0d | Procurement [8049 h] | 8,049 |  |
| DM1040 |  | GATE HOUSE 2&3 INCLUDING PARKING,BUS STOP SHADE | 131.25d | 2013-11-30 A | 2014-08-20 | POM1040, DM1030 FF+2.5d | 20% | 131.25d | 2013-11-30 | 2014-03-14 | 5.5d | 0d | Procurement [8067 h] | 8,067 |  |
| DM1050 |  | VISITORS CENTER | 131.25d | 2013-12-02 A | 2014-08-22 | POM1050, DM1040 FF+2.5d | 20% | 131.25d | 2013-12-02 | 2014-03-16 | 5.5d | 0d | Procurement [7945 h] | 7,945 |  |
| DM1060 |  | GUARD HOUSE MARINE | 131.25d | 2014-04-16 | 2014-08-25 | POM1060, DM1050 FF+2.5d |  |  |  |  | 5.5d | 0d | Procurement [8258 h] | 8,258 |  |
| DM1070 |  | TURNSTILE & X-RAY BUILDING | 131.25d | 2014-04-18 | 2014-08-27 | POM1070, DM1060 FF+2.5d |  |  |  |  | 5.5d | 0d | Procurement [8014 h] | 8,014 |  |
| DM1080 |  | GENERATOR BUILDING | 140d | 2014-08-27 | 2015-01-14 | POM1080, DM1070 |  |  |  |  | 5.5d | 0d | Procurement [7910 h] | 7,910 |  |

| ID | WBS | Activity | Duration | Start | Finish | Predecessors | Total float | Free float | Resources | Cost |
| --- | --- | --- | --- | --- | --- | --- | --- | --- | --- | --- |
|  | 4 | **TELECOM & SECURITY** |  | 2014-08-24 | 2015-06-21 |  |  |  |  |  |
| DTS1030 |  | UPS BUILDING | 131.25d | 2014-08-24 | 2015-01-02 | POT1030 FS+6.25d | 5.75d | 0.25d | Procurement [8352 h] | 8,352 |
| DTS1000 |  | JFC BUILDING | 131.25d | 2014-09-05 | 2015-01-14 | POT1000 FS+6.25d, DM1080 FF | 5.5d | 0d | Procurement [8352 h] | 8,352 |
| DTS1010 |  | QRT BUILDING | 131.25d | 2014-09-05 | 2015-01-14 | POT1010 FS+6.25d, DTS1000 FF | 5.5d | 0d | Procurement [8456 h] | 8,456 |
| DTS1020 |  | GUARD HOUSE (WADI) | 131.25d | 2014-09-05 | 2015-01-14 | POT1020 FS+6.25d, DTS1010 FF | 5.5d | 0d | Procurement [8483 h] | 8,483 |
| DTS1040 |  | GATE HOUSE 2&3 INCLUDING PARKING,BUS STOP SHADE | 131.25d | 2014-09-29 | 2015-02-07 | POT1040 FS+6.25d, DTS1030 FF+36d, DTS1020 FF+24d | 5.5d | 0d | Procurement [8456 h] | 8,456 |
| DTS1050 |  | VISITORS CENTER | 131.25d | 2014-09-29 | 2015-02-07 | POT1050, DTS1040 FF | 5.5d | 0d | Procurement [8470 h] | 8,470 |
| DTS1060 |  | GUARD HOUSE MARINE | 131.25d | 2014-09-29 | 2015-02-07 | POT1060 FS+6.25d, DTS1050 FF | 5.5d | 0d | Procurement [8744 h] | 8,744 |
| DTS1070 |  | TURNSTILE & X-RAY BUILDING | 131.25d | 2014-09-29 | 2015-02-07 | DTS1060 FF | 5.5d | 0d | Procurement [8587 h] | 8,587 |
| DTS1080 |  | GENERATOR BUILDING | 131.25d | 2014-09-29 | 2015-02-07 | DTS1070 FF | 5.5d | 0d | Procurement [8365 h] | 8,365 |
| DTS1090 |  | SECURITY FENCE | 131.25d | 2014-10-05 | 2015-02-13 | DTS1080 FF+6.25d | 5.5d | 0d | Procurement [8470 h] | 8,470 |
| DTS1100 |  | RADAR SYSTEM | 112.5d | 2015-02-04 | 2015-05-27 | DTS1090 FS-10d, DCA1120 FS-140d | 5.5d | 0d | Procurement [8522 h] | 8,522 |
| DTS1110 |  | VESSEL BARRIER | 112.5d | 2015-02-10 | 2015-06-02 | DTS1100 FF+6.25d | 5.5d | 0d | Procurement [8091 h] | 8,091 |
| DTS1120 |  | SONAR SYSTEM | 112.5d | 2015-02-16 | 2015-06-08 | DTS1110 FF+6.25d | 5.5d | 0d | Procurement [8470 h] | 8,470 |
| DTS1130 |  | DROP ARM SYSTEM | 112.5d | 2015-02-22 | 2015-06-15 | DTS1120 FF+6.25d | 5.5d | 0d | Procurement [8483 h] | 8,483 |
| DTS1140 |  | CARGO SCREENING SYSTEM | 112.5d | 2015-03-01 | 2015-06-21 | DTS1130 FF+6.25d | 5.5d | 0d | Procurement [8470 h] | 8,470 |
| DTS1150 |  | CCTV CAMERAS | 112.5d | 2015-03-01 | 2015-06-21 | POT1150 FS+30d, DTS1140 FF | 5.5d |  | Procurement [8300 h] | 8,300 |
|  | 5 | **LANDSCAPING** |  | 2014-11-20 | 2015-02-08 |  |  |  |  |  |
| DLS1000 |  | IRRIGATION SYSTEM | 75d | 2014-11-20 | 2015-02-03 | POL1000 FS+30d | 22d | 4d | Procurement [201 h] | 201 |
| DLS1010 |  | IRRIGATION CONTROL SYSTEM | 75d | 2014-11-24 | 2015-02-07 | POL1010 FS+20d, DLS1000 FF | 18d | 1.5d | Procurement [200 h] | 200 |
| DLS1020 |  | JUNCTION BOXES | 75d | 2014-11-25 | 2015-02-08 | POL1020 FF+112.5d, DLS1010 FF | 16.5d | 0d | Procurement [199 h] | 199 |
| DLS1030 |  | SOFTSCAPING FINISHING | 75d | 2014-11-25 | 2015-02-08 | DLS1020 FF | 16.5d | 0d | Procurement [196 h] | 196 |
| DLS1040 |  | HARDSCAPING FINISHING | 75d | 2014-11-25 | 2015-02-08 | DLS1030 FF | 16.5d | 0d | Procurement [197 h] | 197 |
| DLS1050 |  | WATER PUMPS | 75d | 2014-11-25 | 2015-02-08 | DLS1040 FF | 16.5d | 0d | Procurement [197 h] | 197 |
| DLS1060 |  | WATER FEATURES | 75d | 2014-11-25 | 2015-02-08 | DLS1050 FF | 16.5d | 0d | Procurement [195 h] | 195 |

| ID | WBS | Activity | Duration | Start | Finish | Predecessors | Complete | Planned start | Planned finish | Total float | Free float | Resources | Cost | Actual cost | Devision-02 | FCC Scope |
| --- | --- | --- | --- | --- | --- | --- | --- | --- | --- | --- | --- | --- | --- | --- | --- | --- |
|  | 3 | **CONSTRUCTION** |  | 2013-09-27 | 2015-08-25 |  |  |  |  |  |  |  |  |  |  |  |
|  | 3 | **EXTERNAL WORKS (CIVIL)** |  | 2013-09-27 | 2015-08-25 |  |  |  |  |  |  |  |  |  |  |  |
|  | 2 | **DITCHES CONSTRUCTION** |  | 2013-09-27 | 2014-08-31 |  |  |  |  |  |  |  |  |  |  |  |
|  | 2 | **ZONE-B (4+000 --- 7+000)** |  | 2013-09-27 | 2014-05-25 |  |  |  |  |  |  |  |  |  |  |  |
|  | 1 | **ZONE-B (5+550 --- 7+000) (Priority-1.1)(1450)** |  | 2013-09-27 | 2014-05-25 |  |  |  |  |  |  |  |  |  |  |  |
| ZBDI-1000 |  | SITE PREPARATION (GRADING / LEVELING) | 12.5d | 2013-09-27 A | 2013-10-06 A | ED-1090 | 100% |  |  |  |  | Labour [498.5 h]; Supervisor [498.5 h]; Grader [498.5 h]; Surveyor [498.5 h] | 1,497 |  | DFCR |  |
| ZBDI-1010 |  | BACKFILLING | 31.25d | 2013-11-04 A | 2013-11-28 A | ZBDI-1000 | 100% |  |  |  |  | Loader [2492.5 h]; Dump Truck [2492.5 h]; Surveyor [2492.5 h]; Labour [2492.5 h] | 9,972 |  | DFCR |  |
| ZBDI-1030 |  | DEWATERING | 43.75d | 2013-11-19 A | 2014-01-19 A | ZBDI-1020 SS+1.25d | 100% | 2013-12-14 | 2014-01-17 |  |  | Labour [798 h]; Lumpsum [250] | 798 | 798 | DFCR |  |
| ZBDI-1020 |  | EXCAVATION | 43.75d | 2013-11-19 A | 2014-01-12 A | ZBDI-1010 SS+18.75d | 100% | 2013-11-19 | 2013-12-23 |  |  | Dump Truck [698 h]; Excavator [698 h]; Supervisor [698 h]; Labour [698 h] | 1,396 | 1,396 | DFCR |  |
| ZBDI-1040 |  | ENGINEERING BACKFILLING & COMPACTION | 43.75d | 2013-12-01 A | 2014-01-21 A | ZBDI-1030 SS+6.25d | 100% | 2013-12-19 | 2014-01-22 |  |  | Labour [129.5 h]; Supervisor [129.5 h]; Dump Truck [129.5 h]; Compactor [129.5 h] | 260 | 260 | DFCR |  |
| ZBDI-1050 |  | VAPOR BARRIER | 48.75d | 2013-12-04 A | 2014-03-30 A | ZBDI-1040 SS+6.25d | 100% | 2013-12-28 | 2014-02-14 |  |  | Labour [299 h]; Supervisor [299 h] | 299 | 299 | DFCR | BVFC |
| ZBDI-1060 |  | BLINDING | 48.75d | 2013-12-09 A | 2014-03-30 A | ZBDI-1050 SS+6.25d | 100% | 2013-12-09 | 2014-01-26 |  |  | Labour [997 h]; Supervisor [997 h]; Surveyor [997 h]; Concrete Pump [997 h] | 2,991 | 2,991 | DFCR | BVFC |
| ZBDI-1070 |  | RC HORIZONTAL BEAMS & RC RETAINING WALL | 48.75d | 2013-12-28 A | 2014-03-30 A | ZBDI-1060 SS+6.25d | 100% | 2013-12-28 | 2014-02-14 |  |  | Labour [1739.33 h]; Supervisor [1739.33 h]; Steel Fixer [1739.33 h]; Grader [1739.33 h]; CARPANTER [1739.33 h]; Concrete Pump [1739.33 h] | 8,695 | 8,695 | DFCR | BVFC |
| ZBDI-1080 |  | DEMOLITION OF CONSTRUCTED DITCH | 25d | 2014-05-01 | 2014-05-25 | ZBDI-1070 FS+32d |  |  |  | 5d | 0d | Labour [1180 h]; Supervisor [1180 h] | 1,180 |  | DFCR |  |
|  | 3 | **ZONE-C (7+000 --- 10+750)** |  | 2013-09-27 | 2014-07-31 |  |  |  |  |  |  |  |  |  |  |  |
|  | 1 | **ZONE-C (7+000 --- 8+950) (Priority-1.2)(1950)** |  | 2013-09-27 | 2014-07-31 |  |  |  |  |  |  |  |  |  |  |  |
| ZCDI-1000 |  | SITE PREPARATION (GRADING / LEVELING) | 15d | 2013-09-27 A | 2013-10-08 A | ED-1100 | 100% |  |  |  |  | Labour [551.75 h]; Supervisor [551.75 h]; Grader [551.75 h]; Surveyor [551.75 h] | 1,656 |  | DFCR |  |
| ZCDI-1010 |  | BACKFILLING | 31.25d | 2013-11-04 A | 2013-11-28 A | ZCDI-1000, ED-1170 | 100% |  |  |  |  | Loader [2758.75 h]; Dump Truck [2758.75 h]; Surveyor [2758.75 h]; Labour [2758.75 h] | 11,036 | 11,036 | DFCR |  |
| ZCDI-1020 |  | EXCAVATION | 25d | 2013-11-19 A | 2013-12-08 A | ZCDI-1010 SS+12.5d | 100% |  |  |  |  | Dump Truck [772.5 h]; Excavator [772.5 h]; Supervisor [772.5 h]; Labour [772.5 h] | 1,546 |  | DFCR |  |
| ZCDI-1030 |  | DEWATERING | 20d | 2013-11-20 A | 2013-12-05 A | ZCDI-1020 FF+3.75d | 100% |  |  |  |  | Labour [883 h]; Lumpsum [250] | 883 | 883 | DFCR |  |
| ZCDI-1040 |  | ENGINEERING BACKFILLING & COMPACTION | 18.75d | 2013-11-22 A | 2013-12-16 A | ZCDI-1030 SS+6.25d | 100% | 2013-11-22 | 2013-12-06 |  |  | Labour [143.5 h]; Supervisor [143.5 h]; Dump Truck [143.5 h]; Compactor [143.5 h] | 288 | 288 | DFCR |  |
| ZCDI-1050 |  | VAPOR BARRIER | 57.5d | 2013-12-07 A | 2014-03-30 A | ZCDI-1040 FF+6.25d | 100% | 2013-12-07 | 2014-02-02 |  |  | Labour [331 h]; Supervisor [331 h] | 331 | 331 | DFCR | BVFC |
| ZCDI-1060 |  | BLINDING | 57.5d | 2013-12-08 A | 2014-03-30 A | ZCDI-1050, ZCDI-1050 FF | 100% | 2013-12-08 | 2014-02-03 |  |  | Labour [1103.5 h]; Supervisor [1103.5 h]; Surveyor [1103.5 h]; Concrete Pump [1103.5 h] | 3,312 | 3,312 | DFCR | BVFC |
| ZCDI-1070 |  | RC HORIZONTAL BEAMS & RC RETAINING WALL | 81.25d | 2014-01-15 A | 2014-03-30 A | ZCDI-1060 SS+26.25d, ZBDI-1070 FF+7.5d | 100% | 2014-01-15 | 2014-04-06 |  |  | Labour [2227.83 h]; Supervisor [2227.83 h]; Steel Fixer [2227.83 h]; Grader [2227.83 h]; CARPANTER [2227.83 h]; Concrete Pump [2227.83 h] | 11,140 | 11,140 | DFCR | BVFC |
| ZCDI-1080 |  | DEMOLITION OF CONSTRUCTED DITCH | 67d | 2014-05-26 | 2014-07-31 | ZCDI-1070 FF+22.5d, ZBDI-1080 FF, ZBDI-1080 |  |  |  | 5d | 0d | Labour [3698 h]; Supervisor [3698 h] | 3,698 |  | DFCR |  |

| ID | WBS | Activity | Duration | Start | Finish | Predecessors | Complete | Planned start | Planned finish | Total float | Free float | Constraint | Resources | Cost | Actual cost | Devision-02 | FCC Scope |
| --- | --- | --- | --- | --- | --- | --- | --- | --- | --- | --- | --- | --- | --- | --- | --- | --- | --- |
|  | 4 | **ZONE-D (10+750 --- 14+820)** |  | 2013-11-18 | 2014-08-31 |  |  |  |  |  |  |  |  |  |  |  |  |
|  | 1 | **ZONE-D (10+750 --- 13+100) (Priority-2.1)(2350)** |  | 2013-11-18 | 2014-08-31 |  |  |  |  |  |  |  |  |  |  |  |  |
| ZDDI-1000 |  | SITE PREPARATION (GRADING / LEVELING) | 25d | 2013-11-18 A | 2014-03-30 A | ED-1130 | 100% | 2013-11-18 | 2013-12-12 |  |  |  | Labour [462.75 h]; Supervisor [462.75 h]; Grader [462.75 h]; Surveyor [462.75 h] | 1,389 | 1,389 | DFCR |  |
| ZDDI-1010 |  | BACKFILLING | 30d | 2013-11-24 A | 2014-03-30 A | ZDDI-1000 FS+100d | 100% | 2013-11-24 | 2013-12-23 |  |  |  | Loader [2313.5 h]; Dump Truck [2313.5 h]; Surveyor [2313.5 h]; Labour [2313.5 h] | 9,256 | 9,256 | DFCR |  |
| ZDDI-1020 |  | EXCAVATION | 37.5d | 2013-12-02 A | 2014-03-30 A | ZDDI-1010 FF+15d | 100% | 2013-12-02 | 2014-01-08 |  |  |  | Dump Truck [647.75 h]; Excavator [647.75 h]; Supervisor [647.75 h]; Labour [647.75 h] | 1,296 | 1,296 | DFCR |  |
| ZDDI-1030 |  | DEWATERING | 37.5d | 2013-12-02 A | 2014-03-30 A | ZDDI-1020 FF+12.5d | 100% | 2013-12-02 | 2014-01-08 |  |  |  | Labour [740 h]; Lumpsum [250] | 740 | 740 | DFCR |  |
| ZDDI-1040 |  | ENGINEERING BACKFILLING & COMPACTION | 42.5d | 2013-12-07 A | 2014-03-30 A | ZDDI-1030 SS+12.5d | 100% | 2013-12-07 | 2014-01-18 |  |  |  | Labour [120.25 h]; Supervisor [120.25 h]; Dump Truck [120.25 h]; Compactor [120.25 h] | 240 | 240 | DFCR |  |
| ZDDI-1050 |  | VAPOR BARRIER | 43.75d | 2013-12-14 A | 2014-03-30 A | ZDDI-1040 SS+12.5d | 100% | 2013-12-14 | 2014-01-26 |  |  |  | Labour [277.5 h]; Supervisor [277.5 h] | 278 | 278 | DFCR | BVFC |
| ZDDI-1060 |  | BLINDING | 81.25d | 2014-01-04 A | 2014-03-30 A | ZDDI-1050 SS+18.75d | 100% | 2014-01-04 | 2014-03-26 |  |  |  | Labour [925.5 h]; Supervisor [925.5 h]; Surveyor [925.5 h]; Concrete Pump [925.5 h] | 2,778 | 2,778 | DFCR | BVFC |
| ZDDI-1070 |  | DEMOLITION OF CONSTRUCTED DITCH | 31d | 2014-08-01 | 2014-08-31 | ZDDI-1060 SS+31.25d, ZCDI-1070, ZCDI-1070 FF, ZCDI-1080 |  |  |  | 5d | 0d |  | Labour [325.17 h]; Supervisor [325.17 h]; Steel Fixer [325.17 h]; Grader [325.17 h]; CARPANTER [325.17 h]; Concrete Pump [325.17 h] | 1,625 |  | DFCR | BVFC |
|  | 1 | **FENCE** |  | 2013-11-21 | 2015-08-11 |  |  |  |  |  |  |  |  |  |  |  |  |
|  | 2 | **ZONE-B (4+000 --- 7+000)** |  | 2013-11-21 | 2015-08-11 |  |  |  |  |  |  |  |  |  |  |  |  |
|  | 1 | **ZONE-B (5+550 --- 7+000) (Priority-1.1)(1450)** |  | 2013-11-21 | 2014-10-14 |  |  |  |  |  |  |  |  |  |  |  |  |
| ZBF-1120 |  | SITE PREPARATION (GRADING / LEVELING) | 13.75d | 2013-11-21 A | 2013-12-01 A | ED-1130 | 100% |  |  |  |  |  | Labour [1583.5 h]; Excavator [1583.5 h]; Supervisor [1583.5 h]; Dump Truck [1583.5 h] | 3,168 |  | DFCR |  |
| ZBF-1130 |  | ENGINEERING SELLECTFILL, COMPACTION & BLINDING | 43.75d | 2014-05-04 | 2014-06-16 | ZBDI-1070 FS+35d, ZBF-1120 |  |  |  | 0.25d | 0d |  | Labour [703.67 h]; Supervisor [703.67 h]; Dump Truck [703.67 h] | 1,408 |  | DFCR |  |
| ZBF-1140 |  | WATER PROOFING (FOUNDATION) | 43.75d | 2014-06-20 | 2014-08-03 | ZBF-1130 FS+3.75d |  |  |  | 0.25d | 0d |  | Labour [1689 h]; Lumpsum [200]; Supervisor [1689 h] | 1,689 |  | DFCR | BVFC |
| ZBF-1150 |  | PRECAST FOOTING/FOUNDATION (Installation) | 43.75d | 2014-08-13 | 2014-09-25 | ZBF-1140 SS+53.75d |  |  |  | 0.25d | 0d |  | Labour [2389 h]; Supervisor [2389 h]; Mobile Crane [2389 h]; Surveyor [2389 h] | 7,167 |  | DFCR | BVFC |
| ZBF-1160 |  | PRECAST COLUMNS (Installation) | 43.75d | 2014-08-25 | 2014-10-08 | ZBF-1150 SS+12.5d |  |  |  | 0.25d | 0d |  | Labour [1372.25 h]; Supervisor [1372.25 h]; Mobile Crane [1372.25 h]; Surveyor [1372.25 h] | 4,116 |  | DFCR | BVFC |
| ZBF-1170 |  | PRECAST PANELS (Installation) | 43.75d | 2014-09-01 | 2014-10-14 | ZBF-1160 SS+6.25d |  |  |  | 0.25d | 0d |  | Labour [3589 h]; Surveyor [3589 h]; Mobile Crane [3589 h]; Supervisor [3589 h] | 10,767 |  | DFCR | BVFC |
|  | 2 | **ZONE-B (4+000 --- 5+550) (Priority-4.2)(1550)** |  | 2015-03-31 | 2015-08-11 |  |  |  |  |  |  |  |  |  |  |  |  |
| ZBF-1180 |  | SITE PREPARATION (GRADING / LEVELING) | 25d | 2015-03-31 | 2015-04-24 | ZDF-1420 FS+38d |  |  |  | 32.75d | 0d | start on or after 2015-03-31 | Labour [1295.5 h]; Excavator [1295.5 h]; Supervisor [1295.5 h]; Dump Truck [1295.5 h] | 2,592 |  | DFCR |  |
| ZBF-1190 |  | ENGINEERING SELLECTFILL, COMPACTION & BLINDING | 40d | 2015-04-25 | 2015-06-03 | ZBF-1180 |  |  |  | 32.75d | 0d |  | Labour [575.67 h]; Supervisor [575.67 h]; Dump Truck [575.67 h] | 1,152 |  | DFCR |  |
| ZBF-1200 |  | WATER PROOFING (FOUNDATION) | 40d | 2015-05-07 | 2015-06-16 | ZBF-1190 SS+12.5d |  |  |  | 32.75d | 0d |  | Labour [1382 h]; Lumpsum [200]; Supervisor [1382 h] | 1,382 |  | DFCR | BVFC |
| ZBF-1210 |  | PRECAST FOOTING/FOUNDATION (Installation) | 40d | 2015-05-13 | 2015-06-22 | ZBF-1200 SS+6.25d |  |  |  | 32.75d | 0d |  | Labour [2159.25 h]; Supervisor [2159.25 h]; Mobile Crane [2159.25 h]; Surveyor [2159.25 h] | 6,477 |  | DFCR | BVFC |
| ZBF-1220 |  | PRECAST COLUMNS (Installation) | 40d | 2015-05-20 | 2015-06-28 | ZBF-1210 SS+6.25d |  |  |  | 32.75d | 27.75d |  | Labour [1122.75 h]; Supervisor [1122.75 h]; Mobile Crane [1122.75 h]; Surveyor [1122.75 h] | 3,369 |  | DFCR | BVFC |
| ZBF-1230 |  | PRECAST PANELS (Installation) | 50d | 2015-06-23 | 2015-08-11 | ZBF-1220 SS+6.25d, ZDF-1470 |  |  |  | 5d | 5.25d |  | Labour [2936.5 h]; Surveyor [2936.5 h]; Mobile Crane [2936.5 h]; Supervisor [2936.5 h] | 8,811 |  | DFCR | BVFC |

| ID | WBS | Activity | Duration | Start | Finish | Predecessors | Complete | Remaining | Planned start | Planned finish | Total float | Free float | Resources | Cost | Actual cost | Devision-02 | FCC Scope |
| --- | --- | --- | --- | --- | --- | --- | --- | --- | --- | --- | --- | --- | --- | --- | --- | --- | --- |
|  | 3 | **ZONE-C (7+000 --- 10+750)** |  | 2013-11-24 | 2015-06-27 |  |  |  |  |  |  |  |  |  |  |  |  |
|  | 1 | **ZONE-C (7+000 --- 8+950) (Priority-2.2)(1950)** |  | 2013-11-24 | 2015-02-27 |  |  |  |  |  |  |  |  |  |  |  |  |
| ZCF-1240 |  | SITE PREPARATION (GRADING / LEVELING) | 12.5d | 2013-11-24 A | 2013-12-03 A | ED-1110 | 100% |  |  |  |  |  | Labour [1434 h]; Excavator [1434 h]; Supervisor [1434 h]; Dump Truck [1434 h] | 2,868 |  | DFCR |  |
| ZCF-1250 |  | ENGINEERING SELLECTFILL, COMPACTION & BLINDING | 68.75d | 2014-05-04 | 2014-07-11 | ZCDI-1070 FS+35d, ZCF-1240 |  |  |  |  | -0.25d | 0d | Labour [637.33 h]; Supervisor [637.33 h]; Dump Truck [637.33 h] | 1,274 |  | DFCR |  |
| ZCF-1260 |  | WATER PROOFING (FOUNDATION) | 68.75d | 2014-07-11 | 2014-09-18 | ZCF-1250 |  |  |  |  | -0.25d | 0d | Labour [1529.5 h]; Lumpsum [200]; Supervisor [1529.5 h] | 1,530 |  | DFCR | BVFC |
| ZCF-1270 |  | PRECAST FOOTING/FOUNDATION (Installation) | 68.75d | 2014-07-24 | 2014-09-30 | ZCF-1260 SS+12.5d |  |  |  |  | -0.25d | 0d | Labour [2390 h]; Supervisor [2390 h]; Mobile Crane [2390 h]; Surveyor [2390 h] | 7,170 |  | DFCR | BVFC |
| ZCF-1280 |  | PRECAST COLUMNS (Installation) | 68.75d | 2014-10-01 | 2014-12-08 | ZCF-1270 SS+68.75d |  |  |  |  | -0.25d | 0d | Labour [1663.5 h]; Supervisor [1663.5 h]; Mobile Crane [1663.5 h]; Surveyor [1663.5 h] | 4,992 |  | DFCR | BVFC |
| ZCF-1290 |  | PRECAST PANELS (Installation) | 75d | 2014-12-15 | 2015-02-27 | ZCF-1280 FS+6.25d |  |  |  |  | -0.25d | 0d | Labour [3250.25 h]; Surveyor [3250.25 h]; Mobile Crane [3250.25 h]; Supervisor [3250.25 h] | 9,750 |  | DFCR | BVFC |
|  | 2 | **ZONE-C (9+200 --- 10+750) (Priority-1.2)(1550)** |  | 2014-01-24 | 2015-06-27 |  |  |  |  |  |  |  |  |  |  |  |  |
| ZCF-1300 |  | SITE PREPARATION (GRADING / LEVELING) | 50d | 2014-01-24 A | 2014-03-25 A | ED-1170 | 100% |  | 2014-01-24 | 2014-03-14 |  |  | Labour [1673.25 h]; Excavator [1673.25 h]; Supervisor [1673.25 h]; Dump Truck [1673.25 h] | 3,346 | 3,346 | DFCR |  |
| ZCF-1310 |  | ENGINEERING SELLECTFILL, COMPACTION & BLINDING | 62.5d | 2015-02-28 | 2015-05-01 | ZCF-1300 SS+12.5d, KAR-1010 SS, ZCF-1290 |  |  |  |  | 3d | 0d | Labour [743.67 h]; Supervisor [743.67 h]; Dump Truck [743.67 h] | 1,488 |  | DFCR |  |
| ZCF-1320 |  | WATER PROOFING (FOUNDATION) | 75d | 2015-03-06 | 2015-05-20 | ZCF-1310 SS+6.25d |  |  |  |  | 3d | 0d | Labour [1784.5 h]; Lumpsum [200]; Supervisor [1784.5 h] | 1,785 |  | DFCR | BVFC |
| ZCF-1330 |  | PRECAST FOOTING/FOUNDATION (Installation) | 75d | 2015-03-18 | 2015-06-01 | ZCF-1320 SS+12.5d |  |  |  |  | 3d | 0d | Labour [2788.75 h]; Supervisor [2788.75 h]; Mobile Crane [2788.75 h]; Surveyor [2788.75 h] | 8,367 |  | DFCR | BVFC |
| ZCF-1340 |  | PRECAST COLUMNS (Installation) | 75d | 2015-03-31 | 2015-06-14 | ZCF-1330 SS+12.5d |  |  |  |  | 3d | 0d | Labour [1450 h]; Supervisor [1450 h]; Mobile Crane [1450 h]; Surveyor [1450 h] | 4,350 |  | DFCR | BVFC |
| ZCF-1350 |  | PRECAST PANELS (Installation) | 88.75d | 2015-03-31 | 2015-06-27 | ZBF-1170 SS+23.75d, ZCF-1340 SS |  |  |  |  | 3d | 0d | Labour [3792.5 h]; Surveyor [3792.5 h]; Mobile Crane [3792.5 h]; Supervisor [3792.5 h] | 11,379 |  | DFCR | BVFC |
|  | 4 | **ZONE-D (10+750 --- 14+820)** |  | 2013-11-27 | 2015-08-07 |  |  |  |  |  |  |  |  |  |  |  |  |
|  | 1 | **ZONE-D (10+750 --- 13+100) (Priority-2.1)(2350)** |  | 2013-11-27 | 2015-08-07 |  |  |  |  |  |  |  |  |  |  |  |  |
| ZDF-1360 |  | SITE PREPARATION (GRADING / LEVELING) | 33.75d | 2013-11-27 A | 2015-04-13 | DCA1030 FS+125d | 84% | 33.75d | 2013-11-12 | 2013-12-08 | 3.5d | 0d | Labour [1188.25 h]; Excavator [1188.25 h]; Supervisor [1188.25 h]; Dump Truck [1188.25 h] | 2,376 |  | DFCR |  |
| ZDF-1370 |  | ENGINEERING SELLECTFILL, COMPACTION & BLINDING | 55d | 2015-04-04 | 2015-05-28 | ZDF-1360 FS-10d, ZDDI-1070 SS+12.5d |  |  |  |  | 3.5d | 0d | Labour [528 h]; Supervisor [528 h]; Dump Truck [528 h] | 1,056 |  | DFCR |  |
| ZDF-1380 |  | WATER PROOFING (FOUNDATION) | 55d | 2015-04-10 | 2015-06-04 | ZDF-1370 SS+6.25d |  |  |  |  | 3.5d | 0d | Labour [1267.5 h]; Lumpsum [200]; Supervisor [1267.5 h] | 1,268 |  | DFCR | BVFC |
| ZDF-1390 |  | PRECAST FOOTING/FOUNDATION (Installation) | 55d | 2015-04-15 | 2015-06-09 | ZDF-1380 SS+5d |  |  |  |  | 3.5d | 0d | Labour [1980.25 h]; Supervisor [1980.25 h]; Mobile Crane [1980.25 h]; Surveyor [1980.25 h] | 5,940 |  | DFCR | BVFC |
| ZDF-1400 |  | PRECAST COLUMNS (Installation) | 55d | 2015-04-27 | 2015-06-21 | ZDF-1390 SS+12.5d |  |  |  |  | 12.75d | 9.75d | Labour [1029.75 h]; Supervisor [1029.75 h]; Mobile Crane [1029.75 h]; Surveyor [1029.75 h] | 3,090 |  | DFCR | BVFC |
| ZDF-1410 |  | PRECAST PANELS (Installation) | 65d | 2015-06-04 | 2015-08-07 | ZCF-1350 FS-24d, ZDF-1400 FF+37.5d |  |  |  |  | 3d | 3.25d | Labour [2693.25 h]; Surveyor [2693.25 h]; Mobile Crane [2693.25 h]; Supervisor [2693.25 h] | 8,079 |  | DFCR | BVFC |
|  | 2 | **ZONE-D (13+100 --- 14+820) (Priority-4.1)(1720)** |  | 2014-12-30 | 2015-06-22 |  |  |  |  |  |  |  |  |  |  |  |  |
| ZDF-1420 |  | SITE PREPARATION (GRADING / LEVELING) | 18.75d | 2014-12-30 | 2015-01-17 | ZAF-1000 FS+12.5d, ZDDI-1070 FS+120d |  |  |  |  | 5d | 0d | Labour [1202.5 h]; Excavator [1202.5 h]; Supervisor [1202.5 h]; Dump Truck [1202.5 h] | 2,406 |  | DFCR |  |
| ZDF-1430 |  | ENGINEERING SELLECTFILL, COMPACTION & BLINDING | 43.75d | 2015-01-17 | 2015-03-02 | ZDF-1420 |  |  |  |  | 5d | 0d | Labour [534.33 h]; Supervisor [534.33 h]; Dump Truck [534.33 h] | 1,068 |  | DFCR |  |
| ZDF-1440 |  | WATER PROOFING (FOUNDATION) | 43.75d | 2015-02-05 | 2015-03-21 | ZDF-1430 SS+18.75d |  |  |  |  | 5d | 0d | Labour [1282.5 h]; Lumpsum [200]; Supervisor [1282.5 h] | 1,283 |  | DFCR | BVFC |
| ZDF-1450 |  | PRECAST FOOTING/FOUNDATION (Installation) | 43.75d | 2015-02-24 | 2015-04-08 | ZDF-1440 SS+18.75d |  |  |  |  | 5d | 0d | Labour [2004.25 h]; Supervisor [2004.25 h]; Mobile Crane [2004.25 h]; Surveyor [2004.25 h] | 6,012 |  | DFCR | BVFC |
| ZDF-1460 |  | PRECAST COLUMNS (Installation) | 43.75d | 2015-03-15 | 2015-04-27 | ZDF-1450 SS+18.75d |  |  |  |  | 5d | 0d | Labour [1042.25 h]; Supervisor [1042.25 h]; Mobile Crane [1042.25 h]; Surveyor [1042.25 h] | 3,126 |  | DFCR | BVFC |
| ZDF-1470 |  | PRECAST PANELS (Installation) | 50d | 2015-05-04 | 2015-06-22 | ZDF-1460 SS+50d, ZAF-1110, ZDF-1460 |  |  |  |  | 5d | 0d | Labour [2725.75 h]; Surveyor [2725.75 h]; Mobile Crane [2725.75 h]; Supervisor [2725.75 h] | 8,178 |  | DFCR | BVFC |

| ID | WBS | Activity | Duration | Start | Finish | Predecessors | Total float | Free float | Resources | Cost | Devision-02 | FCC Scope |
| --- | --- | --- | --- | --- | --- | --- | --- | --- | --- | --- | --- | --- |
|  | 1 | **ZONE-A (0+000 --- 4+000)** |  | 2014-05-24 | 2015-03-12 |  |  |  |  |  |  |  |
|  | 1 | **ZONE-A (1+000 --- 4+000) (Priority-3.1)(300)** |  | 2014-06-25 | 2015-02-05 |  |  |  |  |  |  |  |
| ZAF-1000 |  | SITE PREPARATION (GRADING / LEVELING) | 25d | 2014-06-25 | 2014-07-20 | ZAF-1060 FS+12.5d | 4.25d | 0d | Labour [1946 h]; Excavator [1946 h]; Supervisor [1946 h]; Dump Truck [1946 h] | 3,892 | DFCR |  |
| ZAF-1010 |  | ENGINEERING SELLECTFILL, COMPACTION & BLINDING | 87.5d | 2014-07-20 | 2014-10-15 | ZAF-1000 | 4.25d | 0d | Labour [865 h]; Supervisor [865 h]; Dump Truck [865 h] | 1,730 | DFCR |  |
| ZAF-1020 |  | WATER PROOFING (FOUNDATION) | 87.5d | 2014-07-26 | 2014-10-22 | ZAF-1010 SS+6.25d | 4.25d | 0d | Labour [2076 h]; Lumpsum [200]; Supervisor [2076 h] | 2,076 | DFCR | BVFC |
| ZAF-1030 |  | PRECAST FOOTING/FOUNDATION (Installation) | 87.5d | 2014-08-08 | 2014-11-03 | ZAF-1020 SS+12.5d | 4.25d | 0d | Labour [2742.25 h]; Supervisor [2742.25 h]; Mobile Crane [2742.25 h]; Surveyor [2742.25 h] | 8,226 | DFCR | BVFC |
| ZAF-1040 |  | PRECAST COLUMNS (Installation) | 87.5d | 2014-08-20 | 2014-11-16 | ZAF-1030 SS+12.5d | 4.25d | 0d | Labour [1686.5 h]; Supervisor [1686.5 h]; Mobile Crane [1686.5 h]; Surveyor [1686.5 h] | 5,061 | DFCR | BVFC |
| ZAF-1050 |  | PRECAST PANELS (Installation) | 81.25d | 2014-11-16 | 2015-02-05 | ZAF-1040 | 4.25d | 0d | Labour [4411 h]; Surveyor [4411 h]; Mobile Crane [4411 h]; Supervisor [4411 h] | 13,233 | DFCR | BVFC |
|  | 2 | **ZONE-A (0+000 --- 1+000) (Priority-3.2)(1000)** |  | 2014-05-24 | 2015-03-12 |  |  |  |  |  |  |  |
| ZAF-1060 |  | SITE PREPARATION (GRADING / LEVELING) | 20d | 2014-05-24 | 2014-06-12 | ZCF-1300 FS+60d | 4.25d | 0d | Labour [648.75 h]; Excavator [648.75 h]; Supervisor [648.75 h]; Dump Truck [648.75 h] | 1,298 | DFCR |  |
| ZAF-1070 |  | ENGINEERING SELLECTFILL, COMPACTION & BLINDING | 31.25d | 2014-06-13 | 2014-07-14 | ZAF-1060 | 16.75d | 0d | Labour [621.67 h]; Supervisor [621.67 h]; Dump Truck [621.67 h] | 1,244 | DFCR |  |
| ZAF-1080 |  | WATER PROOFING (FOUNDATION) | 31.25d | 2014-07-14 | 2014-08-14 | ZAF-1070 | 16.75d | 0d | Labour [697 h]; Lumpsum [200]; Supervisor [697 h] | 697 | DFCR | BVFC |
| ZAF-1090 |  | PRECAST FOOTING/FOUNDATION (Installation) | 31.25d | 2014-08-14 | 2014-09-14 | ZAF-1080 | 16.75d | 0d | Labour [2081.25 h]; Supervisor [2081.25 h]; Mobile Crane [2081.25 h]; Surveyor [2081.25 h] | 6,243 | DFCR | BVFC |
| ZAF-1100 |  | PRECAST COLUMNS (Installation) | 31.25d | 2014-09-14 | 2014-10-15 | ZAF-1090 | 16.75d | 12.5d | Labour [1062.25 h]; Supervisor [1062.25 h]; Mobile Crane [1062.25 h]; Surveyor [1062.25 h] | 3,186 | DFCR | BVFC |
| ZAF-1110 |  | PRECAST PANELS (Installation) | 35d | 2015-02-05 | 2015-03-12 | ZAF-1100 FS+100d, ZAF-1050 | 4.25d | 0d | Labour [3220.25 h]; Surveyor [3220.25 h]; Mobile Crane [3220.25 h]; Supervisor [3220.25 h] | 9,660 | DFCR | BVFC |
|  | 5 | **CULVERT & SLIDING GATES** |  | 2014-04-12 | 2015-08-09 |  |  |  |  |  |  |  |
|  | 1 | **SLIDING GATES** |  | 2015-04-02 | 2015-08-09 |  |  |  |  |  |  |  |
| CCG-2-1010 |  | GATE # 2 | 25d | 2015-04-02 | 2015-04-26 | BBS1030 | 5d | 0d | Dump Truck [1946.95 h]; Supervisor [11.68 h]; Grader [11.68 h]; Engineer [11.68 h] | 1,971 | DFCR |  |
| CCG-2-1020 |  | GATE # 3 | 25d | 2015-04-27 | 2015-05-21 | CCG-2-1010 | 5d | 0d | CARPANTER [1958.95 h]; Labour [5.76 h]; Engineer [5.76 h]; Steel Fixer [5.76 h]; Concrete Pump [5.76 h] | 1,983 | DFCR | BVFC |
| CCG-2-1030 |  | MARIN GATE-1 | 37.5d | 2015-05-22 | 2015-06-28 | CCG-2-1020 | 5d | 0d | CARPANTER [4082.18 h]; Labour [10.21 h]; Steel Fixer [10.21 h]; Engineer [10.21 h]; Concrete Pump [10.21 h] | 4,122 | DFCR | BVFC |
| CCG-2-1040 |  | MARINE GATE-2 | 38d | 2015-06-28 | 2015-08-05 | CCG-2-1030 | 5d | 0d | CARPANTER [4061.52 h]; Labour [15.62 h]; Engineer [15.62 h]; Steel Fixer [15.62 h]; Concrete Pump [15.62 h] | 4,126 | DFCR | BVFC |
| CCG-2-1000 |  | GATE # 1 | 25d | 2015-07-15 | 2015-08-09 | CCG-2-1040 FF+4d | 16.5d | 16.25d | Excavator [1359.46 h]; Labour [991 h]; Engineer [991 h] | 1,982 | DFCR |  |
|  | 2 | **WADI AL KHULAIS** |  | 2014-04-12 | 2014-12-17 |  |  |  |  |  |  |  |
| CCG-4-1000 |  | EXCAVATION FOR CULVERT | 30d | 2014-04-12 | 2014-05-11 | ZDDI-1060 FS+13d | 0d |  | Engineer [3659.67 h]; Excavator [10.16 h]; Labour [20.33 h] | 3,680 | DFCR |  |
| CCG-4-1010 |  | ENGINEERING BACKFILLING AND COMPACTION | 30d | 2014-05-12 | 2014-06-10 | CCG-4-1000 | 0d |  | Labour [1778.85 h]; Engineer [17.79 h]; Supervisor [17.79 h]; Grader [17.79 h]; Dump Truck [17.79 h] | 1,833 | DFCR |  |
| CCG-4-1020 |  | BAS SLAB | 75d | 2014-06-11 | 2014-08-24 | CCG-4-1010 | 0d |  | CARPANTER [2220 h]; Labour [2220 h]; Engineer [2220 h]; Steel Fixer [2220 h]; Concrete Pump [2220 h] | 11,100 | DFCR | BVFC |
| CCG-4-1030 |  | SIDE WALLS | 81.25d | 2014-08-25 | 2014-11-14 | CCG-4-1020 | 0d |  | CARPANTER [9164.09 h]; Labour [17.18 h]; Engineer [17.18 h]; Steel Fixer [17.18 h]; Supervisor [17.18 h]; Concrete Pump [17.18 h] | 9,232 | DFCR | BVFC |
| CCG-4-1040 |  | TOP SLAB | 90d | 2014-09-19 | 2014-12-17 | CCG-4-1030 SS+25d | 0d |  | CARPANTER [11284 h]; Labour [23.51 h]; Engineer [23.51 h]; Steel Fixer [23.51 h]; Concrete Pump [23.51 h] | 11,380 | DFCR | BVFC |

| ID | WBS | Activity | Duration | Start | Finish | Predecessors | Complete | Remaining | Planned start | Planned finish | Total float | Free float | Resources | Cost | Actual cost | Devision-02 |
| --- | --- | --- | --- | --- | --- | --- | --- | --- | --- | --- | --- | --- | --- | --- | --- | --- |
|  | 4 | **ROADS** |  | 2014-03-01 | 2015-08-25 |  |  |  |  |  |  |  |  |  |  |  |
|  | 1 | **ZONE-A (0+000 --- 4+000)** |  | 2014-03-01 | 2015-04-27 |  |  |  |  |  |  |  |  |  |  |  |
|  | 3 | **KAM ACCESS ROAD (0+000 --- 2+000) (Priority-2)** |  | 2014-03-01 | 2014-07-14 |  |  |  |  |  |  |  |  |  |  |  |
| KAR-1000 |  | SITE GRADING & REMOVING OF DEBRIS | 12.5d | 2014-03-01 A | 2014-04-18 | ED-1110 |  | 12.5d | 2014-04-06 | 2014-04-18 | 37.75d | 0d | Labour [419.6 h]; Grader [419.6 h]; Dump Truck [419.6 h]; Surveyor [419.6 h]; Supervisor [419.6 h] | 1,680 |  | DFCR |
| KAR-1010 |  | SELECT FILL & COMPACTION | 37.5d | 2014-04-01 A | 2014-05-10 | ZDDI-1040 | 10% | 35d | 2014-04-06 | 2014-05-13 | 24.25d | 0d | Labour [1528.33 h]; Dump Truck [1528.33 h]; Supervisor [1528.33 h] | 3,056 | 204 | DFCR |
| KAR-1020 |  | SUB BASE | 18.75d | 2014-05-11 | 2014-05-29 | KAR-1010 |  |  |  |  | 24.25d | 0d | Labour [548.83 h]; Grader [548.83 h]; Supervisor [548.83 h]; Dump Truck [548.83 h]; Surveyor [548.83 h]; Compactor [548.83 h] | 2,196 |  | DFCR |
| KAR-1030 |  | BASE COURSE | 15d | 2014-05-29 | 2014-06-13 | KAR-1020 |  |  |  |  | 24.25d | 0d | Labour [823.25 h]; Supervisor [823.25 h]; Surveyor [823.25 h]; Compactor [823.25 h] | 1,646 |  | DFCR |
| KAR-1040 |  | CURING AGENT (R.C OR M.C) | 6.25d | 2014-06-13 | 2014-06-19 | KAR-1030 |  |  |  |  | 24.25d | 0d | Labour [219.6 h]; Engineer [219.6 h]; Supervisor [219.6 h]; Concrete Pump [219.6 h]; Surveyor [219.6 h] | 880 |  | DFCR |
| KAR-1050 |  | BINDER COURSE (6cm) | 12.5d | 2014-06-20 | 2014-07-02 | KAR-1040 |  |  |  |  | 24.25d | 0d | Labour [1097.5 h]; Lumpsum [100]; Supervisor [1097.5 h] | 1,098 |  | DFCR |
| KAR-1060 |  | COMPACTION | 10d | 2014-06-22 | 2014-07-02 | KAR-1050 FF |  |  |  |  | 24.25d | 0d | Labour [274.5 h]; Surveyor [274.5 h]; Compactor [274.5 h]; Supervisor [274.5 h] | 550 |  | DFCR |
| KAR-1070 |  | WEARING COURSE (8cm) | 12.5d | 2014-07-02 | 2014-07-14 | KAR-1060 |  |  |  |  | 24.25d | 0d | Labour [3293 h]; Lumpsum [150] | 3,293 |  | DFCR |
|  | 4 | **KAM ACCESS ROAD (2+100 --- 4+070) (Priority-3)** |  | 2014-07-17 | 2014-11-15 |  |  |  |  |  |  |  |  |  |  |  |
| KAR-2-1000 |  | SITE GRADING & REMOVING OF DEBRIS | 26d | 2014-07-17 | 2014-08-12 | KAR-1070 SS, KAR-1000 FS+18.75d, ZAF-1060 SS, CKAR-RL-100 FS+80d |  |  |  |  | 37.75d | 0d | Labour [331.8 h]; Grader [331.8 h]; Dump Truck [331.8 h]; Surveyor [331.8 h]; Supervisor [331.8 h] | 1,328 |  | DFCR |
| KAR-2-1010 |  | SELECT FILL & COMPACTION | 12.5d | 2014-08-25 | 2014-09-06 | KAR-2-1000 FS+12.5d |  |  |  |  | 37.75d | 0d | Labour [1150.33 h]; Dump Truck [1150.33 h]; Supervisor [1150.33 h] | 2,300 |  | DFCR |
| KAR-2-1020 |  | SUB BASE | 12.5d | 2014-09-06 | 2014-09-18 | KAR-2-1010 |  |  |  |  | 37.75d | 0d | Labour [329.33 h]; Grader [329.33 h]; Supervisor [329.33 h]; Dump Truck [329.33 h]; Surveyor [329.33 h]; Compactor [329.33 h] | 1,316 |  | DFCR |
| KAR-2-1030 |  | BASE COURSE | 15d | 2014-09-19 | 2014-10-03 | KAR-2-1020 |  |  |  |  | 37.75d | 0d | Labour [494 h]; Supervisor [494 h]; Surveyor [494 h]; Compactor [494 h] | 988 |  | DFCR |
| KAR-2-1040 |  | CURING AGENT (R.C OR M.C) | 6.25d | 2014-10-04 | 2014-10-10 | KAR-2-1030 |  |  |  |  | 37.75d | 0d | Labour [131.8 h]; Engineer [131.8 h]; Supervisor [131.8 h]; Concrete Pump [131.8 h]; Surveyor [131.8 h] | 528 |  | DFCR |
| KAR-2-1050 |  | BINDER COURSE (6cm) | 12.5d | 2014-10-10 | 2014-10-22 | KAR-2-1040 |  |  |  |  | 37.75d | 0d | Labour [658.5 h]; Lumpsum [100]; Supervisor [658.5 h] | 659 |  | DFCR |
| KAR-2-1060 |  | COMPACTION | 10d | 2014-10-22 | 2014-11-01 | KAR-2-1050 |  |  |  |  | 37.75d | 0d | Labour [289.75 h]; Surveyor [289.75 h]; Compactor [289.75 h]; Supervisor [289.75 h] | 580 |  | DFCR |
| KAR-2-1070 |  | WEARING COURSE (8cm) | 14d | 2014-11-01 | 2014-11-15 | KAR-2-1060 |  |  |  |  | 37.75d | 37.5d | Labour [1976 h]; Lumpsum [150] | 1,976 |  | DFCR |
|  | 6 | **KAM ACCESS ROAD(3+000--4+070)RELOCATION OF EXISTING FENCE+SECURITY SYSTEMS** |  | 2014-03-01 | 2014-04-28 |  |  |  |  |  |  |  |  |  |  |  |
| CKAR-RL-100 |  | RELOCATING OF EXISTING FENCE+SECURITY SYSTEMS | 46d | 2014-03-01 A | 2014-04-28 | KAR-1000 | 80% | 10d | 2014-04-18 | 2014-06-03 | 37.75d | 0d | Mobile Crane [1720.4 h]; Loader [1720.4 h]; Dump Truck [1720.4 h]; Supervisor [1720.4 h]; Labour [1720.4 h] | 6,880 | 5,384 | DFCR |
|  | 1 | **MAINTENANCE ROAD (0+000 --- 1+000) (Priority-4.2)(1000) & (1+000 --- 4+000) (Priority-3)(300)** |  | 2015-01-28 | 2015-04-27 |  |  |  |  |  |  |  |  |  |  |  |
| ZAMR-1000 |  | SITE GRADING & REMOVING OF DEBRIS | 18.75d | 2015-01-28 | 2015-02-16 | ZAF-1070, ZAF-1110 SS-8d |  |  |  |  | 4.25d | 0d | Labour [512.8 h]; Grader [512.8 h]; Dump Truck [512.8 h]; Surveyor [512.8 h]; Supervisor [512.8 h] | 2,052 |  | DFCR |
| ZAMR-1010 |  | SELECT FILL & COMPACTION | 30d | 2015-02-11 | 2015-03-13 | ZAMR-1000 FS-5d, ZAF-1090 SS |  |  |  |  | 4.25d | 0d | Labour [1129 h]; Dump Truck [1129 h]; Supervisor [1129 h] | 2,258 |  | DFCR |
| ZAMR-1020 |  | SUB BASE | 33.75d | 2015-02-17 | 2015-03-23 | ZAMR-1010 SS+6.25d |  |  |  |  | 24.25d | 0d | Labour [282.17 h]; Grader [282.17 h]; Supervisor [282.17 h]; Dump Truck [282.17 h]; Surveyor [282.17 h]; Compactor [282.17 h] | 1,128 |  | DFCR |
| ZAMR-1030 |  | BASE COURSE | 35d | 2015-02-23 | 2015-03-30 | ZAMR-1020 SS+6.25d |  |  |  |  | 24.25d | 0d | Labour [423.25 h]; Supervisor [423.25 h]; Surveyor [423.25 h]; Compactor [423.25 h] | 846 |  | DFCR |
| ZAMR-1040 |  | CURING AGENT (R.C OR M.C) | 38.75d | 2015-03-02 | 2015-04-09 | ZAMR-1030 SS+6.25d |  |  |  |  | 24.25d | 0d | Labour [112.8 h]; Engineer [112.8 h]; Supervisor [112.8 h]; Concrete Pump [112.8 h]; Surveyor [112.8 h] | 452 |  | DFCR |
| ZAMR-1050 |  | BINDER COURSE (6cm) | 38.75d | 2015-03-08 | 2015-04-15 | ZAMR-1040 SS+6.25d |  |  |  |  | 24.25d | 0d | Labour [564.5 h]; Lumpsum [100]; Supervisor [564.5 h] | 565 |  | DFCR |
| ZAMR-1060 |  | COMPACTION | 37.5d | 2015-03-14 | 2015-04-20 | ZAMR-1050 SS+6.25d |  |  |  |  | 24.25d | 0d | Labour [391 h]; Surveyor [391 h]; Compactor [391 h]; Supervisor [391 h] | 782 |  | DFCR |
| ZAMR-1070 |  | WEARING COURSE (8cm) | 37.5d | 2015-03-20 | 2015-04-27 | ZAMR-1060 SS+6.25d |  |  |  |  | 24.25d | 24.5d | Labour [1693 h]; Lumpsum [150] | 1,693 |  | DFCR |

| ID | WBS | Activity | Duration | Start | Finish | Predecessors | Total float | Free float | Resources | Cost | Devision-02 |
| --- | --- | --- | --- | --- | --- | --- | --- | --- | --- | --- | --- |
|  | 2 | **PATROL ROAD (0+000 --- 1+000) (Priority-4.2)(1000) & (1+000 --- 4+000) (Priority-3)(300)** |  | 2015-02-16 | 2015-04-20 |  |  |  |  |  |  |
| ZAPR-1000 |  | SITE GRADING & REMOVING OF DEBRIS | 35d | 2015-02-16 | 2015-03-23 | ZAMR-1000 | 5.5d | 0d | Labour [363 h]; Grader [363 h]; Dump Truck [363 h]; Surveyor [363 h]; Supervisor [363 h] | 1,452 | DFCR |
| ZAPR-1010 |  | SELECT FILL & COMPACTION | 16.25d | 2015-02-16 | 2015-03-04 | ZAPR-1000 SS, ZAF-1090 SS | 5.5d | 0d | Labour [1223 h]; Supervisor [1223 h]; Dump Truck [1223 h]; Surveyor [1223 h] | 3,669 | DFCR |
| ZAPR-1020 |  | SUB BASE | 18.75d | 2015-02-22 | 2015-03-13 | ZAPR-1010 SS+6.25d | 5.5d | 0d | Labour [489.2 h]; Grader [489.2 h]; Dump Truck [489.2 h]; Compactor [489.2 h]; Surveyor [489.2 h] | 1,956 | DFCR |
| ZAPR-1030 |  | BASE COURSE | 21.25d | 2015-02-28 | 2015-03-21 | ZAPR-1020 SS+6.25d | 5.5d | 0d | Labour [407.67 h]; Grader [407.67 h]; Dump Truck [407.67 h]; Supervisor [407.67 h]; Surveyor [407.67 h]; Compactor [407.67 h] | 1,632 | DFCR |
| ZAPR-1040 |  | CURING AGENT (R.C OR M.C) | 23.75d | 2015-03-07 | 2015-03-30 | ZAPR-1030 SS+6.25d | 5.5d | 0d | Labour [407.5 h]; Supervisor [407.5 h] | 408 | DFCR |
| ZAPR-1050 |  | BINDER COURSE (6cm) | 26.25d | 2015-03-13 | 2015-04-08 | ZAPR-1040 SS+6.25d | 5.5d | 0d | Labour [815.5 h]; Supervisor [815.5 h] | 816 | DFCR |
| ZAPR-1060 |  | COMPACTION | 26.25d | 2015-03-19 | 2015-04-14 | ZAPR-1050 SS+6.25d | 5.5d | 0d | Labour [605 h]; Supervisor [605 h]; Compactor [605 h] | 605 | DFCR |
| ZAPR-1070 |  | WEARING COURSE (8cm) | 26.25d | 2015-03-25 | 2015-04-20 | ZAPR-1060 SS+6.25d | 5.5d | 5.75d | Labour [2446 h]; Lumpsum [150] | 2,446 | DFCR |
|  | 2 | **ZONE-B (4+000 --- 7+000)** |  | 2015-01-12 | 2015-08-10 |  |  |  |  |  |  |
|  | 1 | **MAINTENANCE ROAD (5+550 --- 7+000) (Priority-1.1)(1450) & (4+000 --- 5+550) (Priority-5)(1550)** |  | 2015-01-12 | 2015-06-26 |  |  |  |  |  |  |
| ZBMR-1000 |  | SITE GRADING & REMOVING OF DEBRIS | 18d | 2015-01-12 | 2015-01-30 | ZBF-1130, ZBF-1170 FS+90d | 0.25d | 0d | Labour [302.4 h]; Grader [302.4 h]; Supervisor [302.4 h]; Dump Truck [302.4 h]; Surveyor [302.4 h] | 1,208 | DFCR |
| ZBMR-1010 |  | SELECT FILL & COMPACTION | 45d | 2015-01-30 | 2015-03-16 | ZBF-1150, ZBMR-1000 | 21.5d | 0d | Labour [767.5 h]; Supervisor [767.5 h]; Dump Truck [767.5 h]; Grader [767.5 h] | 2,304 | DFCR |
| ZBMR-1020 |  | SUB BASE | 30d | 2015-03-06 | 2015-04-05 | ZBMR-1010 SS+35d | 21.5d | 0d | Labour [307 h]; Dump Truck [307 h]; Supervisor [307 h]; Compactor [307 h]; Grader [307 h] | 921 | DFCR |
| ZBMR-1030 |  | BASE COURSE | 48d | 2015-03-25 | 2015-05-12 | ZBMR-1020 SS+18.75d | 21.5d | 0d | Labour [307 h]; Grader [307 h]; Supervisor [307 h]; Surveyor [307 h]; Compactor [307 h] | 921 | DFCR |
| ZBMR-1040 |  | CURING AGENT (R.C OR M.C) | 28d | 2015-04-20 | 2015-05-18 | ZBMR-1030 SS+26.25d | 21.5d | 0d | Labour [512 h] | 512 | DFCR |
| ZBMR-1050 |  | BINDER COURSE (6cm) | 14d | 2015-05-17 | 2015-05-30 | ZBMR-1040 SS+26.25d | 21.5d | 0d | Labour [511.5 h]; Supervisor [511.5 h]; Lumpsum [100] | 512 | DFCR |
| ZBMR-1060 |  | COMPACTION | 24d | 2015-05-23 | 2015-06-16 | ZBMR-1050 SS+6.25d | 21.5d | 0d | Labour [504 h]; Supervisor [504 h]; Compactor [504 h] | 504 | DFCR |
| ZBMR-1070 |  | WEARING COURSE (8cm) | 28d | 2015-05-29 | 2015-06-26 | ZBMR-1060 SS+6.25d | 21.5d | 21.75d | Labour [511.67 h]; Supervisor [511.67 h]; Lumpsum [150]; Compactor [511.67 h] | 512 | DFCR |
|  | 2 | **PATROL ROAD (5+550 --- 7+000) (Priority-1.1)(1450) & (4+000 --- 5+550) (Priority-5)(1550)** |  | 2015-01-30 | 2015-08-10 |  |  |  |  |  |  |
| ZBPR-1000 |  | SITE GRADING & REMOVING OF DEBRIS | 20d | 2015-01-30 | 2015-02-19 | ZBMR-1000, ZBF-1130 SS | 0.25d | 0d | Labour [442 h]; Grader [442 h]; Supervisor [442 h]; Dump Truck [442 h] | 1,326 | DFCR |
| ZBPR-1010 |  | SELECT FILL & COMPACTION | 84d | 2015-02-19 | 2015-05-14 | ZBPR-1000, ZBF-1150 SS | 0.25d | 0d | Labour [1151.5 h]; Supervisor [1151.5 h]; Dump Truck [1151.5 h]; Surveyor [1151.5 h] | 3,456 | DFCR |
| ZBPR-1020 |  | SUB BASE | 78d | 2015-03-10 | 2015-05-27 | ZBPR-1010 SS+18.75d | 0.25d | 0d | Labour [460.6 h]; Grader [460.6 h]; Supervisor [460.6 h]; Dump Truck [460.6 h]; Surveyor [460.6 h] | 1,844 | DFCR |
| ZBPR-1030 |  | BASE COURSE | 74d | 2015-03-29 | 2015-06-11 | ZBPR-1020 SS+18.75d | 0.25d | 0d | Labour [460.6 h]; Grader [460.6 h]; Supervisor [460.6 h]; Dump Truck [460.6 h]; Surveyor [460.6 h] | 1,844 | DFCR |
| ZBPR-1040 |  | CURING AGENT (R.C OR M.C) | 54d | 2015-04-24 | 2015-06-17 | ZBPR-1030 SS+26.25d | 0.25d | 0d | Labour [384 h]; Supervisor [384 h]; Lumpsum [100] | 384 | DFCR |
| ZBPR-1050 |  | BINDER COURSE (6cm) | 40d | 2015-05-20 | 2015-06-29 | ZBPR-1040 SS+26.25d | 0.25d | 0d | Labour [767.5 h]; Supervisor [767.5 h]; Lumpsum [150] | 768 | DFCR |
| ZBPR-1060 |  | COMPACTION | 24d | 2015-06-16 | 2015-07-09 | ZBPR-1050 SS+26.25d | 0.25d | 0d | Labour [589.33 h]; Supervisor [589.33 h]; Compactor [589.33 h] | 589 | DFCR |
| ZBPR-1070 |  | WEARING COURSE (8cm) | 49d | 2015-06-22 | 2015-08-10 | ZBPR-1060 SS+6.25d | 0.25d | 0d | Labour [767.67 h]; Supervisor [767.67 h]; Surveyor [767.67 h] | 1,536 | DFCR |

| ID | WBS | Activity | Duration | Start | Finish | Predecessors | Total float | Free float | Resources | Cost | Devision-02 |
| --- | --- | --- | --- | --- | --- | --- | --- | --- | --- | --- | --- |
|  | 3 | **ZONE-C (7+000 --- 10+900)** |  | 2015-02-28 | 2015-08-25 |  |  |  |  |  |  |
|  | 1 | **MAINTENANCE ROAD (7+000 --- 8+950) (Priority-1.2)(1950) & (9+200 --- 10+900) (Priority-2.2)(1700)** |  | 2015-02-28 | 2015-08-03 |  |  |  |  |  |  |
| ZCMR-1000 |  | SITE GRADING & REMOVING OF DEBRIS | 20d | 2015-02-28 | 2015-03-19 | ZCF-1250, ZCF-1290 | -0.25d | 0d | Labour [636.25 h]; Grader [636.25 h]; Supervisor [636.25 h]; Surveyor [636.25 h] | 1,908 | DFCR |
| ZCMR-1010 |  | SELECT FILL & COMPACTION | 61d | 2015-03-02 | 2015-05-02 | ZCMR-1000 SS+2.5d, ZCF-1270 SS | -0.25d | 0d | Labour [544.67 h]; Grader [544.67 h]; Supervisor [544.67 h]; Dump Truck [544.67 h]; Surveyor [544.67 h]; Compactor [544.67 h] | 2,180 | DFCR |
| ZCMR-1020 |  | SUB BASE | 58d | 2015-03-15 | 2015-05-11 | ZCMR-1010 SS+12.5d | -0.25d | 0d | Labour [272.33 h]; Grader [272.33 h]; Supervisor [272.33 h]; Dump Truck [272.33 h]; Surveyor [272.33 h]; Compactor [272.33 h] | 1,088 | DFCR |
| ZCMR-1030 |  | BASE COURSE | 71d | 2015-03-27 | 2015-06-06 | ZCMR-1020 SS+12.5d | -0.25d | 0d | Labour [272.33 h]; Grader [272.33 h]; Supervisor [272.33 h]; Dump Truck [272.33 h]; Surveyor [272.33 h]; Compactor [272.33 h] | 1,088 | DFCR |
| ZCMR-1040 |  | CURING AGENT (R.C OR M.C) | 63d | 2015-04-11 | 2015-06-13 | ZCMR-1030 SS+15d | -0.25d | 0d | Labour [272.5 h]; Supervisor [272.5 h] | 273 | DFCR |
| ZCMR-1050 |  | BINDER COURSE (6cm) | 89d | 2015-04-17 | 2015-07-15 | ZCMR-1040 SS+6.25d | -0.25d | 0d | Labour [363 h]; Supervisor [363 h]; Surveyor [363 h]; Lumpsum [100] | 726 | DFCR |
| ZCMR-1060 |  | COMPACTION | 95d | 2015-04-24 | 2015-07-27 | ZCMR-1050 SS+6.25d | -0.25d | 0d | Labour [515 h]; Supervisor [515 h]; Compactor [515 h] | 515 | DFCR |
| ZCMR-1070 |  | WEARING COURSE (8cm) | 95d | 2015-04-30 | 2015-08-03 | ZCMR-1060 SS+6.25d | -0.25d | 0d | Labour [408.5 h]; Supervisor [408.5 h]; Dump Truck [408.5 h]; Compactor [408.5 h] | 818 | DFCR |
|  | 2 | **PATROL ROAD (7+000 --- 8+950) (Priority-1.2)(1950) & (9+200 --- 10+900) (Priority-2.2)(1700)** |  | 2015-04-01 | 2015-08-25 |  |  |  |  |  |  |
| ZCPR-1000 |  | SITE GRADING & REMOVING OF DEBRIS | 20d | 2015-04-01 | 2015-04-21 | ZCMR-1000 FS+12.5d, ZCF-1250 SS | 0d |  | Labour [454.25 h]; Supervisor [454.25 h]; Surveyor [454.25 h]; Grader [454.25 h] | 1,362 | DFCR |
| ZCPR-1010 |  | SELECT FILL & COMPACTION | 59d | 2015-04-21 | 2015-06-19 | ZCPR-1000, ZCF-1270 SS | 0d |  | Labour [1225.5 h]; Supervisor [1225.5 h]; Dump Truck [1225.5 h]; Surveyor [1225.5 h] | 3,678 | DFCR |
| ZCPR-1020 |  | SUB BASE | 60d | 2015-05-04 | 2015-07-02 | ZCPR-1010 SS+12.5d | 0d |  | Labour [490.2 h]; Supervisor [490.2 h]; Surveyor [490.2 h]; Compactor [490.2 h]; Dump Truck [490.2 h] | 1,470 | DFCR |
| ZCPR-1030 |  | BASE COURSE | 58d | 2015-05-16 | 2015-07-13 | ZCPR-1020 SS+12.5d | 0d |  | Labour [490.2 h]; Supervisor [490.2 h]; Surveyor [490.2 h]; Compactor [490.2 h]; Dump Truck [490.2 h] | 1,470 | DFCR |
| ZCPR-1040 |  | CURING AGENT (R.C OR M.C) | 51d | 2015-05-31 | 2015-07-21 | ZCPR-1030 SS+15d | 0d |  | Labour [408.5 h]; Supervisor [408.5 h]; Lumpsum [100] | 409 | DFCR |
| ZCPR-1050 |  | BINDER COURSE (6cm) | 54d | 2015-06-06 | 2015-07-30 | ZCPR-1040 SS+6.25d | 0d |  | Labour [544.67 h]; Supervisor [544.67 h]; Lumpsum [150]; Compactor [544.67 h] | 545 | DFCR |
| ZCPR-1060 |  | COMPACTION | 56d | 2015-06-13 | 2015-08-07 | ZCPR-1050 SS+6.25d | 0d |  | Labour [329.25 h]; Supervisor [329.25 h]; Surveyor [329.25 h]; Compactor [329.25 h] | 658 | DFCR |
| ZCPR-1070 |  | WEARING COURSE (8cm) | 64d | 2015-06-23 | 2015-08-25 | ZCPR-1060 SS+10d | 0d | 0.25d | Labour [490.2 h]; Supervisor [490.2 h]; Dump Truck [490.2 h]; Surveyor [490.2 h]; Compactor [490.2 h] | 1,470 | DFCR |
|  | 4 | **ZONE-D (10+900 --- 14+820)** |  | 2015-03-20 | 2015-08-17 |  |  |  |  |  |  |
|  | 1 | **MAINTENANCE ROAD (10+900 --- 13+100) (Priority-2.1)(2200) & (13+100 --- 14+820) (Priority-4.1)(1720)** |  | 2015-03-20 | 2015-08-17 |  |  |  |  |  |  |
| ZDMR-1000 |  | SITE GRADING & REMOVING OF DEBRIS | 18.75d | 2015-03-20 | 2015-04-07 | ZDF-1370 SS-15d | 11d | 7.5d | Labour [375 h]; Supervisor [375 h]; Grader [375 h]; Dump Truck [375 h]; Surveyor [375 h] | 1,500 | DFCR |
| ZDMR-1010 |  | SELECT FILL & COMPACTION | 31d | 2015-04-15 | 2015-05-16 | ZDMR-1000, ZDF-1390 SS | 3.5d | 0d | Labour [572 h]; Supervisor [572 h]; Dump Truck [572 h]; Surveyor [572 h]; Compactor [572 h] | 1,716 | DFCR |
| ZDMR-1020 |  | SUB BASE | 48d | 2015-05-04 | 2015-06-20 | ZDMR-1010 SS+18.75d | 3.5d | 0d | Labour [238.33 h]; Supervisor [238.33 h]; Dump Truck [238.33 h]; Grader [238.33 h]; Surveyor [238.33 h]; Compactor [238.33 h] | 952 | DFCR |
| ZDMR-1030 |  | BASE COURSE | 43d | 2015-05-22 | 2015-07-04 | ZDMR-1020 SS+18.75d | 3.5d | 0d | Labour [238.33 h]; Grader [238.33 h]; Supervisor [238.33 h]; Dump Truck [238.33 h]; Surveyor [238.33 h]; Compactor [238.33 h] | 952 | DFCR |
| ZDMR-1040 |  | CURING AGENT (R.C OR M.C) | 33d | 2015-06-10 | 2015-07-13 | ZDMR-1030 SS+18.75d | 3.5d | 0d | Labour [238.5 h]; Supervisor [238.5 h]; Lumpsum [100] | 239 | DFCR |
| ZDMR-1050 |  | BINDER COURSE (6cm) | 15d | 2015-06-29 | 2015-07-14 | ZDMR-1040 SS+18.75d | 3.5d | 0d | Labour [238.25 h]; Supervisor [238.25 h]; Surveyor [238.25 h]; Compactor [238.25 h] | 476 | DFCR |
| ZDMR-1060 |  | COMPACTION | 25d | 2015-07-05 | 2015-07-30 | ZDMR-1050 SS+6.25d | 3.5d | 3.75d | Labour [244.25 h]; Supervisor [244.25 h]; Compactor [244.25 h]; Surveyor [244.25 h] | 488 | DFCR |
| ZDMR-1070 |  | WEARING COURSE (8cm) | 14d | 2015-08-03 | 2015-08-17 | ZDMR-1060 SS+10d, ZCMR-1070, ZDMR-1060 | -0.25d | 0d | Labour [357.5 h]; Supervisor [357.5 h]; Surveyor [357.5 h]; Compactor [357.5 h] | 716 | DFCR |

| ID | WBS | Activity | Duration | Start | Finish | Predecessors | Complete | Planned start | Planned finish | Total float | Free float | Constraint | Resources | Cost | Actual cost | Devision-02 | Devision-07 | Devision-03 | Devision-06 | Devision-04 | Devision-08 |
| --- | --- | --- | --- | --- | --- | --- | --- | --- | --- | --- | --- | --- | --- | --- | --- | --- | --- | --- | --- | --- | --- |
|  | 2 | **PATROL ROAD (10+900 --- 13+100) (Priority-2.1)(2200) & (13+100 --- 14+820) (Priority-4.1)(1720)** |  | 2015-04-04 | 2015-08-15 |  |  |  |  |  |  |  |  |  |  |  |  |  |  |  |  |
| ZDPR-1000 |  | SITE GRADING & REMOVING OF DEBRIS | 18.75d | 2015-04-04 | 2015-04-22 | ZDF-1370 SS |  |  |  | 16.25d | 0d |  | Labour [678.75 h]; Grader [678.75 h]; Supervisor [678.75 h]; Surveyor [678.75 h] | 2,037 |  | DFCR |  |  |  |  |  |
| ZDPR-1010 |  | SELECT FILL & COMPACTION | 41d | 2015-04-22 | 2015-06-02 | ZDF-1390 SS, ZDPR-1000 |  |  |  | 16.25d | 0d |  | Labour [858 h]; Supervisor [858 h]; Dump Truck [858 h]; Surveyor [858 h]; Compactor [858 h] | 2,574 |  | DFCR |  |  |  |  |  |
| ZDPR-1020 |  | SUB BASE | 34d | 2015-05-02 | 2015-06-05 | ZDPR-1010 SS+10d |  |  |  | 16.25d | 0d |  | Labour [429 h]; Supervisor [429 h]; Dump Truck [429 h]; Surveyor [429 h]; Compactor [429 h] | 1,287 |  | DFCR |  |  |  |  |  |
| ZDPR-1030 |  | BASE COURSE | 28d | 2015-05-21 | 2015-06-18 | ZDPR-1020 SS+18.75d |  |  |  | 16.25d | 0d |  | Labour [429 h]; Supervisor [429 h]; Dump Truck [429 h]; Surveyor [429 h]; Compactor [429 h] | 1,287 |  | DFCR |  |  |  |  |  |
| ZDPR-1040 |  | CURING AGENT (R.C OR M.C) | 25d | 2015-06-03 | 2015-06-27 | ZDPR-1030 SS+12.5d |  |  |  | 16.25d | 0d |  | Labour [357.5 h]; Lumpsum [100]; Supervisor [357.5 h] | 358 |  | DFCR |  |  |  |  |  |
| ZDPR-1050 |  | BINDER COURSE (6cm) | 29d | 2015-06-11 | 2015-07-10 | ZDPR-1040 SS+8.75d |  |  |  | 16.25d | 0d |  | Labour [357.5 h]; Supervisor [357.5 h]; Surveyor [357.5 h]; Compactor [357.5 h] | 716 |  | DFCR |  |  |  |  |  |
| ZDPR-1060 |  | COMPACTION | 28d | 2015-06-26 | 2015-07-24 | ZDPR-1050 SS+15d |  |  |  | 16.25d | 0d |  | Labour [303.75 h]; Supervisor [303.75 h]; Surveyor [303.75 h]; Compactor [303.75 h] | 608 |  | DFCR |  |  |  |  |  |
| ZDPR-1070 |  | WEARING COURSE (8cm) | 30d | 2015-07-16 | 2015-08-15 | ZDPR-1060 SS+20d |  |  |  | 16.25d | 16.5d |  | Labour [536.25 h]; Supervisor [536.25 h]; Surveyor [536.25 h]; Compactor [536.25 h] | 1,072 |  | DFCR |  |  |  |  |  |
|  | 3 | **LANDSCAPING (0+000 --- 14+820)** |  | 2014-12-13 | 2015-07-02 |  |  |  |  |  |  |  |  |  |  |  |  |  |  |  |  |
|  | 1 | **ALL STATIONS INCLUDING BUILDINGS** |  | 2014-12-13 | 2015-07-02 |  |  |  |  |  |  |  |  |  |  |  |  |  |  |  |  |
| LAND-1000 |  | 20 CM EXCAVATION FROM WALK WAY | 50d | 2014-12-13 | 2015-01-31 | KAR-1070 FS+151d |  |  |  | 24.25d | 7.75d |  | Labour [759.8 h]; Supervisor [759.8 h]; Surveyor [759.8 h]; Excavator [759.8 h]; Dump Truck [759.8 h] | 2,280 |  | DFCR |  |  |  |  |  |
| LAND-1010 |  | 15 CM GRAVEL DRAIN BACKFILLING | 40d | 2015-02-08 | 2015-03-20 | LAND-1000, DLS1060 |  |  |  | 16.5d | 0d |  | Labour [949.6 h]; Supervisor [949.6 h]; Dump Truck [949.6 h]; Surveyor [949.6 h]; Compactor [949.6 h] | 2,850 |  | DFCR |  |  |  |  |  |
| LAND-1020 |  | GEO TEXTILE WATER MEMBRANE | 44d | 2015-02-14 | 2015-03-30 | LAND-1010 FF+10d |  |  |  | 16.5d | 8.5d |  | Labour [1590.5 h]; Supervisor [1590.5 h] | 1,591 |  | DFCR |  |  |  |  |  |
| LAND-1030 |  | MIX SOIL | 35d | 2015-03-29 | 2015-05-03 | LAND-1020 FF+25d, POL1060 FS+225d |  |  |  | 8d | 0d |  | Labour [1266.33 h]; Dump Truck [1266.33 h]; Supervisor [1266.33 h] | 2,532 |  | DFCR |  |  |  |  |  |
| LAND-1040 |  | GRASSING/PLANTING | 75d | 2015-04-18 | 2015-07-02 | LAND-1030 SS+20d |  |  |  | 8d | 7.75d |  | Labour [4748 h]; Lumpsum [650] | 4,748 |  | DFCR |  |  |  |  |  |
|  | 2 | **BUILDINGS** |  | 2013-11-15 | 2015-07-04 |  |  |  |  |  |  |  |  |  |  |  |  |  |  |  |  |
|  | 5 | **POST GUARDS & VISITORS CENTER (GATE # 2 & 3)** |  | 2013-11-15 | 2015-01-15 |  |  |  |  |  |  |  |  |  |  |  |  |  |  |  |  |
|  | 1 | **CIVIL WORKS** |  | 2013-11-15 | 2014-08-26 |  |  |  |  |  |  |  |  |  |  |  |  |  |  |  |  |
| CBCPG-1000 |  | LEVELING | 2.5d | 2013-11-15 A | 2013-11-16 A | ED-1130, ED-1110 | 100% | 2013-11-15 | 2013-11-17 |  |  |  | Labour [85 h]; Grader [85 h] | 170 | 170 | DFCR |  |  |  |  |  |
| CBCPG-1010 |  | MATERIAL REPLACE AS SELECT FILL AND COMPACTION | 12d | 2014-05-01 | 2014-05-12 | CBCPG-1000 FS+6.25d |  |  |  | -0d | 0d | start on 2014-05-01 | Labour [259 h]; Lumpsum [50] | 259 |  | DFCR |  |  |  |  |  |
| CBCPG-1020 |  | TERMITE CONTROL | 10d | 2014-05-14 | 2014-05-24 | CBCPG-1010 FS+1.25d |  |  |  | 0.25d | 0d |  | Labour [135 h] | 135 |  |  | BTI |  |  |  |  |
| CBCPG-1030 |  | BLIND/LEAN CONCRETE | 10d | 2014-05-28 | 2014-06-06 | CBCPG-1020 FS+3.75d |  |  |  | 0.25d | 0d |  | Labour [91.75 h]; Concrete Pump [91.75 h]; Supervisor [91.75 h]; Surveyor [91.75 h] | 276 |  |  |  | BCW |  |  |  |
| CBCPG-1040 |  | WATER PROOFING | 8d | 2014-06-13 | 2014-06-21 | CBCPG-1030 FS+6.25d |  |  |  | 0.25d | 0d |  | Labour [243 h]; Lumpsum [30] | 243 |  |  | BTI |  |  |  |  |
| CBCPG-1050 |  | R.C FOUNDATION | 16d | 2014-06-23 | 2014-07-09 | CBCPG-1040 FS+2.5d |  |  |  | 0.25d | 0d |  | Labour [80.8 h]; CARPANTER [80.8 h]; Steel Fixer [80.8 h]; Supervisor [80.8 h]; Concrete Pump [80.8 h] | 324 |  |  |  | BCW |  |  |  |
| CBCPG-1060 |  | DUCT BANK OPENING | 18d | 2014-06-25 | 2014-07-12 | CBCPG-1050 SS+1.25d |  |  |  | 17d | 0d |  | Labour [93.5 h]; Supervisor [93.5 h] | 94 |  |  |  |  | BWP |  |  |
| CBCPG-1080 |  | BEAMS & COLUMNS | 15d | 2014-07-01 | 2014-07-16 | CBCPG-1050 SS+7.5d |  |  |  | 0.25d | 0d |  | Labour [87.83 h]; CARPANTER [87.83 h]; Steel Fixer [87.83 h]; Engineer [87.83 h]; Supervisor [87.83 h]; Concrete Pump [87.83 h] | 440 |  |  |  | BCW |  |  |  |
| CBCPG-1070 |  | UTILITY INSTALLATION | 20d | 2014-07-13 | 2014-08-01 | CBCPG-1050 SS, CBCPG-1060 |  |  |  | 17d | 0d |  | Labour [96.5 h]; Supervisor [96.5 h] | 97 |  |  |  |  | BWP |  |  |
| CBCPG-1090 |  | ROOF SLAB | 10d | 2014-07-16 | 2014-07-26 | CBCPG-1080 |  |  |  | 0.25d | 0d |  | Labour [89.17 h]; CARPANTER [89.17 h]; Engineer [89.17 h]; Steel Fixer [89.17 h]; Supervisor [89.17 h]; Concrete Pump [89.17 h] | 445 |  |  |  | BCW |  |  |  |
| CBCPG-1100 |  | MASONRY BLOCK WORKS | 15d | 2014-07-26 | 2014-08-10 | CBCPG-1090 |  |  |  | 0.25d | 0d |  | Labour [451 h] | 451 |  |  |  |  |  | BMW |  |
| CBCPG-1110 |  | OPENING WORKS (DOORS & WINDOWS) | 10d | 2014-08-16 | 2014-08-26 | CBCPG-1100 FS+6.25d |  |  |  | 0.25d | 0d |  | Labour [83.5 h]; Supervisor [83.5 h] | 84 |  |  |  |  |  |  | BDW |

| ID | WBS | Activity | Duration | Start | Finish | Predecessors | Complete | Planned start | Planned finish | Total float | Free float | Resources | Cost | Actual cost | Devision-15 | Devision-09 | Devision-08 | Devision-02 | Devision-07 | Devision-03 | Devision-06 | Devision-04 |
| --- | --- | --- | --- | --- | --- | --- | --- | --- | --- | --- | --- | --- | --- | --- | --- | --- | --- | --- | --- | --- | --- | --- |
|  | 2 | **ELECTRICAL & TELECOMMUNICATION SYSTEMS** |  | 2014-08-02 | 2014-09-13 |  |  |  |  |  |  |  |  |  |  |  |  |  |  |  |  |  |
| CBEPG-1120 |  | DUCT BANK (OUTSIDE PLANT) | 12.5d | 2014-08-02 | 2014-08-14 | CBCPG-1070 |  |  |  | 17d | 0d | Labour [107 h]; Supervisor [107 h] | 107 |  | MEP&LV |  |  |  |  |  |  |  |
| CBEPG-1130 |  | LOADER/TRAY FOR STRUCTURAL CABLING | 8.75d | 2014-08-14 | 2014-08-23 | CBEPG-1120 |  |  |  | 17d | 0d | Labour [121.5 h]; Supervisor [121.5 h] | 122 |  | MEP&LV |  |  |  |  |  |  |  |
| CBEPG-1140 |  | CABLING / WIRING | 6.25d | 2014-08-23 | 2014-08-29 | CBEPG-1130 |  |  |  | 17d | 0d | Labour [79.5 h]; Supervisor [79.5 h] | 80 |  | MEP&LV |  |  |  |  |  |  |  |
| CBEPG-1150 |  | EQUIPMENT/FIXTURES INSTALLATION ACCORDING TO STANDARD | 8.75d | 2014-09-01 | 2014-09-09 | CBEPG-1140 FS+2.5d |  |  |  | 17d | 0d | Labour [109.5 h]; Supervisor [109.5 h] | 110 |  | MEP&LV |  |  |  |  |  |  |  |
| CBEPG-1160 |  | TESTING AND COMMISSIONING | 3.75d | 2014-09-09 | 2014-09-13 | CBEPG-1150 |  |  |  | 17d | 10.5d | Engineer [107 h] | 107 |  | MEP&LV |  |  |  |  |  |  |  |
|  | 3 | **MECHANICAL WORKS** |  | 2014-07-31 | 2015-01-05 |  |  |  |  |  |  |  |  |  |  |  |  |  |  |  |  |  |
| CBMPG-1170 |  | DRAINAGE SYSTEM (PIPING) | 23d | 2014-07-31 | 2014-08-23 | CBCPG-1100 SS+5d |  |  |  | 6.5d | 0d | Labour [61.5 h]; Supervisor [61.5 h] | 62 |  | MEP&LV |  |  |  |  |  |  |  |
| CBMPG-1190 |  | HVAQ PIPING & ACCESSORIES WORKS | 25d | 2014-08-12 | 2014-09-06 | CBCPG-1090 FS+17.5d |  |  |  | 9.5d | 0d | Labour [75.5 h]; Supervisor [75.5 h] | 76 |  | MEP&LV |  |  |  |  |  |  |  |
| CBMPG-1200 |  | FIRE FIGHTING PIPING/PLUMBING WORKS | 18d | 2014-08-22 | 2014-09-09 | CBCPG-1100 FS+12.5d |  |  |  | 23.75d | 0d | Labour [74.5 h]; Supervisor [74.5 h] | 75 |  | MEP&LV |  |  |  |  |  |  |  |
| CBMPG-1180 |  | POTABLE WATER SYSTEM (PIPING) | 23d | 2014-08-23 | 2014-09-15 | CBMPG-1170 |  |  |  | 6.5d | 0d | Labour [83.5 h]; Supervisor [83.5 h] | 84 |  | MEP&LV |  |  |  |  |  |  |  |
| CBMPG-1210 |  | COLD & HOT WATER SUPPLY SYSTEM (POTABLE PIPING) | 12d | 2014-09-09 | 2014-09-21 | CBMPG-1200 |  |  |  | 23.75d | 17.25d | Labour [79.5 h]; Supervisor [79.5 h] | 80 |  | MEP&LV |  |  |  |  |  |  |  |
| CBMPG-1220 |  | HVAQ EQUIPMENTS/FIXTURES INSTALLATIONS | 12d | 2014-09-26 | 2014-10-08 | CBAPG-1260 FS+2.5d, CBMPG-1190 FS+20d |  |  |  | 9.5d | 0d | Labour [111.5 h]; Supervisor [111.5 h] | 112 |  | MEP&LV |  |  |  |  |  |  |  |
| CBMPG-1230 |  | PLUMBING FIXTURES A& ACCESSORIES | 10d | 2014-11-24 | 2014-12-04 | CBAPG-1290, CBMPG-1180 FS+70d |  |  |  | 6.5d | 0d | Labour [75.5 h]; Supervisor [75.5 h] | 76 |  | MEP&LV |  |  |  |  |  |  |  |
| CBMPG-1240 |  | INSTALLATIONS OF EQUIPMENTS /FIXTURES OF FIRE FIGHTING SYSTEM | 16d | 2014-11-27 | 2014-12-13 | CBAPG-1300 FS+10d |  |  |  | 9.5d | 3d | Labour [56 h]; Supervisor [56 h] | 56 |  | MEP&LV |  |  |  |  |  |  |  |
| CBMPG-1250 |  | TESTING & COMMISSIONING | 14d | 2014-12-23 | 2015-01-05 | CBMPG-1230 FS+18.75d, CBMPG-1240 FS+6.25d, CBMPG-1210 FS+75d, CBEPG-1160 FS+90d |  |  |  | 6.5d | 0d | Engineer [167 h] | 167 |  | MEP&LV |  |  |  |  |  |  |  |
|  | 4 | **ARCHITECTURAL WORKS** |  | 2014-08-16 | 2015-01-15 |  |  |  |  |  |  |  |  |  |  |  |  |  |  |  |  |  |
| CBAPG-1260 |  | PLASTERING WORKS | 28d | 2014-08-16 | 2014-09-13 | CBCPG-1100 FS+6.25d |  |  |  | 11.5d | 0d | Labour [60 h]; Supervisor [60 h] | 60 |  |  | BFW |  |  |  |  |  |  |
| CBAPG-1270 |  | DOORS & WINDOWS ISNTALLATIONS | 18d | 2014-09-17 | 2014-10-05 | CBAPG-1260 FS+3.75d, CBCPG-1110 FS+8.75d |  |  |  | 11.5d | 0d | Labour [92 h]; Supervisor [92 h] | 92 |  |  |  | BDW |  |  |  |  |  |
| CBAPG-1280 |  | MARBLE/CERAMIC TILE WORKS | 20d | 2014-09-26 | 2014-10-15 | CBAPG-1260 FS+12.5d |  |  |  | 22.25d | 12.75d | Labour [138 h]; Supervisor [138 h] | 138 |  |  | BFW |  |  |  |  |  |  |
| CBAPG-1300 |  | ROOF CEILING WORKS | 20d | 2014-10-28 | 2014-11-17 | CBMPG-1200, CBAPG-1280, CBMPG-1220 FS+20d |  |  |  | 9.5d | 0d | Labour [119.5 h]; Supervisor [119.5 h] | 120 |  |  | BFW |  |  |  |  |  |  |
| CBAPG-1290 |  | PAINTING WORKS | 20d | 2014-10-30 | 2014-11-19 | CBAPG-1270 FS+25d |  |  |  | 11.5d | 5d | Labour [138 h]; Supervisor [138 h] | 138 |  |  | BFW |  |  |  |  |  |  |
| CBAPG-1310 |  | TESTING & COMMISSIONING | 10d | 2015-01-06 | 2015-01-15 | CBAPG-1290, CBMPG-1250 |  |  |  | 6.5d | 6.25d | Engineer [127 h] | 127 |  |  | BFW |  |  |  |  |  |  |
|  | 3 | **TURNSTILE BUILDING (GATE # 2 & 3)** |  | 2013-11-15 | 2015-04-16 |  |  |  |  |  |  |  |  |  |  |  |  |  |  |  |  |  |
|  | 1 | **CIVIL WORKS** |  | 2013-11-15 | 2014-11-29 |  |  |  |  |  |  |  |  |  |  |  |  |  |  |  |  |  |
| CBCTS-1000 |  | LEVELING | 2.5d | 2013-11-15 A | 2013-11-16 A | CBCPG-1000 SS | 100% | 2013-11-15 | 2013-11-17 |  |  | Labour [88 h]; Grader [88 h] | 176 | 176 |  |  |  | DFCR |  |  |  |  |
| CBCTS-1010 |  | MATERIAL REPLACE AS SELECT FILL AND COMPACTION | 10d | 2014-07-22 | 2014-08-01 | CBCTS-1000 FS+6.25d, CBCPG-1010 FS+12.5d, CBCPG-1110 FS-35d |  |  |  | 0.25d | 0d | Labour [259 h]; Lumpsum [50] | 259 |  |  |  |  | DFCR |  |  |  |  |
| CBCTS-1020 |  | TERMITE CONTROL | 10d | 2014-08-02 | 2014-08-12 | CBCTS-1010 FS+1.25d |  |  |  | 5d | 0d | Labour [135 h] | 135 |  |  |  |  |  | BTI |  |  |  |
| CBCTS-1030 |  | BLIND/LEAN CONCRETE | 15d | 2014-08-16 | 2014-08-31 | CBCTS-1020 FS+3.75d |  |  |  | 5d | 0d | Labour [41.75 h]; Concrete Pump [41.75 h]; Supervisor [41.75 h]; Surveyor [41.75 h] | 126 |  |  |  |  |  |  | BCW |  |  |
| CBCTS-1040 |  | WATER PROOFING | 8d | 2014-09-06 | 2014-09-14 | CBCTS-1030 FS+6.25d |  |  |  | 5d | 0d | Labour [143 h]; Lumpsum [30] | 143 |  |  |  |  |  | BTI |  |  |  |
| CBCTS-1050 |  | R.C FOUNDATION | 16d | 2014-09-17 | 2014-10-03 | CBCTS-1040 FS+2.5d |  |  |  | 5d | 0d | Labour [140.8 h]; CARPANTER [140.8 h]; Steel Fixer [140.8 h]; Supervisor [140.8 h]; Concrete Pump [140.8 h] | 564 |  |  |  |  |  |  | BCW |  |  |
| CBCTS-1060 |  | DUCT BANK OPENING | 8d | 2014-09-18 | 2014-09-26 | CBCTS-1050 SS+1.25d |  |  |  | 21.5d | 0d | Labour [193.5 h]; Supervisor [193.5 h] | 194 |  |  |  |  |  |  |  | BWP |  |
| CBCTS-1080 |  | BEAMS & COLUMNS | 15d | 2014-09-24 | 2014-10-09 | CBCTS-1050 SS+7.5d |  |  |  | 5d | 0d | Labour [104.5 h]; CARPANTER [104.5 h]; Steel Fixer [104.5 h]; Engineer [104.5 h]; Supervisor [104.5 h]; Concrete Pump [104.5 h] | 525 |  |  |  |  |  |  | BCW |  |  |
| CBCTS-1070 |  | UTILITY INSTALLATION | 10d | 2014-09-26 | 2014-10-06 | CBCTS-1050 SS, CBCTS-1060 |  |  |  | 21.5d | 0d | Labour [96.5 h]; Supervisor [96.5 h] | 97 |  |  |  |  |  |  |  | BWP |  |
| CBCTS-1090 |  | ROOF SLAB | 20d | 2014-10-09 | 2014-10-29 | CBCTS-1080 |  |  |  | 5d | 0d | Labour [72.5 h]; CARPANTER [72.5 h]; Engineer [72.5 h]; Steel Fixer [72.5 h]; Supervisor [72.5 h]; Concrete Pump [72.5 h] | 365 |  |  |  |  |  |  | BCW |  |  |
| CBCTS-1100 |  | MASONRY BLOCK WORKS | 15d | 2014-10-29 | 2014-11-13 | CBCTS-1090 |  |  |  | 5d | 0d | Labour [551 h] | 551 |  |  |  |  |  |  |  |  | BMW |
| CBCTS-1110 |  | OPENING WORKS (DOORS & WINDOWS) | 10d | 2014-11-20 | 2014-11-29 | CBCTS-1100 FS+6.25d |  |  |  | 6d | 1d | Labour [83.5 h]; Supervisor [83.5 h] | 84 |  |  |  | BDW |  |  |  |  |  |

| ID | WBS | Activity | Duration | Start | Finish | Predecessors | Total float | Free float | Resources | Cost | Devision-15 | Devision-09 | Devision-08 | Devision-05 |
| --- | --- | --- | --- | --- | --- | --- | --- | --- | --- | --- | --- | --- | --- | --- |
|  | 2 | **ELECTRICAL & TELECOMMUNICATION SYSTEMS** |  | 2014-10-06 | 2014-12-31 |  |  |  |  |  |  |  |  |  |
| CBETS-1120 |  | DUCT BANK (OUTSIDE PLANT) | 20d | 2014-10-06 | 2014-10-26 | CBCTS-1070 | 21.5d | 0d | Labour [107 h]; Supervisor [107 h] | 107 | MEP&LV |  |  |  |
| CBETS-1130 |  | LOADER/TRAY FOR STRUCTURAL CABLING | 18d | 2014-10-26 | 2014-11-13 | CBETS-1120 | 21.5d | 0d | Labour [121.5 h]; Supervisor [121.5 h] | 122 | MEP&LV |  |  |  |
| CBETS-1140 |  | CABLING / WIRING | 16d | 2014-11-13 | 2014-11-29 | CBETS-1130 | 21.5d | 0d | Labour [129.5 h]; Supervisor [129.5 h] | 130 | MEP&LV |  |  |  |
| CBETS-1150 |  | EQUIPMENT/FIXTURES INSTALLATION ACCORDING TO STANDARD | 16d | 2014-12-02 | 2014-12-17 | CBETS-1140 FS+2.5d | 21.5d | 0d | Labour [109.5 h]; Supervisor [109.5 h] | 110 | MEP&LV |  |  |  |
| CBETS-1160 |  | TESTING AND COMMISSIONING | 14d | 2014-12-18 | 2014-12-31 | CBETS-1150 | 21.5d | 16.5d | Engineer [107 h] | 107 | MEP&LV |  |  |  |
|  | 3 | **MECHANICAL WORKS** |  | 2014-11-16 | 2015-04-01 |  |  |  |  |  |  |  |  |  |
| CBMTS-1190 |  | HVAQ PIPING & ACCESSORIES WORKS | 28d | 2014-11-16 | 2014-12-14 | CBCTS-1090 FS+17.5d | 29d | 0d | Labour [125.5 h]; Supervisor [125.5 h] | 126 | MEP&LV |  |  |  |
| CBMTS-1170 |  | DRAINAGE SYSTEM (PIPING) | 28d | 2014-11-23 | 2014-12-21 | CBCTS-1100 SS+25d | 25d | 0d | Labour [111.5 h]; Supervisor [111.5 h] | 112 | MEP&LV |  |  |  |
| CBMTS-1200 |  | FIRE FIGHTING PIPING/PLUMBING WORKS | 15d | 2014-11-26 | 2014-12-11 | CBCTS-1100 FS+12.5d | 18.25d | 0d | Labour [74.5 h]; Supervisor [74.5 h] | 75 | MEP&LV |  |  |  |
| CBMTS-1210 |  | COLD & HOT WATER SUPPLY SYSTEM (POTABLE PIPING) | 14d | 2014-12-11 | 2014-12-25 | CBMTS-1200 | 18.25d | 13.25d | Labour [129.5 h]; Supervisor [129.5 h] | 130 | MEP&LV |  |  |  |
| CBMTS-1220 |  | HVAQ EQUIPMENTS/FIXTURES INSTALLATIONS | 20d | 2014-12-14 | 2015-01-03 | CBATS-1260 FS+2.5d, CBMTS-1190 | 29d | 9.25d | Labour [111.5 h]; Supervisor [111.5 h] | 112 | MEP&LV |  |  |  |
| CBMTS-1180 |  | POTABLE WATER SYSTEM (PIPING) | 28d | 2014-12-21 | 2015-01-18 | CBMTS-1170 | 25d | 20d | Labour [133.5 h]; Supervisor [133.5 h] | 134 | MEP&LV |  |  |  |
| CBMTS-1230 |  | PLUMBING FIXTURES A& ACCESSORIES | 20d | 2015-02-07 | 2015-02-27 | CBATS-1290, CBMTS-1180 | 5d | 0d | Labour [125.5 h]; Supervisor [125.5 h] | 126 | MEP&LV |  |  |  |
| CBMTS-1240 |  | INSTALLATIONS OF EQUIPMENTS /FIXTURES OF FIRE FIGHTING SYSTEM | 14d | 2015-02-11 | 2015-02-25 | CBATS-1300 FS+10d | 19.75d | 14.75d | Labour [56 h]; Supervisor [56 h] | 56 | MEP&LV |  |  |  |
| CBMTS-1250 |  | TESTING & COMMISSIONING | 14d | 2015-03-18 | 2015-04-01 | CBMTS-1230 FS+18.75d, CBMTS-1240 FS+6.25d, CBMTS-1210 FS+70d, CBETS-1160 FS+60d | 5d | 0d | Engineer [167 h] | 167 | MEP&LV |  |  |  |
|  | 4 | **ARCHITECTURAL WORKS** |  | 2014-11-20 | 2015-04-16 |  |  |  |  |  |  |  |  |  |
| CBATS-1260 |  | PLASTERING WORKS | 16d | 2014-11-20 | 2014-12-05 | CBCTS-1100 FS+6.25d | 5d | 0d | Labour [110 h]; Supervisor [110 h] | 110 |  | BFW |  |  |
| CBATS-1270 |  | DOORS & WINDOWS ISNTALLATIONS | 16d | 2014-12-09 | 2014-12-25 | CBATS-1260 FS+3.75d, CBCTS-1110 FS+8.75d | 5d | 0d | Labour [58 h]; Supervisor [58 h] | 58 |  |  | BDW |  |
| CBATS-1280 |  | MARBLE/CERAMIC TILE WORKS | 25d | 2014-12-18 | 2015-01-12 | CBATS-1260 FS+12.5d | 19.75d | 0d | Labour [88 h]; Supervisor [88 h] | 88 |  | BFW |  |  |
| CBATS-1300 |  | ROOF CEILING WORKS | 20d | 2015-01-12 | 2015-02-01 | CBMTS-1200, CBATS-1280, CBMTS-1220 | 19.75d | 0d | Labour [119.5 h]; Supervisor [119.5 h] | 120 |  | BFW |  |  |
| CBATS-1290 |  | PAINTING WORKS | 19d | 2015-01-19 | 2015-02-07 | CBATS-1270 FS+25d | 5d | 0d | Labour [113 h]; Supervisor [113 h] | 113 |  | BFW |  |  |
| CBATS-1310 |  | TESTING & COMMISSIONING | 15d | 2015-04-01 | 2015-04-16 | CBATS-1290, CBMTS-1250 | 5d | 0d | Engineer [127 h] | 127 |  | BFW |  |  |
|  | 4 | **SUN SHADES & BUS SHELTERS (GATE # 2 & 3)** |  | 2015-01-16 | 2015-07-04 |  |  |  |  |  |  |  |  |  |
|  | 1 | **BUS SHELTERS** |  | 2015-01-16 | 2015-07-04 |  |  |  |  |  |  |  |  |  |
| BBS1000 |  | BUS SHELTER OUTSIDE GATE # 2 | 31.25d | 2015-01-16 | 2015-02-16 | CBATS-1310 FS-90d | 5d | 0d | Labour [775 h] | 775 |  |  |  | BMTW |
| BBS1010 |  | BUS SHELTER INSIDE GATE # 2 | 31.25d | 2015-02-16 | 2015-03-19 | BBS1000 | 5d | 0d | Labour [775 h] | 775 |  |  |  | BMTW |
| BBS1030 |  | PROPOSED ASPHALT ROAD AROUND BUILDINGS AREA (GATE # 2) | 31.25d | 2015-03-01 | 2015-04-01 | BBS1020 SF+13d | 5d | 0d | Labour [775 h] | 775 |  |  |  | BMTW |
| BBS1020 |  | BUS SHELTER OUTSIDE GATE # 3 | 31.25d | 2015-03-20 | 2015-04-20 | BBS1010 | 5d | 0d | Labour [775 h] | 775 |  |  |  | BMTW |
| BBS1040 |  | PROPOSED ASPHALT ROAD AROUND BUILDINGS AREA (GATE # 3) | 31.25d | 2015-06-03 | 2015-07-04 | BBS1030, BSS-1010 | 17.25d | 17d | Labour [775 h] | 775 |  |  |  | BMTW |

| ID | WBS | Activity | Duration | Start | Finish | Predecessors | Complete | Planned start | Planned finish | Total float | Free float | Resources | Cost | Actual cost | Devision-05 | Devision-02 | Devision-07 | Devision-03 | Devision-06 | Devision-04 | Devision-08 | Devision-15 |
| --- | --- | --- | --- | --- | --- | --- | --- | --- | --- | --- | --- | --- | --- | --- | --- | --- | --- | --- | --- | --- | --- | --- |
|  | 2 | **SUN SHADES** |  | 2015-04-20 | 2015-06-02 |  |  |  |  |  |  |  |  |  |  |  |  |  |  |  |  |  |
| BSS-1000 |  | SUN SHADES AT GATE # 2 | 43.75d | 2015-04-20 | 2015-06-02 | BBS1020 |  |  |  | 17.25d | 0d | Grader [1224.8 h]; Labour [306.2 h] | 1,531 |  | BMTW |  |  |  |  |  |  |  |
| BSS-1010 |  | SUN SHADES AT GATE # 3 | 43.75d | 2015-04-20 | 2015-06-02 | BBS1030, BSS-1000 SS |  |  |  | 17.25d | 0d | Grader [204 h]; Labour [306 h] | 510 |  | BMTW |  |  |  |  |  |  |  |
|  | 1 | **JOIN FORCE CONTROL BUILDING (GATE # 3)** |  | 2013-11-15 | 2015-02-17 |  |  |  |  |  |  |  |  |  |  |  |  |  |  |  |  |  |
|  | 1 | **CIVIL WORKS** |  | 2013-11-15 | 2014-12-08 |  |  |  |  |  |  |  |  |  |  |  |  |  |  |  |  |  |
| CBCJFC-1000 |  | LEVELING | 2.5d | 2013-11-15 A | 2013-11-16 A | CBCTS-1000 SS | 100% | 2013-11-15 | 2013-11-17 |  |  | Labour [88 h]; Grader [88 h] | 176 | 176 |  | DFCR |  |  |  |  |  |  |
| CBCJFC-1010 |  | MATERIAL REPLACE AS SELECT FILL AND COMPACTION | 15d | 2014-08-01 | 2014-08-16 | CBCJFC-1000 FS+6.25d, CBCTS-1010 |  |  |  | 0.25d | 0d | Labour [259 h]; Lumpsum [50] | 259 |  |  | DFCR |  |  |  |  |  |  |
| CBCJFC-1020 |  | TERMITE CONTROL | 10d | 2014-08-17 | 2014-08-27 | CBCJFC-1010 FS+1.25d |  |  |  | 24d | 0d | Labour [135 h] | 135 |  |  |  | BTI |  |  |  |  |  |
| CBCJFC-1030 |  | BLIND/LEAN CONCRETE | 10d | 2014-08-31 | 2014-09-10 | CBCJFC-1020 FS+3.75d |  |  |  | 24d | 0d | Labour [91.75 h]; Concrete Pump [91.75 h]; Supervisor [91.75 h]; Surveyor [91.75 h] | 276 |  |  |  |  | BCW |  |  |  |  |
| CBCJFC-1040 |  | WATER PROOFING | 7d | 2014-09-16 | 2014-09-23 | CBCJFC-1030 FS+6.25d |  |  |  | 24d | 0d | Labour [243 h]; Lumpsum [30] | 243 |  |  |  | BTI |  |  |  |  |  |
| CBCJFC-1050 |  | R.C FOUNDATION | 25d | 2014-09-23 | 2014-10-17 | CBCJFC-1040 SS+6.25d |  |  |  | 24d | 0d | Labour [80.8 h]; CARPANTER [80.8 h]; Steel Fixer [80.8 h]; Supervisor [80.8 h]; Concrete Pump [80.8 h] | 324 |  |  |  |  | BCW |  |  |  |  |
| CBCJFC-1060 |  | DUCT BANK OPENING | 3.75d | 2014-09-24 | 2014-09-27 | CBCJFC-1050 SS+1.25d |  |  |  | 24d | 0d | Labour [93.5 h]; Supervisor [93.5 h] | 94 |  |  |  |  |  | BWP |  |  |  |
| CBCJFC-1070 |  | UTILITY INSTALLATION | 10d | 2014-09-28 | 2014-10-07 | CBCJFC-1050 SS, CBCJFC-1060 |  |  |  | 24d | 0d | Labour [46.5 h]; Supervisor [46.5 h] | 47 |  |  |  |  |  | BWP |  |  |  |
| CBCJFC-1080 |  | BEAMS & COLUMNS | 29d | 2014-09-30 | 2014-10-29 | CBCJFC-1050 SS+7.5d |  |  |  | 25.75d | 0d | Labour [71.17 h]; CARPANTER [71.17 h]; Steel Fixer [71.17 h]; Engineer [71.17 h]; Supervisor [71.17 h]; Concrete Pump [71.17 h] | 355 |  |  |  |  | BCW |  |  |  |  |
| CBCJFC-1090 |  | ROOF SLAB | 31d | 2014-10-05 | 2014-11-05 | CBCJFC-1080 SS+5d |  |  |  | 25.75d | 0d | Labour [55.83 h]; CARPANTER [55.83 h]; Engineer [55.83 h]; Steel Fixer [55.83 h]; Supervisor [55.83 h]; Concrete Pump [55.83 h] | 280 |  |  |  |  | BCW |  |  |  |  |
| CBCJFC-1100 |  | MASONRY BLOCK WORKS | 39d | 2014-10-30 | 2014-12-08 | CBCJFC-1090 SS+25d |  |  |  | 25.75d | 0d | Labour [511 h] | 511 |  |  |  |  |  |  | BMW |  |  |
| CBCJFC-1110 |  | OPENING WORKS (DOORS & WINDOWS) | 7d | 2014-11-25 | 2014-12-02 | CBCJFC-1100 SS+26.25d |  |  |  | 34.25d | 8d | Labour [183.5 h]; Supervisor [183.5 h] | 184 |  |  |  |  |  |  |  | BDW |  |
|  | 2 | **ELECTRICAL & TELECOMMUNICATION SYSTEMS** |  | 2014-10-08 | 2014-12-14 |  |  |  |  |  |  |  |  |  |  |  |  |  |  |  |  |  |
| CBEJFC-1120 |  | DUCT BANK (OUTSIDE PLANT) | 15d | 2014-10-08 | 2014-10-22 | CBCJFC-1070 |  |  |  | 24d | 0d | Labour [107 h]; Supervisor [107 h] | 107 |  |  |  |  |  |  |  |  | MEP&LV |
| CBEJFC-1130 |  | LOADER/TRAY FOR STRUCTURAL CABLING | 18d | 2014-10-23 | 2014-11-09 | CBEJFC-1120 |  |  |  | 24d | 0d | Labour [121.5 h]; Supervisor [121.5 h] | 122 |  |  |  |  |  |  |  |  | MEP&LV |
| CBEJFC-1140 |  | CABLING / WIRING | 16d | 2014-11-10 | 2014-11-25 | CBEJFC-1130 |  |  |  | 24d | 0d | Labour [129.5 h]; Supervisor [129.5 h] | 130 |  |  |  |  |  |  |  |  | MEP&LV |
| CBEJFC-1150 |  | EQUIPMENT/FIXTURES INSTALLATION ACCORDING TO STANDARD | 16d | 2014-11-28 | 2014-12-14 | CBEJFC-1140 FS+2.5d |  |  |  | 24d | 0d | Labour [109.5 h]; Supervisor [109.5 h] | 110 |  |  |  |  |  |  |  |  | MEP&LV |
| CBEJFC-1160 |  | TESTING AND COMMISSIONING | 5d | 2014-12-09 | 2014-12-14 | CBEJFC-1150 FF |  |  |  | 24d | 0d | Engineer [107 h] | 107 |  |  |  |  |  |  |  |  | MEP&LV |
|  | 3 | **MECHANICAL WORKS** |  | 2014-10-31 | 2015-02-17 |  |  |  |  |  |  |  |  |  |  |  |  |  |  |  |  |  |
| CBMJFC-1190 |  | HVAQ PIPING & ACCESSORIES WORKS | 21d | 2014-10-31 | 2014-11-21 | CBCJFC-1090 SS+26.25d |  |  |  | 35.5d | 9.75d | Labour [125.5 h]; Supervisor [125.5 h] | 126 |  |  |  |  |  |  |  |  | MEP&LV |
| CBMJFC-1170 |  | DRAINAGE SYSTEM (PIPING) | 25d | 2014-11-04 | 2014-11-29 | CBCJFC-1100 SS+5d |  |  |  | 29d | 0d | Labour [111.5 h]; Supervisor [111.5 h] | 112 |  |  |  |  |  |  |  |  | MEP&LV |
| CBMJFC-1200 |  | FIRE FIGHTING PIPING/PLUMBING WORKS | 18d | 2014-11-18 | 2014-12-06 | CBCJFC-1100 SS+18.75d |  |  |  | 26d | 0d | Labour [74.5 h]; Supervisor [74.5 h] | 75 |  |  |  |  |  |  |  |  | MEP&LV |
| CBMJFC-1180 |  | POTABLE WATER SYSTEM (PIPING) | 21d | 2014-11-29 | 2014-12-20 | CBMJFC-1170 |  |  |  | 29d | 2.75d | Labour [133.5 h]; Supervisor [133.5 h] | 134 |  |  |  |  |  |  |  |  | MEP&LV |
| CBMJFC-1210 |  | COLD & HOT WATER SUPPLY SYSTEM (POTABLE PIPING) | 10d | 2014-12-06 | 2014-12-16 | CBMJFC-1200 |  |  |  | 26d | 0.25d | Labour [129.5 h]; Supervisor [129.5 h] | 130 |  |  |  |  |  |  |  |  | MEP&LV |
| CBMJFC-1220 |  | HVAQ EQUIPMENTS/FIXTURES INSTALLATIONS | 15d | 2014-12-16 | 2014-12-31 | CBAJFC-1260 SS+15d, CBMJFC-1190 FS+15d, CBMJFC-1210 |  |  |  | 25.75d | 0d | Labour [111.5 h]; Supervisor [111.5 h] | 112 |  |  |  |  |  |  |  |  | MEP&LV |
| CBMJFC-1230 |  | PLUMBING FIXTURES A& ACCESSORIES | 24d | 2015-01-07 | 2015-01-31 | CBAJFC-1290 SS+8.75d, CBMJFC-1180 FS+15d, CBMJFC-1220 FF |  |  |  | 26.25d | 2.25d | Labour [125.5 h]; Supervisor [125.5 h] | 126 |  |  |  |  |  |  |  |  | MEP&LV |
| CBMJFC-1240 |  | INSTALLATIONS OF EQUIPMENTS /FIXTURES OF FIRE FIGHTING SYSTEM | 18d | 2015-01-11 | 2015-01-29 | CBAJFC-1300 SS |  |  |  | 27d | 3d | Labour [56 h]; Supervisor [56 h] | 56 |  |  |  |  |  |  |  |  | MEP&LV |
| CBMJFC-1250 |  | TESTING & COMMISSIONING | 15d | 2015-02-02 | 2015-02-17 | CBMJFC-1230, CBMJFC-1240 SS+18.75d, CBEJFC-1160 FS+50d |  |  |  | 24d | 23.75d | Engineer [167 h] | 167 |  |  |  |  |  |  |  |  | MEP&LV |

| ID | WBS | Activity | Duration | Start | Finish | Predecessors | Complete | Total float | Free float | Resources | Cost | Devision-09 | Devision-08 | Devision-02 | Devision-07 | Devision-03 | Devision-06 | Devision-04 | Devision-15 |
| --- | --- | --- | --- | --- | --- | --- | --- | --- | --- | --- | --- | --- | --- | --- | --- | --- | --- | --- | --- |
|  | 4 | **ARCHITECTURAL WORKS** |  | 2014-12-01 | 2015-02-15 |  |  |  |  |  |  |  |  |  |  |  |  |  |  |
| CBAJFC-1260 |  | PLASTERING WORKS | 18d | 2014-12-01 | 2014-12-19 | CBCJFC-1100 FS-7d |  | 25.75d | 0d | Labour [110 h]; Supervisor [110 h] | 110 | BFW |  |  |  |  |  |  |  |
| CBAJFC-1270 |  | DOORS & WINDOWS ISNTALLATIONS | 21d | 2014-12-19 | 2015-01-09 | CBAJFC-1260, CBCJFC-1110 FS+8.75d |  | 26.25d | 0d | Labour [92 h]; Supervisor [92 h] | 92 |  | BDW |  |  |  |  |  |  |
| CBAJFC-1280 |  | MARBLE/CERAMIC TILE WORKS | 16d | 2014-12-19 | 2015-01-04 | CBAJFC-1260 |  | 30.25d | 4.5d | Labour [138 h]; Supervisor [138 h] | 138 | BFW |  |  |  |  |  |  |  |
| CBAJFC-1290 |  | PAINTING WORKS | 20d | 2014-12-29 | 2015-01-18 | CBAJFC-1270 SS+10d |  | 26.25d | 0d | Labour [138 h]; Supervisor [138 h] | 138 | BFW |  |  |  |  |  |  |  |
| CBAJFC-1300 |  | ROOF CEILING WORKS | 20d | 2015-01-11 | 2015-01-31 | CBMJFC-1200 SS+18.75d, CBAJFC-1280 SS+18.75d, CBMJFC-1220 SS+26.25d |  | 25.75d | 0d | Labour [119.5 h]; Supervisor [119.5 h] | 120 | BFW |  |  |  |  |  |  |  |
| CBAJFC-1310 |  | TESTING & COMMISSIONING | 15d | 2015-01-31 | 2015-02-15 | CBAJFC-1290, CBAJFC-1300 |  | 25.75d | 25.5d | Engineer [127 h] | 127 | BFW |  |  |  |  |  |  |  |
|  | 2 | **QUICK RESPONSE TEAM BUILDING (GATE # 3)** |  | 2013-11-15 | 2015-05-01 |  |  |  |  |  |  |  |  |  |  |  |  |  |  |
|  | 1 | **CIVIL WORKS** |  | 2013-11-15 | 2015-01-09 |  |  |  |  |  |  |  |  |  |  |  |  |  |  |
| CBCQRT-1000 |  | LEVELING | 2.5d | 2013-11-15 A | 2013-11-16 A | CBCJFC-1000 SS | 100% |  |  | Labour [138 h]; Grader [138 h] | 276 |  |  | DFCR |  |  |  |  |  |
| CBCQRT-1010 |  | MATERIAL REPLACE AS SELECT FILL AND COMPACTION | 15d | 2014-08-29 | 2014-09-12 | CBCQRT-1000 FS+6.25d, CBCJFC-1010 FS+12.5d |  | 0.25d | 0d | Labour [459 h]; Lumpsum [50] | 459 |  |  | DFCR |  |  |  |  |  |
| CBCQRT-1020 |  | TERMITE CONTROL | 10d | 2014-09-14 | 2014-09-24 | CBCQRT-1010 FS+1.25d |  | 11.25d | 0d | Labour [135 h] | 135 |  |  |  | BTI |  |  |  |  |
| CBCQRT-1030 |  | BLIND/LEAN CONCRETE | 10d | 2014-09-28 | 2014-10-07 | CBCQRT-1020 FS+3.75d |  | 11.25d | 0d | Labour [91.75 h]; Concrete Pump [91.75 h]; Supervisor [91.75 h]; Surveyor [91.75 h] | 276 |  |  |  |  | BCW |  |  |  |
| CBCQRT-1040 |  | WATER PROOFING | 7d | 2014-10-14 | 2014-10-21 | CBCQRT-1030 FS+6.25d |  | 11.25d | 0d | Labour [143 h]; Lumpsum [30] | 143 |  |  |  | BTI |  |  |  |  |
| CBCQRT-1050 |  | R.C FOUNDATION | 18d | 2014-10-23 | 2014-11-10 | CBCQRT-1040 FS+2.5d |  | 11.25d | 0d | Labour [40.8 h]; CARPANTER [40.8 h]; Steel Fixer [40.8 h]; Supervisor [40.8 h]; Concrete Pump [40.8 h] | 164 |  |  |  |  | BCW |  |  |  |
| CBCQRT-1060 |  | DUCT BANK OPENING | 14d | 2014-10-25 | 2014-11-07 | CBCQRT-1050 SS+1.25d |  | 28.5d | 0d | Labour [93.5 h]; Supervisor [93.5 h] | 94 |  |  |  |  |  | BWP |  |  |
| CBCQRT-1080 |  | BEAMS & COLUMNS | 25d | 2014-10-31 | 2014-11-25 | CBCQRT-1050 SS+7.5d |  | 11.25d | 0d | Labour [71.17 h]; CARPANTER [71.17 h]; Steel Fixer [71.17 h]; Engineer [71.17 h]; Supervisor [71.17 h]; Concrete Pump [71.17 h] | 355 |  |  |  |  | BCW |  |  |  |
| CBCQRT-1070 |  | UTILITY INSTALLATION | 20d | 2014-11-08 | 2014-11-27 | CBCQRT-1050 SS, CBCQRT-1060 |  | 28.5d | 0d | Labour [46.5 h]; Supervisor [46.5 h] | 47 |  |  |  |  |  | BWP |  |  |
| CBCQRT-1090 |  | ROOF SLAB | 20d | 2014-11-25 | 2014-12-15 | CBCQRT-1080 |  | 11.25d | 0d | Labour [55.83 h]; CARPANTER [55.83 h]; Engineer [55.83 h]; Steel Fixer [55.83 h]; Supervisor [55.83 h]; Concrete Pump [55.83 h] | 280 |  |  |  |  | BCW |  |  |  |
| CBCQRT-1100 |  | MASONRY BLOCK WORKS | 14d | 2014-12-15 | 2014-12-29 | CBCQRT-1090 |  | 11.25d | 0d | Labour [351 h] | 351 |  |  |  |  |  |  | BMW |  |
| CBCQRT-1110 |  | OPENING WORKS (DOORS & WINDOWS) | 5d | 2015-01-04 | 2015-01-09 | CBCQRT-1100 FS+6.25d |  | 13.25d | 2d | Labour [83.5 h]; Supervisor [83.5 h] | 84 |  | BDW |  |  |  |  |  |  |
|  | 2 | **ELECTRICAL & TELECOMMUNICATION SYSTEMS** |  | 2014-11-28 | 2015-02-13 |  |  |  |  |  |  |  |  |  |  |  |  |  |  |
| CBEQRT-1120 |  | DUCT BANK (OUTSIDE PLANT) | 15d | 2014-11-28 | 2014-12-12 | CBCQRT-1070 |  | 28.5d | 0d | Labour [157 h]; Supervisor [157 h] | 157 |  |  |  |  |  |  |  | MEP&LV |
| CBEQRT-1130 |  | LOADER/TRAY FOR STRUCTURAL CABLING | 18d | 2014-12-13 | 2014-12-30 | CBEQRT-1120 |  | 28.5d | 0d | Labour [171.5 h]; Supervisor [171.5 h] | 172 |  |  |  |  |  |  |  | MEP&LV |
| CBEQRT-1140 |  | CABLING / WIRING | 16d | 2014-12-31 | 2015-01-15 | CBEQRT-1130 |  | 28.5d | 0d | Labour [129.5 h]; Supervisor [129.5 h] | 130 |  |  |  |  |  |  |  | MEP&LV |
| CBEQRT-1150 |  | EQUIPMENT/FIXTURES INSTALLATION ACCORDING TO STANDARD | 16d | 2015-01-18 | 2015-02-03 | CBEQRT-1140 FS+2.5d |  | 28.5d | 0d | Labour [109.5 h]; Supervisor [109.5 h] | 110 |  |  |  |  |  |  |  | MEP&LV |
| CBEQRT-1160 |  | TESTING AND COMMISSIONING | 10d | 2015-02-03 | 2015-02-13 | CBEQRT-1150 |  | 28.5d | 28.25d | Engineer [107 h] | 107 |  |  |  |  |  |  |  | MEP&LV |

| ID | WBS | Activity | Duration | Start | Finish | Predecessors | Complete | Total float | Free float | Resources | Cost | Devision-15 | Devision-09 | Devision-08 | Devision-02 | Devision-07 | Devision-03 | Devision-06 | Devision-04 |
| --- | --- | --- | --- | --- | --- | --- | --- | --- | --- | --- | --- | --- | --- | --- | --- | --- | --- | --- | --- |
|  | 3 | **MECHANICAL WORKS** |  | 2014-12-20 | 2015-04-21 |  |  |  |  |  |  |  |  |  |  |  |  |  |  |
| CBMQRT-1170 |  | DRAINAGE SYSTEM (PIPING) | 28d | 2014-12-20 | 2015-01-17 | CBCQRT-1100 SS+5d |  | 32.5d | 0d | Labour [111.5 h]; Supervisor [111.5 h] | 112 | MEP&LV |  |  |  |  |  |  |  |
| CBMQRT-1190 |  | HVAQ PIPING & ACCESSORIES WORKS | 28d | 2015-01-01 | 2015-01-29 | CBCQRT-1090 FS+17.5d |  | 22.75d | 0d | Labour [125.5 h]; Supervisor [125.5 h] | 126 | MEP&LV |  |  |  |  |  |  |  |
| CBMQRT-1180 |  | POTABLE WATER SYSTEM (PIPING) | 28d | 2015-01-17 | 2015-02-14 | CBMQRT-1170 |  | 32.5d | 21.25d | Labour [83.5 h]; Supervisor [83.5 h] | 84 | MEP&LV |  |  |  |  |  |  |  |
| CBMQRT-1200 |  | FIRE FIGHTING PIPING/PLUMBING WORKS | 10d | 2015-01-28 | 2015-02-07 | CBCQRT-1100 FS+30d |  | 20.25d | 0d | Labour [74.5 h]; Supervisor [74.5 h] | 75 | MEP&LV |  |  |  |  |  |  |  |
| CBMQRT-1220 |  | HVAQ EQUIPMENTS/FIXTURES INSTALLATIONS | 10d | 2015-01-29 | 2015-02-08 | CBAQRT-1270 FS+2.5d, CBMQRT-1190 |  | 22.75d | 5.25d | Labour [111.5 h]; Supervisor [111.5 h] | 112 | MEP&LV |  |  |  |  |  |  |  |
| CBMQRT-1210 |  | COLD & HOT WATER SUPPLY SYSTEM (POTABLE PIPING) | 28d | 2015-02-07 | 2015-03-07 | CBMQRT-1200 |  | 20.25d | 9d | Labour [129.5 h]; Supervisor [129.5 h] | 130 | MEP&LV |  |  |  |  |  |  |  |
| CBMQRT-1240 |  | INSTALLATIONS OF EQUIPMENTS /FIXTURES OF FIRE FIGHTING SYSTEM | 28d | 2015-03-08 | 2015-04-04 | CBAQRT-1310 FS+10d |  | 17.5d | 6.25d | Labour [106 h]; Supervisor [106 h] | 106 | MEP&LV |  |  |  |  |  |  |  |
| CBMQRT-1230 |  | PLUMBING FIXTURES A& ACCESSORIES | 26d | 2015-03-16 | 2015-04-11 | CBAQRT-1300, CBMQRT-1180 FS+8.75d, CBMQRT-1200, CBMQRT-1220, CBMQRT-1210 |  | 11.25d | 0d | Labour [75.5 h]; Supervisor [75.5 h] | 76 | MEP&LV |  |  |  |  |  |  |  |
| CBMQRT-1250 |  | TESTING & COMMISSIONING | 10d | 2015-04-11 | 2015-04-21 | CBMQRT-1240, CBMQRT-1230 |  | 11.25d | 0d | Engineer [167 h] | 167 | MEP&LV |  |  |  |  |  |  |  |
|  | 4 | **ARCHITECTURAL WORKS** |  | 2015-01-04 | 2015-05-01 |  |  |  |  |  |  |  |  |  |  |  |  |  |  |
| CBAQRT-1270 |  | PLASTERING WORKS | 12d | 2015-01-04 | 2015-01-16 | CBCQRT-1100 FS+6.25d |  | 11.25d | 0d | Labour [110 h]; Supervisor [110 h] | 110 |  | BFW |  |  |  |  |  |  |
| CBAQRT-1280 |  | DOORS & WINDOWS ISNTALLATIONS | 12d | 2015-01-20 | 2015-02-01 | CBAQRT-1270 FS+3.75d, CBCQRT-1110 FS+8.75d |  | 11.25d | 0d | Labour [92 h]; Supervisor [92 h] | 92 |  |  | BDW |  |  |  |  |  |
| CBAQRT-1290 |  | MARBLE/CERAMIC TILE WORKS | 16d | 2015-01-29 | 2015-02-13 | CBAQRT-1270 FS+12.5d |  | 17.5d | 0d | Labour [138 h]; Supervisor [138 h] | 138 |  | BFW |  |  |  |  |  |  |
| CBAQRT-1310 |  | ROOF CEILING WORKS | 12d | 2015-02-14 | 2015-02-25 | CBMQRT-1200, CBAQRT-1290, CBMQRT-1220 |  | 17.5d | 0d | Labour [119.5 h]; Supervisor [119.5 h] | 120 |  | BFW |  |  |  |  |  |  |
| CBAQRT-1300 |  | PAINTING WORKS | 18d | 2015-02-26 | 2015-03-16 | CBAQRT-1280 FS+25d |  | 11.25d | 0d | Labour [138 h]; Supervisor [138 h] | 138 |  | BFW |  |  |  |  |  |  |
| CBAQRT-1320 |  | TESTING & COMMISSIONING | 10d | 2015-04-21 | 2015-05-01 | CBAQRT-1300, CBMQRT-1250 |  | 11.25d | 11d | Engineer [127 h] | 127 |  | BFW |  |  |  |  |  |  |
|  | 6 | **UNINTERRUPTIBEL POWER SUPPLY (UPS) BUILDING (GATE # 3)** |  | 2013-11-15 | 2015-04-13 |  |  |  |  |  |  |  |  |  |  |  |  |  |  |
|  | 1 | **CIVIL WORKS** |  | 2013-11-15 | 2014-12-21 |  |  |  |  |  |  |  |  |  |  |  |  |  |  |
| CBCUPS-1000 |  | LEVELING | 2.5d | 2013-11-15 A | 2013-11-16 A | CBCQRT-1000 SS | 100% |  |  | Labour [138 h]; Grader [138 h] | 276 |  |  |  | DFCR |  |  |  |  |
| CBCUPS-1010 |  | MATERIAL REPLACE AS SELECT FILL AND COMPACTION | 15d | 2014-06-30 | 2014-07-14 | CBCUPS-1000 FS+6.25d, CBCQRT-1010 FS-75d |  | 0.25d | 0d | Labour [459 h]; Lumpsum [50] | 459 |  |  |  | DFCR |  |  |  |  |
| CBCUPS-1020 |  | TERMITE CONTROL | 16d | 2014-06-30 | 2014-07-15 | CBCUPS-1010 SS |  | 13.5d | 0d | Labour [135 h] | 135 |  |  |  |  | BTI |  |  |  |
| CBCUPS-1030 |  | BLIND/LEAN CONCRETE | 32d | 2014-07-12 | 2014-08-13 | CBCUPS-1020 SS+12.5d |  | 13.5d | 0d | Labour [91.75 h]; Concrete Pump [91.75 h]; Supervisor [91.75 h]; Surveyor [91.75 h] | 276 |  |  |  |  |  | BCW |  |  |
| CBCUPS-1040 |  | WATER PROOFING | 35d | 2014-07-31 | 2014-09-04 | CBCUPS-1030 SS+18.75d |  | 13.5d | 0d | Labour [643 h]; Lumpsum [30] | 643 |  |  |  |  | BTI |  |  |  |
| CBCUPS-1050 |  | R.C FOUNDATION | 57d | 2014-08-12 | 2014-10-08 | CBCUPS-1040 SS+12.5d |  | 13.5d | 0d | Labour [440.8 h]; CARPANTER [440.8 h]; Steel Fixer [440.8 h]; Supervisor [440.8 h]; Concrete Pump [440.8 h] | 1,764 |  |  |  |  |  | BCW |  |  |
| CBCUPS-1060 |  | DUCT BANK OPENING | 57d | 2014-08-14 | 2014-10-09 | CBCUPS-1050 SS+1.25d |  | 25.75d | 0d | Labour [93.5 h]; Supervisor [93.5 h] | 94 |  |  |  |  |  |  | BWP |  |
| CBCUPS-1080 |  | BEAMS & COLUMNS | 57d | 2014-08-20 | 2014-10-16 | CBCUPS-1050 SS+7.5d |  | 13.5d | 0d | Labour [137.83 h]; CARPANTER [137.83 h]; Steel Fixer [137.83 h]; Engineer [137.83 h]; Supervisor [137.83 h]; Concrete Pump [137.83 h] | 690 |  |  |  |  |  | BCW |  |  |
| CBCUPS-1090 |  | ROOF SLAB | 45d | 2014-09-08 | 2014-10-22 | CBCUPS-1080 SS+18.75d |  | 13.5d | 0d | Labour [122.5 h]; CARPANTER [122.5 h]; Engineer [122.5 h]; Steel Fixer [122.5 h]; Supervisor [122.5 h]; Concrete Pump [122.5 h] | 615 |  |  |  |  |  | BCW |  |  |
| CBCUPS-1070 |  | UTILITY INSTALLATION | 30d | 2014-09-14 | 2014-10-14 | CBCUPS-1050 SS, CBCUPS-1060 SS+31.25d |  | 25.75d | 0d | Labour [46.5 h]; Supervisor [46.5 h] | 47 |  |  |  |  |  |  | BWP |  |
| CBCUPS-1100 |  | MASONRY BLOCK WORKS | 40d | 2014-10-23 | 2014-12-01 | CBCUPS-1090 |  | 13.5d | 0d | Labour [551 h] | 551 |  |  |  |  |  |  |  | BMW |
| CBCUPS-1110 |  | OPENING WORKS (DOORS & WINDOWS) | 20d | 2014-12-02 | 2014-12-21 | CBCUPS-1100 |  | 22d | 0d | Labour [183.5 h]; Supervisor [183.5 h] | 184 |  |  | BDW |  |  |  |  |  |

| ID | WBS | Activity | Duration | Start | Finish | Predecessors | Total float | Free float | Resources | Cost | Devision-15 | Devision-09 | Devision-08 |
| --- | --- | --- | --- | --- | --- | --- | --- | --- | --- | --- | --- | --- | --- |
|  | 2 | **ELECTRICAL & TELECOMMUNICATION SYSTEMS** |  | 2014-09-26 | 2015-01-05 |  |  |  |  |  |  |  |  |
| CBEUPS-1120 |  | DUCT BANK (OUTSIDE PLANT) | 30d | 2014-09-26 | 2014-10-26 | CBCUPS-1070 SS+12.5d | 25.75d | 0d | Labour [257 h]; Supervisor [257 h] | 257 | MEP&LV |  |  |
| CBEUPS-1130 |  | LOADER/TRAY FOR STRUCTURAL CABLING | 30d | 2014-10-09 | 2014-11-08 | CBEUPS-1120 SS+12.5d | 25.75d | 0d | Labour [321.5 h]; Supervisor [321.5 h] | 322 | MEP&LV |  |  |
| CBEUPS-1140 |  | CABLING / WIRING | 25d | 2014-10-28 | 2014-11-21 | CBEUPS-1130 SS+18.75d | 25.75d | 0d | Labour [229.5 h]; Supervisor [229.5 h] | 230 | MEP&LV |  |  |
| CBEUPS-1150 |  | EQUIPMENT/FIXTURES INSTALLATION ACCORDING TO STANDARD | 25d | 2014-11-23 | 2014-12-18 | CBEUPS-1140 SS+26.25d | 25.75d | 3.75d | Labour [459.5 h]; Supervisor [459.5 h] | 460 | MEP&LV |  |  |
| CBEUPS-1160 |  | TESTING AND COMMISSIONING | 15d | 2014-12-22 | 2015-01-05 | CBEUPS-1150, CBCUPS-1110 | 22d | 0d | Engineer [507 h] | 507 | MEP&LV |  |  |
|  | 3 | **MECHANICAL WORKS** |  | 2014-12-02 | 2015-04-13 |  |  |  |  |  |  |  |  |
| CBMUPS-1170 |  | DRAINAGE SYSTEM (PIPING) | 45d | 2014-12-02 | 2015-01-15 | CBCUPS-1100 | 21.5d | 0d | Labour [211.5 h]; Supervisor [211.5 h] | 212 | MEP&LV |  |  |
| CBMUPS-1200 |  | FIRE FIGHTING PIPING/PLUMBING WORKS | 30d | 2014-12-02 | 2014-12-31 | CBCUPS-1100 | 45.25d | 0d | Labour [174.5 h]; Supervisor [174.5 h] | 175 | MEP&LV |  |  |
| CBMUPS-1210 |  | COLD & HOT WATER SUPPLY SYSTEM (POTABLE PIPING) | 35d | 2015-01-01 | 2015-02-04 | CBMUPS-1200 | 46.5d | 25d | Labour [229.5 h]; Supervisor [229.5 h] | 230 | MEP&LV |  |  |
| CBMUPS-1190 |  | HVAQ PIPING & ACCESSORIES WORKS | 30d | 2015-01-11 | 2015-02-09 | CBCUPS-1090 FS+80d | 21.5d | 0d | Labour [275.5 h]; Supervisor [275.5 h] | 276 | MEP&LV |  |  |
| CBMUPS-1180 |  | POTABLE WATER SYSTEM (PIPING) | 45d | 2015-01-16 | 2015-03-01 | CBMUPS-1170 | 21.5d | 0d | Labour [183.5 h]; Supervisor [183.5 h] | 184 | MEP&LV |  |  |
| CBMUPS-1220 |  | HVAQ EQUIPMENTS/FIXTURES INSTALLATIONS | 20d | 2015-02-10 | 2015-03-01 | CBAUPS-1270, CBMUPS-1190 | 21.5d | 0d | Labour [211.5 h]; Supervisor [211.5 h] | 212 | MEP&LV |  |  |
| CBMUPS-1230 |  | PLUMBING FIXTURES A& ACCESSORIES | 25d | 2015-03-02 | 2015-03-26 | CBAUPS-1300, CBMUPS-1180, CBMUPS-1220, CBMUPS-1210 | 21.5d | 3d | Labour [275.5 h]; Supervisor [275.5 h] | 276 | MEP&LV |  |  |
| CBMUPS-1240 |  | INSTALLATIONS OF EQUIPMENTS /FIXTURES OF FIRE FIGHTING SYSTEM | 25d | 2015-03-05 | 2015-03-29 | CBAUPS-1310 | 18.5d | 0d | Labour [156 h]; Supervisor [156 h] | 156 | MEP&LV |  |  |
| CBMUPS-1250 |  | TESTING & COMMISSIONING | 15d | 2015-03-30 | 2015-04-13 | CBMUPS-1230, CBMUPS-1240, CBAUPS-1310 | 18.5d | 18.25d | Engineer [367 h] | 367 | MEP&LV |  |  |
|  | 4 | **ARCHITECTURAL WORKS** |  | 2014-12-02 | 2015-03-19 |  |  |  |  |  |  |  |  |
| CBAUPS-1270 |  | PLASTERING WORKS | 35d | 2014-12-02 | 2015-01-05 | CBCUPS-1100 | 13.5d | 0d | Labour [110 h]; Supervisor [110 h] | 110 |  | BFW |  |
| CBAUPS-1290 |  | MARBLE/CERAMIC TILE WORKS | 45d | 2014-12-30 | 2015-02-12 | CBAUPS-1270 FS-7d | 13.5d | 0d | Labour [138 h]; Supervisor [138 h] | 138 |  | BFW |  |
| CBAUPS-1280 |  | DOORS & WINDOWS ISNTALLATIONS | 20d | 2015-01-06 | 2015-01-25 | CBAUPS-1270 | 26.5d | 0d | Labour [92 h]; Supervisor [92 h] | 92 |  |  | BDW |
| CBAUPS-1300 |  | PAINTING WORKS | 25d | 2015-01-26 | 2015-02-19 | CBAUPS-1280 | 26.5d | 10d | Labour [138 h]; Supervisor [138 h] | 138 |  | BFW |  |
| CBAUPS-1310 |  | ROOF CEILING WORKS | 35d | 2015-01-29 | 2015-03-04 | CBMUPS-1200 SS+26.25d, CBAUPS-1290 FS-15d | 13.5d | 0d | Labour [119.5 h]; Supervisor [119.5 h] | 120 |  | BFW |  |
| CBAUPS-1320 |  | TESTING & COMMISSIONING | 15d | 2015-03-05 | 2015-03-19 | CBAUPS-1300, CBCUPS-1110 FF+75d, CBAJFC-1310 FF, CBAUPS-1310 | 13.5d | 13.25d | Engineer [327 h] | 327 |  | BFW |  |
|  | 4 | **ELECTRICAL & COMMUNICATION SYSTEMS** |  | 2014-07-14 | 2015-07-19 |  |  |  |  |  |  |  |  |
|  | 1 | **PACKAGE SUBSTATION** |  | 2014-07-14 | 2015-03-19 |  |  |  |  |  |  |  |  |
| EPS1000 |  | MEDIUM VOL (MV) TAGE PANEL INSTALLATION | 117.5d | 2014-07-14 | 2014-11-08 | CBCUPS-1010 FS-1d | 0.25d | 0d | Labour [2252.5 h]; Engineer [2252.5 h]; Technician [2252.5 h] | 4,506 | MEP&LV |  |  |
| EPS1010 |  | MV TRANSFORMER INSTALLATION | 37.5d | 2014-11-09 | 2014-12-16 | EPS1000 FS+1d | 0.25d | 0d | Labour [1438.75 h]; Engineer [1438.75 h]; Supervisor [1438.75 h]; Technician [1438.75 h] | 2,878 | MEP&LV |  |  |
| EPS1020 |  | LOW VOLTAGE PANEL INSTALLATION | 92.5d | 2014-12-17 | 2015-03-19 | EPS1010 | 0.25d | 0d | Labour [1333.5 h]; Engineer [1333.5 h]; Supervisor [1333.5 h]; Technician [1333.5 h] | 2,668 | MEP&LV |  |  |

| ID | WBS | Activity | Duration | Start | Finish | Predecessors | Total float | Free float | Resources | Cost | Devision-15 |
| --- | --- | --- | --- | --- | --- | --- | --- | --- | --- | --- | --- |
|  | 2 | **MEDIUM VOLTAGE CABLES** |  | 2014-10-14 | 2015-04-22 |  |  |  |  |  |  |
|  | 1 | **ZONE-A (0+000 --- 4+000)** |  | 2014-10-16 | 2015-02-21 |  |  |  |  |  |  |
| MVZA-1000 |  | DUCT BANKS | 62.5d | 2014-10-16 | 2014-12-17 | ZAF-1010 | 19.25d | 0d | Labour [846 h]; Engineer [846 h]; Supervisor [846 h] | 1,692 | MEP&LV |
| MVZA-1010 |  | CABLE LAYING | 66d | 2014-12-17 | 2015-02-21 | MVZA-1000 | 19.25d | 0d | Labour [464.5 h]; Engineer [464.5 h]; Supervisor [464.5 h]; Technician [464.5 h] | 930 | MEP&LV |
|  | 2 | **ZONE-B (4+100 --- 7+000)** |  | 2014-10-14 | 2015-02-16 |  |  |  |  |  |  |
| MVZB-1000 |  | DUCT BANKS | 69d | 2014-10-14 | 2014-12-22 | ZBF-1170 | 3.25d | 0d | Labour [799.33 h]; Engineer [799.33 h]; Supervisor [799.33 h] | 1,598 | MEP&LV |
| MVZB-1010 |  | CABLE LAYING | 50d | 2014-12-29 | 2015-02-16 | MVZB-1000 FF+56.25d | 20.75d | 0d | Labour [443 h]; Engineer [443 h]; Supervisor [443 h]; Technician [443 h] | 886 | MEP&LV |
|  | 3 | **ZONE-C (7+100 --- 10+900)** |  | 2014-12-22 | 2015-04-09 |  |  |  |  |  |  |
| MVZC-1000 |  | DUCT BANKS | 58d | 2014-12-22 | 2015-02-18 | ZCF-1250, MVZB-1000 | 3.25d | 0d | Labour [866 h]; Engineer [866 h]; Supervisor [866 h] | 1,732 | MEP&LV |
| MVZC-1010 |  | CABLE LAYING | 50d | 2015-02-18 | 2015-04-09 | MVZC-1000 | 37.25d | 0d | Labour [472.25 h]; Supervisor [472.25 h]; Engineer [472.25 h]; Technician [472.25 h] | 944 | MEP&LV |
|  | 4 | **ZONE-D (11+000 --- 14+820)** |  | 2014-12-17 | 2015-04-22 |  |  |  |  |  |  |
| MVZD-1000 |  | DUCT BANKS | 63d | 2014-12-17 | 2015-02-18 | MVZC-1000 FF | 3.25d | 0d | Labour [799.33 h]; Engineer [799.33 h]; Supervisor [799.33 h] | 1,598 | MEP&LV |
| MVZD-1010 |  | CABLE LAYING | 63d | 2015-02-18 | 2015-04-22 | MVZD-1000 | 3.25d | 0d | Labour [450.5 h]; Engineer [450.5 h]; Supervisor [450.5 h]; Technician [450.5 h] | 902 | MEP&LV |
|  | 8 | **DIESEL GENERATOR** |  | 2015-04-22 | 2015-06-21 |  |  |  |  |  |  |
| EDG-1000 |  | INSTALLATION OF DIESEL GENERATORS | 15d | 2015-04-22 | 2015-05-07 | MVZD-1010 | 25.25d | 0d | Technician [1388 h]; Engineering [1388 h]; Labour [1388 h] | 2,776 | MEP&LV |
| EDG-1010 |  | LAYING CABLE BETWEEN GENERATOR ROOM & OUTLETS | 20d | 2015-05-07 | 2015-05-27 | EDG-1000 | 25.25d | 0d | Labour [396.67 h]; Technician [396.67 h]; Engineering [396.67 h] | 794 | MEP&LV |
| EDG-1020 |  | MAKING CONNECTIONS | 15d | 2015-05-27 | 2015-06-11 | EDG-1010 | 25.25d | 0d | Engineering [148.5 h]; Technician [148.5 h] | 149 | MEP&LV |
| EDG-1030 |  | TESTING | 10d | 2015-06-11 | 2015-06-21 | EDG-1020 | 25.25d | 3.25d | Technician [148.5 h]; Engineering [148.5 h] | 149 | MEP&LV |
|  | 9 | **LOW VOLTAGE CABLE** |  | 2014-11-14 | 2015-03-06 |  |  |  |  |  |  |
| EATS-1010 |  | CABLE LAYING | 112.5d | 2014-11-14 | 2015-03-06 | MVZB-1010 FF+6.25d, EATS-1000 FF+6.25d | 9d | 0d | Technician [476 h] |  | MEP&LV |
| EATS-1000 |  | DUCT BANK | 68d | 2014-12-22 | 2015-02-28 | MVZB-1000 | 9d | 0d | Technician [2141.5 h]; Engineering [2141.5 h] | 2,142 | MEP&LV |
|  | 7 | **SWITCH GEARS** |  | 2015-04-15 | 2015-06-14 |  |  |  |  |  |  |
| ESG-1000 |  | INSTALLATIONS OF MEDIUM VOLTAGE SWITCHGEARS | 30d | 2015-04-15 | 2015-05-15 | MCZB-1000 SS, CBAPG-1260 SS+17.5d | 26.75d | 0d | Engineering [2141 h] | 2,141 | MEP&LV |
| ESG-1010 |  | TESTING OF MEDIUM SWITCHGEARS | 30d | 2015-05-15 | 2015-06-14 | ESG-1000, CBAUPS-1270 | 26.75d | 26.5d | Engineering [119 h]; Technician [119 h] | 119 | MEP&LV |

| ID | WBS | Activity | Duration | Start | Finish | Predecessors | Total float | Free float | Resources | Cost | Devision-15 |
| --- | --- | --- | --- | --- | --- | --- | --- | --- | --- | --- | --- |
|  | 3 | **UNINTERRUPTIBLE POWER SUPPLY (UPS)** |  | 2015-02-05 | 2015-07-19 |  |  |  |  |  |  |
| UPS1000 |  | INSTALL UPS SYSTEM | 25d | 2015-02-05 | 2015-03-01 | CBEUPS-1160 FS+30d | 22d | 0d | Labour [3747.59 h]; Technician [102.21 h]; Engineering [102.21 h] | 3,850 | MEP&LV |
| UPS1010 |  | POWER CONNECT FROM UPS TO LV PANELS | 25d | 2015-03-02 | 2015-03-26 | UPS1000 | 22d | 0d | Labour [1010.5 h]; Engineer [1010.5 h]; Supervisor [1010.5 h]; Technician [1010.5 h] | 2,022 | MEP&LV |
| UPS1020 |  | UPS SUPPLY FROM LV PANELS TO PARTICULAR EQUIPMENTS | 25d | 2015-06-25 | 2015-07-19 | UPS1010 FS+90d, EDG-1030 | 22d | 21.75d | Labour [975.75 h]; Engineer [975.75 h]; Supervisor [975.75 h]; Technician [975.75 h] | 1,952 | MEP&LV |
|  | 4 | **LIGHTING & SECURITY CAMERA POLES** |  | 2015-01-30 | 2015-06-26 |  |  |  |  |  |  |
|  | 1 | **ZONE-A (0+000 --- 4+000)** |  | 2015-02-23 | 2015-06-17 |  |  |  |  |  |  |
| LPZA-1000 |  | POLES FOUNDATION | 62.5d | 2015-02-23 | 2015-04-27 | ZAMR-1010 SS+12.5d | 4.25d | 0d | Labour [928 h]; Supervisor [928 h]; Surveyor [928 h] | 1,856 | MEP&LV |
| LPZA-1010 |  | POLES INSTALLATION | 51.25d | 2015-04-27 | 2015-06-17 | LPZA-1000 | 4.25d | 4.5d | Labour [696 h]; Supervisor [696 h]; Surveyor [696 h]; Mobile Crane [696 h] | 2,088 | MEP&LV |
|  | 2 | **ZONE-B (4+100 --- 7+000)** |  | 2015-01-30 | 2015-06-19 |  |  |  |  |  |  |
| LPZB-1000 |  | POLES FOUNDATION | 75d | 2015-01-30 | 2015-04-15 | ZBMR-1010 SS | 21.75d | 0d | Labour [641.75 h]; Engineer [641.75 h]; Supervisor [641.75 h]; Surveyor [641.75 h] | 1,926 | MEP&LV |
| LPZB-1010 |  | POLES INSTALLATION | 65d | 2015-04-15 | 2015-06-19 | LPZB-1000 | 21.75d | 21.5d | Labour [643 h]; Supervisor [643 h]; Surveyor [643 h]; Mobile Crane [643 h] | 1,929 | MEP&LV |
|  | 3 | **ZONE-C (7+100 --- 10+900)** |  | 2015-04-03 | 2015-06-21 |  |  |  |  |  |  |
| LPZC-1000 |  | POLES FOUNDATION | 44d | 2015-04-03 | 2015-05-17 | ZCMR-1010 SS+32d | 24.25d | 0d | Labour [696 h]; Engineer [696 h]; Supervisor [696 h]; Surveyor [696 h] | 2,088 | MEP&LV |
| LPZC-1010 |  | POLES INSTALLATION | 54d | 2015-04-28 | 2015-06-21 | LPZC-1000 SS+25d | 36.5d | 0d | Labour [696 h]; Supervisor [696 h]; Surveyor [696 h]; Mobile Crane [696 h] | 2,088 | MEP&LV |
|  | 4 | **ZONE-D (11+000 --- 14+820)** |  | 2015-04-20 | 2015-06-26 |  |  |  |  |  |  |
| LPZD-1000 |  | POLES FOUNDATION | 29d | 2015-04-20 | 2015-05-19 | ZDMR-1010 SS+5d | 4.75d | 0d | Labour [641.75 h]; Engineer [641.75 h]; Supervisor [641.75 h]; Surveyor [641.75 h] | 1,926 | MEP&LV |
| LPZD-1010 |  | POLES INSTALLATION | 38d | 2015-05-19 | 2015-06-26 | LPZD-1000 | 39d | 38.75d | Labour [643 h]; Supervisor [643 h]; Surveyor [643 h]; Mobile Crane [643 h] | 1,929 | MEP&LV |
|  | 5 | **COMMUNICATION DUCT BANK STATION** |  | 2014-10-16 | 2015-06-21 |  |  |  |  |  |  |
|  | 1 | **ZONE-A (0+000 --- 4+000)** |  | 2014-10-16 | 2015-03-14 |  |  |  |  |  |  |
| CDBZA-1000 |  | TRENCH FOR DUCT FOR DUCT BANK | 31.25d | 2014-10-16 | 2014-11-16 | MVZA-1000 SS | 29.75d | 0d | Labour [168 h]; Excavator [168 h]; Surveyor [168 h]; Supervisor [168 h] | 336 | MEP&LV |
| CDBZA-1010 |  | CONDUITS LAYING | 31.25d | 2014-11-16 | 2014-12-17 | CDBZA-1000 | 29.75d | 0d | Labour [280.33 h]; Supervisor [280.33 h]; Engineer [280.33 h] | 560 | MEP&LV |
| CDBZA-1020 |  | FORM WORK & REBARS | 18.75d | 2014-12-17 | 2015-01-05 | CDBZA-1010 | 29.75d | 0d | Labour [266.25 h]; CARPANTER [266.25 h]; Steel Fixer [266.25 h]; Supervisor [266.25 h] | 798 | MEP&LV |
| CDBZA-1030 |  | CONCRETE | 25d | 2015-01-05 | 2015-01-30 | CDBZA-1020 | 29.75d | 0d | Labour [168 h]; Supervisor [168 h]; Concrete Pump [168 h]; Engineer [168 h] | 504 | MEP&LV |
| CDBZA-1040 |  | WARNING TAPE (ORANGE COLOR) | 18.75d | 2015-01-30 | 2015-02-17 | CDBZA-1030 | 29.75d | 0d | Labour [302.5 h]; Supervisor [302.5 h] | 303 | MEP&LV |
| CDBZA-1050 |  | BACKFILLING | 25d | 2015-02-18 | 2015-03-14 | CDBZA-1040 | 29.75d | 29.5d | Labour [196.25 h]; Supervisor [196.25 h]; Dump Truck [196.25 h]; Compactor [196.25 h] | 392 | MEP&LV |

| ID | WBS | Activity | Duration | Start | Finish | Predecessors | Total float | Free float | Resources | Cost | Devision-15 |
| --- | --- | --- | --- | --- | --- | --- | --- | --- | --- | --- | --- |
|  | 2 | **ZONE-B (4+100 --- 7+000)** |  | 2015-01-21 | 2015-06-21 |  |  |  |  |  |  |
| CDBZB-1000 |  | TRENCH FOR DUCT FOR DUCT BANK | 28d | 2015-01-21 | 2015-02-18 | MVZB-1000 FS+30d | 13.25d | 0d | Labour [155.25 h]; Excavator [155.25 h]; Surveyor [155.25 h]; Supervisor [155.25 h] | 310 | MEP&LV |
| CDBZB-1010 |  | CONDUITS LAYING | 23d | 2015-02-18 | 2015-03-13 | CDBZB-1000 | 13.25d | 0d | Labour [258.67 h]; Supervisor [258.67 h]; Engineer [258.67 h] | 518 | MEP&LV |
| CDBZB-1020 |  | FORM WORK & REBARS | 31.25d | 2015-03-13 | 2015-04-13 | CDBZB-1010 | 13.25d | 0d | Labour [245.75 h]; CARPANTER [245.75 h]; Steel Fixer [245.75 h]; Supervisor [245.75 h] | 738 | MEP&LV |
| CDBZB-1030 |  | CONCRETE | 28d | 2015-04-14 | 2015-05-11 | CDBZB-1020 | 13.25d | 0d | Labour [155.25 h]; Supervisor [155.25 h]; Concrete Pump [155.25 h]; Engineer [155.25 h] | 465 | MEP&LV |
| CDBZB-1040 |  | WARNING TAPE (ORANGE COLOR) | 23d | 2015-05-12 | 2015-06-03 | CDBZB-1030 | 13.25d | 0d | Labour [279.5 h]; Supervisor [279.5 h] | 280 | MEP&LV |
| CDBZB-1050 |  | BACKFILLING | 18d | 2015-06-04 | 2015-06-21 | CDBZB-1040, CDBZD-1050 FF | 13.25d | 13d | Labour [181 h]; Supervisor [181 h]; Dump Truck [181 h]; Compactor [181 h] | 362 | MEP&LV |
|  | 3 | **ZONE-C (7+100 --- 10+900)** |  | 2014-12-22 | 2015-05-28 |  |  |  |  |  |  |
| CDBZC-1000 |  | TRENCH FOR DUCT FOR DUCT BANK | 33d | 2014-12-22 | 2015-01-24 | MVZC-1000 SS | 18.5d | 0d | Labour [168 h]; Excavator [168 h]; Surveyor [168 h]; Supervisor [168 h] | 336 | MEP&LV |
| CDBZC-1010 |  | CONDUITS LAYING | 31d | 2015-01-24 | 2015-02-24 | CDBZC-1000 | 18.5d | 0d | Labour [280.33 h]; Supervisor [280.33 h]; Engineer [280.33 h] | 560 | MEP&LV |
| CDBZC-1020 |  | FORM WORK & REBARS | 26d | 2015-02-24 | 2015-03-22 | CDBZC-1010 | 18.5d | 0d | Labour [266.25 h]; CARPANTER [266.25 h]; Steel Fixer [266.25 h]; Supervisor [266.25 h] | 798 | MEP&LV |
| CDBZC-1030 |  | CONCRETE | 23d | 2015-03-22 | 2015-04-14 | CDBZC-1020 | 18.5d | 0d | Labour [168 h]; Supervisor [168 h]; Concrete Pump [168 h]; Engineer [168 h] | 504 | MEP&LV |
| CDBZC-1040 |  | WARNING TAPE (ORANGE COLOR) | 26d | 2015-04-14 | 2015-05-10 | CDBZC-1030 | 18.5d | 0d | Labour [302.5 h]; Supervisor [302.5 h] | 303 | MEP&LV |
| CDBZC-1050 |  | BACKFILLING | 18d | 2015-05-10 | 2015-05-28 | CDBZC-1040 | 18.5d | 0d | Labour [196.25 h]; Supervisor [196.25 h]; Dump Truck [196.25 h]; Compactor [196.25 h] | 392 | MEP&LV |
|  | 4 | **ZONE-D (11+000 --- 14+820)** |  | 2015-01-04 | 2015-06-16 |  |  |  |  |  |  |
| CDBZD-1000 |  | TRENCH FOR DUCT FOR DUCT BANK | 25d | 2015-01-04 | 2015-01-29 | MVZD-1000 SS+18d | 19.5d | 0d | Labour [155.25 h]; Excavator [155.25 h]; Surveyor [155.25 h]; Supervisor [155.25 h] | 310 | MEP&LV |
| CDBZD-1010 |  | CONDUITS LAYING | 23d | 2015-01-29 | 2015-02-21 | CDBZD-1000 | 19.5d | 0d | Labour [258.67 h]; Supervisor [258.67 h]; Engineer [258.67 h] | 518 | MEP&LV |
| CDBZD-1020 |  | FORM WORK & REBARS | 36d | 2015-02-21 | 2015-03-29 | CDBZD-1010 | 19.5d | 0d | Labour [245.75 h]; CARPANTER [245.75 h]; Steel Fixer [245.75 h]; Supervisor [245.75 h] | 738 | MEP&LV |
| CDBZD-1030 |  | CONCRETE | 33d | 2015-03-29 | 2015-05-01 | CDBZD-1020 | 19.5d | 0d | Labour [155.25 h]; Supervisor [155.25 h]; Concrete Pump [155.25 h]; Engineer [155.25 h] | 465 | MEP&LV |
| CDBZD-1040 |  | WARNING TAPE (ORANGE COLOR) | 26d | 2015-05-01 | 2015-05-27 | CDBZD-1030 | 19.5d | 1d | Labour [279.5 h]; Supervisor [279.5 h] | 280 | MEP&LV |
| CDBZD-1050 |  | BACKFILLING | 19d | 2015-05-28 | 2015-06-16 | CDBZD-1040, CDBZC-1050 | 18.5d | 5.25d | Labour [181 h]; Supervisor [181 h]; Dump Truck [181 h]; Compactor [181 h] | 362 | MEP&LV |
|  | 6 | **MISCELLANEOUS COMMUNICATION ITEMS** |  | 2015-04-06 | 2015-06-22 |  |  |  |  |  |  |
|  | 1 | **ZONE-A (0+000 --- 4+000)** |  | 2015-04-20 | 2015-06-22 |  |  |  |  |  |  |
| MCZA-1000 |  | OUTLETS, INTERNAL CONDUITS, BOXES & TAPES ETC | 62.5d | 2015-04-20 | 2015-06-22 | LPZA-1000 SS, MCZB-1000 FF, MCZC-1000 FF, MCZD-1000 FF | 23d | 22.75d | Labour [1469.25 h]; Engineer [1469.25 h]; Supervisor [1469.25 h]; Technician [1469.25 h] | 2,938 | MEP&LV |

| ID | WBS | Activity | Duration | Start | Finish | Predecessors | Total float | Free float | Constraint | Resources | Cost | Devision-15 |
| --- | --- | --- | --- | --- | --- | --- | --- | --- | --- | --- | --- | --- |
|  | 2 | **ZONE-B (4+100 --- 7+000)** |  | 2015-04-15 | 2015-06-02 |  |  |  |  |  |  |  |
| MCZB-1000 |  | OUTLETS, INTERNAL CONDUITS, BOXES & TAPES ETC | 48d | 2015-04-15 | 2015-06-02 | LPZB-1000 | 26.75d | 0d |  | Labour [1356.25 h]; Engineer [1356.25 h]; Supervisor [1356.25 h]; Technician [1356.25 h] | 2,712 | MEP&LV |
|  | 3 | **ZONE-C (7+100 --- 10+900)** |  | 2015-04-06 | 2015-06-20 |  |  |  |  |  |  |  |
| MCZC-1000 |  | OUTLETS, INTERNAL CONDUITS, BOXES & TAPES ETC | 76d | 2015-04-06 | 2015-06-20 | LPZC-1000 SS+2.5d | 24.25d | 1.25d |  | Labour [1469.25 h]; Engineer [1469.25 h]; Supervisor [1469.25 h]; Technician [1469.25 h] | 2,938 | MEP&LV |
|  | 4 | **ZONE-D (11+000 --- 14+820)** |  | 2015-04-20 | 2015-06-22 |  |  |  |  |  |  |  |
| MCZD-1000 |  | OUTLETS, INTERNAL CONDUITS, BOXES & TAPES ETC | 63d | 2015-04-20 | 2015-06-22 | LPZD-1000 SS | 4.75d | 0d |  | Labour [1356.25 h]; Engineer [1356.25 h]; Supervisor [1356.25 h]; Technician [1356.25 h] | 2,712 | MEP&LV |
|  | 5 | **CONSTRUCTION OF SECURITY SYSTEMS** |  | 2014-09-02 | 2015-07-29 |  |  |  |  |  |  |  |
|  | 1 | **CONSTRUCTION OF MARINE SECURITY (OFF SHORE)** |  | 2014-09-02 | 2015-03-27 |  |  |  |  |  |  |  |
|  | 4 | **BOAT AUTOMATIC IDENTIFICATION SYSTEM** |  | 2014-12-01 | 2015-03-27 |  |  |  |  |  |  |  |
| BAIS-1000 |  | LOCATION SURVEYING & FOUNDATION | 37.5d | 2014-12-01 | 2015-01-07 | SON-1000 | 31.5d | 0d |  | Labour [475 h]; Surveyor [475 h]; Supervisor [475 h]; Engineer [475 h] | 1,425 | MEP&LV |
| BAIS-1010 |  | SYSTEM INSTALLATION | 79d | 2015-01-07 | 2015-03-27 | BAIS-1000 | 31.5d | 28.25d |  | Labour [1243.8 h]; Engineer [1243.8 h]; Supervisor [1243.8 h]; Technician [1243.8 h]; Surveyor [1243.8 h] | 3,732 | MEP&LV |
|  | 3 | **VESEL BARRIER** |  | 2014-10-03 | 2015-01-05 |  |  |  |  |  |  |  |
| VBA-1000 |  | ROPE TIE FOUNDATION | 30d | 2014-10-03 | 2014-11-01 | MSTS1110 | -0d | 0d | start on 2014-10-03 | Labour [584.75 h]; Engineer [584.75 h]; Supervisor [584.75 h]; Surveyor [584.75 h] | 1,755 | MEP&LV |
| VBA-1010 |  | VESSEL BARRIER LAYING | 65d | 2014-11-02 | 2015-01-05 | VBA-1000 | 22d | 0d |  | Labour [1058 h]; Engineer [1058 h]; Supervisor [1058 h]; Surveyor [1058 h]; Mobile Crane [1058 h] | 4,232 | MEP&LV |
|  | 1 | **SONAR SYSTEM** |  | 2014-09-02 | 2015-03-07 |  |  |  |  |  |  |  |
| SON-1000 |  | FOUNDATION WORKS | 90d | 2014-09-02 | 2014-11-30 | VBA-1000 SS-31d | 31.5d | 0d |  | Labour [316.75 h]; Engineer [316.75 h]; Supervisor [316.75 h]; Surveyor [316.75 h] | 951 | MEP&LV |
| SON-1010 |  | SYSTEM INSTALLATION | 61d | 2015-01-06 | 2015-03-07 | SON-1000, VBA-1010 | 22d | 18.75d |  | Labour [1236.8 h]; Engineer [1236.8 h]; Supervisor [1236.8 h]; Technician [1236.8 h]; Surveyor [1236.8 h] | 3,711 | MEP&LV |
|  | 2 | **RADAR SYSTEM** |  | 2014-11-06 | 2015-01-10 |  |  |  |  |  |  |  |
| RAD-1000 |  | SYSTEM INSTALLATION | 66d | 2014-11-06 | 2015-01-10 | VBA-1010 SS+4d | 47d | 10.5d |  | Labour [1347.6 h]; Engineer [1347.6 h]; Supervisor [1347.6 h]; Technician [1347.6 h]; Surveyor [1347.6 h] | 4,044 | MEP&LV |
|  | 2 | **CONSTRUCTION OF SECURITY FACILITIES (ON SHORE)** |  | 2014-09-04 | 2015-07-29 |  |  |  |  |  |  |  |
|  | 1 | **INTRUSION DETECTION & ASSESSMENT SYSTEM** |  | 2015-01-10 | 2015-04-20 |  |  |  |  |  |  |  |
| CSF-1000 |  | INTRUSION DETECTION & ASSESMENT SYSTEM INSTALLATION | 100d | 2015-01-10 | 2015-04-20 | CSF-1070 SS+128d | 37.25d | 34d |  | Labour [4210.8 h]; Engineer [4210.8 h]; Supervisor [4210.8 h]; Technician [4210.8 h]; Surveyor [4210.8 h] | 12,633 | MEP&LV |
|  | 2 | **SECURITY ACCESS CONTROL SYSEM (SACS)** |  | 2015-01-21 | 2015-04-21 |  |  |  |  |  |  |  |
| CSF-1010 |  | SACS (RADAR & THERMAL DETECTION SYSTEM) | 90d | 2015-01-21 | 2015-04-21 | RAD-1000, LPZC-1010 FS-151d, LPZC-1000 FS-151d | 36.5d | 33.25d |  | Labour [3190.6 h]; Engineer [3190.6 h]; Supervisor [3190.6 h]; Technician [3190.6 h]; Surveyor [3190.6 h] | 9,573 | MEP&LV |

| ID | WBS | Activity | Duration | Start | Finish | Predecessors | Total float | Free float | Resources | Cost | Devision-15 |
| --- | --- | --- | --- | --- | --- | --- | --- | --- | --- | --- | --- |
|  | 4 | **DROPED ARM & HYDRAULIC CRASH BARRIER** |  | 2015-03-25 | 2015-06-17 |  |  |  |  |  |  |
|  | 1 | **PROPOSED GATE # 2** |  | 2015-03-25 | 2015-06-17 |  |  |  |  |  |  |
| CSF-1030 |  | DROP ARM & CRASH BARRIER FOUNDATION & SYSTEN INSTALLATION | 85d | 2015-03-25 | 2015-06-17 | EATS-1010 FS+18d | 9d | 0d | Labour [791 h]; Engineer [791 h]; Supervisor [791 h]; Technician [791 h] | 1,582 | MEP&LV |
|  | 2 | **PROPOSED GATE # 3** |  | 2015-03-25 | 2015-06-17 |  |  |  |  |  |  |
| CSF-1040 |  | DROP ARM & CRASH BARRIER FOUNDATION & SYSTEN INSTALLATION | 85d | 2015-03-25 | 2015-06-17 | EATS-1010 FS+18d | 16d | 0d | Labour [791 h]; Engineer [791 h]; Supervisor [791 h]; Technician [791 h] | 1,582 | MEP&LV |
|  | 5 | **REDIO FREQUENCY IDENTIFICATION SYSTEM** |  | 2014-09-04 | 2015-06-23 |  |  |  |  |  |  |
|  | 1 | **ZONE-A (0+000 --- 4+000)** |  | 2015-02-21 | 2015-06-07 |  |  |  |  |  |  |
| CSF-1050 |  | RADIO FREQUENCY SYSTEM INSTALLATION | 106.25d | 2015-02-21 | 2015-06-07 | MVZA-1010 | 19.25d | 16d | Labour [580 h]; Engineer [580 h]; Supervisor [580 h]; Technician [580 h]; Surveyor [580 h] | 1,740 | MEP&LV |
|  | 2 | **ZONE-B (4+100 --- 7+000)** |  | 2015-01-28 | 2015-05-30 |  |  |  |  |  |  |
| CSF-1060 |  | RADIO FREQUENCY SYSTEM INSTALLATION | 122.5d | 2015-01-28 | 2015-05-30 | MVZB-1010 SS+30d | 27.5d | 24.25d | Labour [550.8 h]; Engineer [550.8 h]; Supervisor [550.8 h]; Technician [550.8 h]; Surveyor [550.8 h] | 1,653 | MEP&LV |
|  | 3 | **ZONE-C (7+100 --- 10+900)** |  | 2014-09-04 | 2015-03-28 |  |  |  |  |  |  |
| CSF-1070 |  | RADIO FREQUENCY SYSTEM INSTALLATION | 205d | 2014-09-04 | 2015-03-28 | MVZC-1010 SS-167d | 37.25d | 0d | Labour [849.6 h]; Engineer [849.6 h]; Supervisor [849.6 h]; Technician [849.6 h]; Surveyor [849.6 h] | 2,550 | MEP&LV |
|  | 4 | **ZONE-D (11+000 --- 14+820)** |  | 2015-02-18 | 2015-06-23 |  |  |  |  |  |  |
| CSF-1080 |  | RADIO FREQUENCY SYSTEM INSTALLATION | 125d | 2015-02-18 | 2015-06-23 | MVZD-1010 SS | 3.25d | 0d | Labour [550.8 h]; Engineer [550.8 h]; Supervisor [550.8 h]; Technician [550.8 h]; Surveyor [550.8 h] | 1,653 | MEP&LV |
|  | 3 | **ALL CLOSED-CIRCUIT SYSTEM** |  | 2015-03-30 | 2015-07-29 |  |  |  |  |  |  |
| CSF-1020 |  | CCTV & MONITORING SYSTEM | 121d | 2015-03-30 | 2015-07-29 | CSF-1070 SS+37.5d, CSF-1080 SS+40d | 5.5d | 5.25d | Labour [3190.6 h]; Engineer [3190.6 h]; Supervisor [3190.6 h]; Technician [3190.6 h]; Surveyor [3190.6 h] | 9,573 | MEP&LV |
|  | 8 | **REMAINING SECURITY WORKS** |  | 2015-04-18 | 2015-06-16 |  |  |  |  |  |  |
| CSF-1130 |  | OTHER SECURITY MISCELLANEOUS WORKS (IP TELEPHONE, WIRELESS ACCESS & IP TV etc,) | 59d | 2015-04-18 | 2015-06-16 | MVZD-1000 FS+59d | 10.25d | 7d | Engineering [6174.56 h]; Technician [38.36 h]; Surveyor [38.36 h]; Supervisor [38.36 h]; Labour [38.36 h] | 6,251 | MEP&LV |
|  | 6 | **LICENSE PLAT RECOGNITION SYSTEM (LPRS)** |  | 2015-04-17 | 2015-05-15 |  |  |  |  |  |  |
|  | 1 | **PROPOSED GATE # 2** |  | 2015-04-17 | 2015-05-15 |  |  |  |  |  |  |
| CSF-1090 |  | SYSTEM INSTALLATION | 29d | 2015-04-17 | 2015-05-15 | CSF-1030 SS+23d | 16d | 0d | Labour [499 h]; Engineer [499 h]; Supervisor [499 h]; Technician [499 h]; Surveyor [499 h] | 1,497 | MEP&LV |
|  | 2 | **PROPOSED GATE # 3** |  | 2015-04-17 | 2015-05-15 |  |  |  |  |  |  |
| CSF-1100 |  | SYSTEM INSTALLATION | 29d | 2015-04-17 | 2015-05-15 | CSF-1040 SS+23d | 16d | 0d | Labour [499.2 h]; Engineer [499.2 h]; Supervisor [499.2 h]; Technician [499.2 h]; Surveyor [499.2 h] | 1,497 | MEP&LV |
|  | 7 | **INSTALLATION & CONSTRUCTION OF UVIS** |  | 2015-04-17 | 2015-06-10 |  |  |  |  |  |  |
|  | 1 | **PROPOSED GATE # 2** |  | 2015-04-17 | 2015-06-10 |  |  |  |  |  |  |
| CSF-1110 |  | UNDER VEHICLE INSPECTION & VEHICLE X-RAY SYSTEM | 55d | 2015-04-17 | 2015-06-10 | CSF-1090 SS | 16d | 12.75d | Labour [632.8 h]; Engineer [632.8 h]; Supervisor [632.8 h]; Technician [632.8 h]; Surveyor [632.8 h] | 1,899 | MEP&LV |

| ID | WBS | Activity | Duration | Start | Finish | Predecessors | Total float | Free float | Resources | Cost | Devision-15 | Devision-01 |
| --- | --- | --- | --- | --- | --- | --- | --- | --- | --- | --- | --- | --- |
|  | 2 | **PROPOSED GATE # 3** |  | 2015-04-17 | 2015-06-10 |  |  |  |  |  |  |  |
| CSF-1120 |  | UNDER VEHICLE INSPECTION & VEHICLE X-RAY SYSTEM | 55d | 2015-04-17 | 2015-06-10 | CSF-1100 SS | 16d | 12.75d | Labour [632.8 h]; Engineer [632.8 h]; Supervisor [632.8 h]; Technician [632.8 h]; Surveyor [632.8 h] | 1,899 | MEP&LV |  |
|  | 4 | **COMMISSIONING** |  | 2015-06-23 | 2015-10-30 |  |  |  |  |  |  |  |
|  | 6 | **PRE COMMISSIONING** |  | 2015-06-23 | 2015-08-26 |  |  |  |  |  |  |  |
| PRC-1070 |  | PRE COMMISSIONING OF SECURITY SYSTEMS | 60d | 2015-06-23 | 2015-08-22 | BAIS-1010 FS+60d, VBA-1010 SS, SON-1010 SS+150d, RAD-1000 FS+30d, CSF-1000 FS+30d, CSF-1010 FS+30d, CSF-1030, CSF-1040 SS, CSF-1050, CSF-1060, CSF-1070 SS, CSF-1080, CSF-1020 SS, CSF-1090, CSF-1100, CSF-1110, CSF-1120, CSF-1130, MS-1220 FF+13.75d | 3.25d | 3.5d | Engineering [13066 h] | 13,066 |  | MOB |
| PRC-1000 |  | PRE COMMISSIONING OF COMMUNICATION SYSTEM | 60d | 2015-06-27 | 2015-08-25 | ZBDI-1080 SS, ZCDI-1080 SS, MS-1240 FS+3.5d, MCZD-1000 | 0d | 0.25d | Engineer [12901 h] | 12,901 |  | MOB |
| PRC-1060 |  | PRE COMMISSIONING BUILDINGS | 15d | 2015-08-10 | 2015-08-25 | CBAPG-1310, CBEPG-1160, CBATS-1310, CBETS-1160, CBEJFC-1160, CBAJFC-1310, CBEQRT-1160 FS+150d, CBAQRT-1320, CBEUPS-1160, CBAUPS-1320, CCG-2-1000 FF, CCG-2-1010, CCG-2-1020, CCG-2-1030, CCG-2-1040, BBS1040, BSS-1010, CBMUPS-1250, UPS1020, MS-1210 FS+0.5d | 0.25d | 0.5d | Engineering [9341 h] | 9,341 |  | MOB |
| PRC-1010 |  | PRE COMMISSIONING OF SECURITY FENCE | 15d | 2015-08-11 | 2015-08-26 | ZBF-1170, ZBF-1230 FF+6.25d, ZCF-1290, ZCF-1350, ZDF-1410, ZDF-1470, ZAF-1110, ZAF-1050, MS-1230 FF+9d | -0.25d | 0d | Engineer [10387 h] | 10,387 |  | MOB |
| PRC-1080 |  | PRE COMMISSIONING EXCEPTION ITEMS | 15d | 2015-08-11 | 2015-08-26 | PRC-1000 SS, PRC-1060 SS, PRC-1070 SS, PRC-1000 FF, PRC-1010 FF, PRC-1060 FF, PRC-1070 FF | -0.25d | 0d | Engineering [9725 h] | 9,725 |  | MOB |
|  | 5 | **START UP & COMMISSIONING** |  | 2015-08-11 | 2015-10-01 |  |  |  |  |  |  |  |
| PRC-1020 |  | CLEARING EIL | 15d | 2015-08-11 | 2015-08-26 | PRC-1010 FS-15d, PRC-1080 SS, ZCPR-1070 FF | -0.25d | 0d | Engineer [6936 h] | 6,936 |  | MOB |
| PRC-1030 |  | COMPLETE MECHANICAL COMPLETION CERTIFICATE | 6d | 2015-08-26 | 2015-09-01 | PRC-1020, ZDPR-1070 FF | -0.25d | 0d | Engineer [7605 h] | 7,605 |  | MOB |
| PRC-1040 |  | COMMISSIONING ASSISTANCE | 15d | 2015-09-01 | 2015-09-16 | PRC-1030 | -0.25d | 0d | Engineer [6138 h] | 6,138 |  | MOB |
| PRC-1050 |  | COMPLETE PERFORMANCE ACCEPTANCE CERTIFICATE OF ALL WORKS | 15d | 2015-09-16 | 2015-10-01 | PRC-1040 | -0.25d | 0d | Engineer [3048 h] | 3,048 |  | MOB |
|  | 1 | **DEMOBILIZATION** |  | 2015-10-01 | 2015-10-30 |  |  |  |  |  |  |  |
| DMOB-1000 |  | DEMOBILIZATION OF SITE OFFICE, TEMPORARY FENCES AND EQUIPMENTS | 29.5d | 2015-10-01 | 2015-10-30 | PRC-1020 FF+20.5d, PRC-1050 | -0.25d | 0d | Engineer [219.67 h]; Supervisor [219.67 h]; Mobile Crane [219.67 h] | 440 |  | MOB |
| DMOB-1010 |  | HANDING OVER | 9.5d | 2015-10-21 | 2015-10-30 | DMOB-1000 FF | -0.25d | 0d |  |  |  | MOB |

## Activity codes

| Code | Value | Meaning |
| --- | --- | --- |
| Devision-01 | ENG | Engineering |
| Devision-01 | MOB | Mobilization |
| Devision-02 | DFCR | Ditch, Fence, Culverts & Roads (Earth Wroks) 220,655,058 |
| Devision-03 | BCW | Buildings Concrete Works |
| Devision-04 | BMW | Buildings Mesonary Works |
| Devision-05 | BMTW | Buildings Metal Works |
| Devision-06 | BWP | Buildings Wood & Plastic Works |
| Devision-07 | BTI | Buildings thermal & Insulation Works |
| Devision-08 | BDW | Buildings Doors & Windows |
| Devision-09 | BFW | Buildings Finishing Works |
| Devision-15 | MEP&LV | BUILDING MEP & LOW VOLTAGE WORKS |
| FCC Scope | BVFC | Blinding, Vapors, Foundation & Coloums |
